# PAQUETE 08 RIO CHICAMA TRAMO 3: 15+800 - 30+000

Schedule from Primavera P6, 2024-11-04 to 2026-01-24, data date 2024-11-04.
Must finish by 2026-01-21

## Calendars

- 1T - 7x0 - 8 hr: Mon-Sun 08:00-16:00.

## Resources

| Resource | Group |
| --- | --- |
| HH | labor |

## Schedule

| ID | WBS | Activity | Type | Duration | Start | Finish | Predecessors | Total float | Free float | Resources | RCuad | Cuadrilla día | FDur | Cuadrilla | Rendimiento | Metrado | Unidad | Turno | Dur. Cal. | FactorR |
| --- | --- | --- | --- | --- | --- | --- | --- | --- | --- | --- | --- | --- | --- | --- | --- | --- | --- | --- | --- | --- |
|  | 0 | **HITOS** |  |  | 2024-11-04 | 2026-01-24 |  |  |  |  |  |  |  |  |  |  |  |  |  |  |
| A1000 |  | Inicio de obra - Acceso al Sitio | milestone | 0d | 2024-11-04 | 2024-11-04 |  | -3d | 0d |  | 0 | 0 | 0 |  |  |  |  |  |  |  |
| A1010 |  | Culminación de obras | milestone | 0d | 2026-01-24 | 2026-01-24 | A1220, A1250, A1030 FF | -3d | 0d |  | 0 | 0 | 0 |  |  |  |  |  |  |  |
|  | 1 | **OBRAS PRELIMINARES** |  |  | 2024-11-04 | 2026-01-24 |  |  |  |  |  |  |  |  |  |  |  |  |  |  |
|  | 1 | **MOVILIZACIÓN Y DESMOVILIZACIÓN** |  |  | 2024-11-04 | 2026-01-24 |  |  |  |  |  |  |  |  |  |  |  |  |  |  |
| A1020 |  | Movilización de equipos a obra |  | 25d | 2024-11-04 | 2024-11-28 | A1000 | -3d | 0d | HH [200 h] | 0 | 0 | 0 |  |  |  |  |  |  |  |
| A1030 |  | Desmovilización de equipos a obra |  | 11d | 2026-01-14 | 2026-01-24 | A1060, A1160, A1210, A1240, A1260, A1280, A1290, A1230, A4780, A4720 | -3d | 0d | HH [88 h] | 0 | 0 | 0 |  |  |  |  |  |  |  |
|  | 2 | **TRAZO Y REPLANTEO** |  |  | 2024-11-14 | 2026-01-07 |  |  |  |  |  |  |  |  |  |  |  |  |  |  |
| A1040 |  | Trazo y replanteo topográfico al inicio de obra |  | 15d | 2024-11-14 | 2024-11-28 | A1020 FF | -3d | 0d | HH [120 h] | 0 | 0 | 0 |  |  |  |  |  |  |  |
| A1041 |  | Trazo y replanteo topográfico durante la ejecución de obra |  | 390d | 2024-11-29 | 2025-12-23 | A1040 | 3d | 0d |  | 0 | 0 | 0 |  |  |  |  |  |  |  |
| A1060 |  | Levantamiento topografico final de obra |  | 15d | 2025-12-24 | 2026-01-07 | A1041 | 3d | 6d | HH [120 h] | 0 | 0 | 0 |  |  |  |  |  |  |  |
|  | 3 | **ACCESOS** |  |  | 2024-11-05 | 2025-12-29 |  |  |  |  |  |  |  |  |  |  |  |  |  |  |
|  | 2 | **REHABILITACIÓN DE ACCESOS EXISTENTES** |  |  | 2024-11-05 | 2025-02-02 |  |  |  |  |  |  |  |  |  |  |  |  |  |  |
| A4660 |  | Rehabilitación de accesos existentes |  | 90d | 2024-11-05 | 2025-02-02 | A1000 SS+1d | 12d | 0d | HH [720 h] | 0 | 0 | 0 |  |  |  |  |  |  |  |
| A4670 |  | Suministro, transporte e instalación de alcantarillas HDPE corrugada DN 600 mm, para cruce sobre canal |  | 90d | 2024-11-05 | 2025-02-02 | A4660 SS | 342d | 0d |  | 0 | 0 | 0 |  |  |  |  |  |  |  |
| A4680 |  | Suministro, transporte e instalación de alcantarillas HDPE corrugada DN 750 mm, para cruce sobre canal |  | 90d | 2024-11-05 | 2025-02-02 | A4670 SS | 342d | 0d |  | 0 | 0 | 0 |  |  |  |  |  |  |  |
| A4790 |  | Suministro, transporte e instalación de alcantarillas HDPE corrugada DN 900 mm, para cruce sobre canal |  | 90d | 2024-11-05 | 2025-02-02 | A4680 SS | 342d | 0d |  | 0 | 0 | 0 |  |  |  |  |  |  |  |
| A5240 |  | Suministro, transporte e instalación de alcantarillas HDPE corrugada DN 1200 mm, para cruce sobre canal |  | 90d | 2024-11-05 | 2025-02-02 | A4790 SS | 342d | 59d |  | 0 | 0 | 0 |  |  |  |  |  |  |  |
|  | 3 | **MANTENIMIENTO DE ACCESOS** |  |  | 2024-11-20 | 2025-12-29 |  |  |  |  |  |  |  |  |  |  |  |  |  |  |
| A1160 |  | Mantenimiento de accesos (L<15 km) |  | 405d | 2024-11-20 | 2025-12-29 | A4660 SS+15d | 12d | 15d | HH [3240 h] | 0 | 0 | 0 |  |  |  |  |  |  |  |
|  | 1 | **CONSTRUCCIÓN DE ACCESO NUEVO** |  |  | 2024-11-18 | 2024-12-26 |  |  |  |  |  |  |  |  |  |  |  |  |  |  |
| A1070 |  | Desbroce y remoción de suelo vegetal con equipo |  | 8d | 2024-11-18 | 2024-11-25 | A4660 SS+13d | 14d | 0d | HH [64 h] | 10000 | 1 | 7.75319799 | 1 | 10000 | 63034.13 | m2 | 1 | 6.303413 | 1.23 |
| A1071 |  | Transporte de material excedente a DMO, d=1km |  | 8d | 2024-11-18 | 2024-11-25 | A1070 SS | 14d | 0d |  | 0 | 0 | 0 |  |  | 27735.02 | m3k |  |  |  |
| A1072 |  | Transporte de material excedente a DMO, d>1km |  | 8d | 2024-11-18 | 2024-11-25 | A1071 SS | 14d | 3d |  | 0 | 0 | 0 |  |  | 719506.78 | m3k |  |  |  |
| A1080 |  | Excavación en material común para accesos |  | 30d | 2024-11-18 | 2024-12-17 | A1070 SS | 23d | 0d | HH [240 h] | 1000 | 1 | 28.5804153 | 1 | 1000 | 23236.11 | m3 | 1 | 23.23611 | 1.23 |
| A1090 |  | Transporte de material excedente a DME, d=1km |  | 30d | 2024-11-18 | 2024-12-17 | A1080 SS | 32d | 0d |  | 0 | 0 | 0 |  |  | 9752.13 | m3k |  |  |  |
| A1100 |  | Transporte de material excedente a DME, d>1km |  | 30d | 2024-11-18 | 2024-12-17 | A1090 SS | 32d | 9d |  | 0 | 0 | 0 |  |  | 58596.15 | m3k |  |  |  |
| A1110 |  | Relleno compactado con equipo pesado para accesos |  | 34d | 2024-11-23 | 2024-12-26 | A1080 SS+5d | 23d | 0d | HH [272 h] | 450 | 1 | 33.221316 | 1 | 450 | 12154.14 | m3 | 1 | 27.0092 | 1.23 |

| ID | WBS | Activity | Duration | Start | Finish | Predecessors | Total float | Free float | Resources | RCuad | Cuadrilla día | FDur | Rendimiento | Metrado | Unidad | Cuadrilla | Turno | Dur. Cal. | FactorR |
| --- | --- | --- | --- | --- | --- | --- | --- | --- | --- | --- | --- | --- | --- | --- | --- | --- | --- | --- | --- |
|  | 4 | **ACCESO EN CAUCE DE RÍO** |  | 2024-12-27 | 2025-12-29 |  |  |  |  |  |  |  |  |  |  |  |  |  |  |
| A1170 |  | Habilitación de acceso temporal en cauce de río. (Inc. Colocación y Retiro de alcantarilla) | 368d | 2024-12-27 | 2025-12-29 | A1110, A4660 SS+30d, A1100 | 23d | 0d | HH [2944 h] | 0 | 0 | 0 |  |  |  |  |  |  |  |
|  | 4 | **CAMPAMENTOS** |  | 2024-11-29 | 2025-12-30 |  |  |  |  |  |  |  |  |  |  |  |  |  |  |
|  | 1 | **CONSTRUCCIÓN DE CAMPAMENTOS (TALLERES, ALMACENES Y OFICINAS)** |  | 2024-11-29 | 2024-12-17 |  |  |  |  |  |  |  |  |  |  |  |  |  |  |
| A1180 |  | Desbroce y remoción de suelo vegetal con equipo | 1d | 2024-11-29 | 2024-11-29 | A1040 | 11d | 0d | HH [8 h] | 0 | 0 | 0 | 10000 | 1811.12 | m2 |  |  |  |  |
| A1181 |  | Transporte de material excedente a DMO, d=1km | 1d | 2024-11-29 | 2024-11-29 | A1180 SS, A1072 | 11d | 0d |  | 0 | 0 | 0 |  | 4292.2 | m3k |  |  |  |  |
| A1190 |  | Conformación de terraplén para campamentos | 8d | 2024-11-30 | 2024-12-07 | A1180, A1181 | 11d | 0d | HH [64 h] | 0 | 0 | 0 | 1500 | 9038.29 | m2 |  |  |  |  |
| A1200 |  | Construcción de campamentos | 10d | 2024-12-08 | 2024-12-17 | A1190 | 11d | 0d | HH [80 h] | 0 | 0 | 0 |  |  |  |  |  |  |  |
|  | 2 | **MANTENIMIENTO DE CAMPAMENTOS** |  | 2024-12-23 | 2025-12-30 |  |  |  |  |  |  |  |  |  |  |  |  |  |  |
| A1210 |  | Mantenimiento de campamentos | 373d | 2024-12-23 | 2025-12-30 | A1200 SS+15d | 11d | 14d | HH [2984 h] | 0 | 0 | 0 |  |  |  |  |  |  |  |
|  | 5 | **DESVÍO TEMPORAL DEL RÍO** |  | 2025-01-06 | 2025-10-07 |  |  |  |  |  |  |  |  |  |  |  |  |  |  |
| A1220 |  | Conformación de ataguía para desvío temporal de cauce de río | 275d | 2025-01-06 | 2025-10-07 | A1170 SS+10d | 79d | 0d | HH [2200 h] | 1000 | 1 | 274.5102069 | 1000 | 223179.03 | m3 | 1 | 1 | 223.17903 | 1.23 |
| A6510 |  | Colocación de roca al volteo | 275d | 2025-01-06 | 2025-10-07 | A1220 SS | 79d | 0d |  | 250 | 1 | 85.0497768 | 250 | 17286.54 | m3 | 1 | 1 | 69.14616 | 1.23 |
| A6520 |  | Transporte de roca seleccionada de cantera para enrocado de protección, d=1km | 275d | 2025-01-06 | 2025-10-07 | A6510 SS | 79d | 0d |  | 0 | 1 | 0 |  | 15212.16 | m3k | 1 | 1 |  | 1.23 |
| A6530 |  | Transporte de roca seleccionada de cantera para enrocado de protección, d>1km | 275d | 2025-01-06 | 2025-10-07 | A6520 SS | 79d | 0d |  | 0 | 1 | 0 |  | 288346.19 | m3k | 1 | 1 |  | 1.23 |
| A6540 |  | Carguío de roca rechazada | 275d | 2025-01-06 | 2025-10-07 | A6530 SS | 79d | 0d |  | 750 | 1 | 28.3499256 | 750 | 17286.54 | m3 | 1 | 1 | 23.04872 | 1.23 |
| A6550 |  | Transporte de roca rechazada a DME, d=1km | 275d | 2025-01-06 | 2025-10-07 | A6540 SS | 79d | 0d |  | 0 | 1 | 0 |  | 15215.16 | m3k | 1 | 1 |  | 1.23 |
| A6560 |  | Transporte de roca rechazada a DME, d>1km | 275d | 2025-01-06 | 2025-10-07 | A6550 SS, A1320, A6500 | 79d | 72d |  | 0 | 1 | 0 |  | 17286.54 | m3k | 1 | 1 |  | 1.23 |
|  | 6 | **CONTROLES AMBIENTALES Y SEÑALIZACIÓN** |  | 2024-11-14 | 2026-01-07 |  |  |  |  |  |  |  |  |  |  |  |  |  |  |
|  | 1 | **SEÑALIZACIÓN** |  | 2024-11-14 | 2026-01-07 |  |  |  |  |  |  |  |  |  |  |  |  |  |  |
| A1240 |  | Señalización de obra | 420d | 2024-11-14 | 2026-01-07 | A1040 SS | 3d | 6d | HH [3360 h] | 0 | 0 | 0 |  |  |  |  |  |  |  |
| A1230 |  | Cartel de Obra de 7.00 x 3.50 m | 5d | 2024-11-29 | 2024-12-03 | A1040 | 403d | 406d | HH [40 h] | 0 | 0 | 0 |  |  |  |  |  |  |  |
|  | 2 | **CONTROLES AMBIENTALES** |  | 2024-11-14 | 2026-01-03 |  |  |  |  |  |  |  |  |  |  |  |  |  |  |
| A1250 |  | Implementación de controles ambientales durante la construcción | 400d | 2024-11-14 | 2025-12-18 | A1040 SS | 7d | 0d | HH [3200 h] | 0 | 0 | 0 |  |  |  |  |  |  |  |
| A1260 |  | Restauración y revegetación de áreas intervenidas | 16d | 2025-12-19 | 2026-01-03 | A1250, A6560 | 7d | 10d | HH [128 h] | 0 | 0 | 0 |  |  |  |  |  |  |  |

| ID | WBS | Activity | Type | Duration | Start | Finish | Predecessors | Total float | Free float | Resources | Cuadrilla | Rendimiento | Metrado | Unidad | Turno | RCuad | Dur. Cal. | Cuadrilla día | FactorR | FDur |
| --- | --- | --- | --- | --- | --- | --- | --- | --- | --- | --- | --- | --- | --- | --- | --- | --- | --- | --- | --- | --- |
|  | 3 | **DME Y DMO** |  |  | 2024-11-17 | 2026-01-05 |  |  |  |  |  |  |  |  |  |  |  |  |  |  |
| A1300 |  | Desbroce y remoción de suelo vegetal con equipo |  | 36d | 2024-11-17 | 2024-12-22 | A1020 SS+13d | 17d | 0d | HH [288 h] | 1 | 10000 | 124885.93 | m2 | 1 | 10000 | 12.488593 | 1 | 1.23 | 15.36096939 |
| A1310 |  | Transporte de material excedente a DMO, d=1km |  | 36d | 2024-11-17 | 2024-12-22 | A1300 SS | 93d | 0d |  | 1 |  | 47986.88 | m3k | 1 | 0 |  | 1 | 1.23 | 0 |
| A1320 |  | Transporte de material excedente a DMO, d>1km |  | 36d | 2024-11-17 | 2024-12-22 | A1310 SS | 93d | 14d |  | 1 |  | 421516.66 | m3k | 1 | 0 |  | 1 | 1.23 | 0 |
| A1270 |  | Acondicionamiento de terrenos para DME y DMO |  | 115d | 2024-11-29 | 2025-03-23 | A1040, A1300 SS | 5d | 0d | HH [920 h] | 1 | 4000 | 702299.09 | m2 | 2 | 4000 | 175.5747725 | 1 | 1.23 | 215.956970175 |
| A1280 |  | Conformación de material excedente en DME y DMO |  | 398d | 2024-12-04 | 2026-01-05 | A1270 SS+5d | 5d | 8d | HH [3184 h] | 1 | 1125 | 736677.37 | m3 | 1 | 1125 | 654.824328888889 | 1 | 1.23 | 805.433924533333 |
|  | 7 | **PRODUCCIÓN DE MATERIAL** |  |  | 2024-11-23 | 2024-12-26 |  |  |  |  |  |  |  |  |  |  |  |  |  |  |
| A1290 |  | Proceso y selección de material propio |  | 30d | 2024-11-23 | 2024-12-22 | A1110 SS | 384d | 387d | HH [240 h] |  |  | 12154.14 | m3 |  | 0 |  | 0 |  | 0 |
| A6500 |  | Transporte de material propio para relleno, d=1km |  | 34d | 2024-11-23 | 2024-12-26 | A1110 SS | 89d | 10d |  |  |  | 10695.64 | m3k |  | 0 |  | 0 |  | 0 |
|  | 8 | **PRUEBAS DE CONTROL DE CALIDAD** |  |  | 2024-11-29 | 2026-01-13 |  |  |  |  |  |  |  |  |  |  |  |  |  |  |
| A6570 |  | Pruebas de control de calidad para suelos |  | 411d | 2024-11-29 | 2026-01-13 | A4690 SS | 8d | 0d |  |  |  | 1 | glb |  |  |  |  |  |  |
| A6590 |  | Ensayos de validación de diques existentes |  | 367d | 2024-11-29 | 2025-11-30 | A6570 SS | 52d | 55d |  |  |  | 1 | glb |  |  |  |  |  |  |
| A6580 |  | Pruebas de control de calidad para concreto |  | 256d | 2025-04-24 | 2026-01-04 | A6320 SS | 17d | 20d |  |  |  | 1 | glb |  |  |  |  |  |  |
|  | 3 | **ENCAUZAMIENTO DE RÍO - SECTOR 1 (PK 27+857 al PK 30+000))** |  |  | 2024-11-29 | 2025-04-02 |  |  |  |  |  |  |  |  |  |  |  |  |  |  |
| A4690 |  | Inicio - Sector 1 | milestone | 0d | 2024-11-29 | 2024-11-29 | A1040, A1040 SS | -3d | 0d |  |  |  |  |  |  | 0 |  | 0 |  | 0 |
| A4700 |  | Fin - Sector 1 | milestone | 0d | 2025-04-02 | 2025-04-02 | C1360 FF, C1650 FF, A5240 FF, C1310 FF, C1320 FF, C1330 FF, C1730 FF, C1740 FF, C1480 FF, C1540 FF, C1590 FF, C1620 FF, C1660 FF | 283d | 252d |  |  |  |  |  |  | 0 |  | 0 |  | 0 |
|  | 1 | **DIPRO-007-MI** |  |  | 2024-11-29 | 2025-03-10 |  |  |  |  |  |  |  |  |  |  |  |  |  |  |
|  | 2 | **MOVIMIENTO DE TIERRAS PARA DIQUE LONGITUDINALES** |  |  | 2024-11-29 | 2025-03-10 |  |  |  |  |  |  |  |  |  |  |  |  |  |  |
|  | 1 | **EXCAVACIÓN** |  |  | 2024-11-29 | 2025-03-10 |  |  |  |  |  |  |  |  |  |  |  |  |  |  |
| C1260 |  | Desbroce y remoción de suelo vegetal con equipo |  | 3d | 2024-11-29 | 2024-12-01 | A4690 SS | -3d | 0d |  | 1 | 10000 | 18699.62 | m2 | 1 | 10000 | 1.869962 | 1 | 1.2313 | 2.3024842106 |
| C1270 |  | Transporte de material excedente a DMO, d=1km |  | 3d | 2024-11-29 | 2024-12-01 | C1260 SS | -3d | 0d |  | 1 |  | 5509.63 | m3xkm | 1 | 0 |  | 1 | 1.2313 | 0 |
| C1280 |  | Transporte de material excedente a DMO, d>1km |  | 3d | 2024-11-29 | 2024-12-01 | C1270 FF | -3d | 0d |  | 1 |  | 79461.93 | m3xkm | 1 | 0 |  | 1 | 1.2313 | 0 |
| C1290 |  | Excavación en material común |  | 35d | 2024-12-02 | 2025-01-05 | C1260, C1280 | -3d | 0d |  | 1 | 724 | 40544.87 | m3 | 2 | 1448 | 28.0006008287293 | 2 | 1.2313 | 34.4771398004144 |
| C1320 |  | Transporte de material excedente a DME, d=1km |  | 91d | 2024-12-02 | 2025-03-02 | C1260 | 314d | 31d |  | 1 |  | 33077.45 | m3xkm | 1 | 0 |  | 1 | 1.2313 | 0 |
| C1330 |  | Transporte de material excedente a DME, d>1km |  | 91d | 2024-12-02 | 2025-03-02 | C1260 | 314d | 31d |  | 1 |  | 341809.25 | m3xkm | 1 | 0 |  | 1 | 1.2313 | 0 |
| C1300 |  | Excavación para conformación de uña antisocavante |  | 72d | 2024-12-21 | 2025-03-02 | C1370 SS+4d | -3d | 0d |  | 1 | 450 | 26170.06 | m3 | 1 | 450 | 58.1556888888889 | 1 | 1.2313 | 71.6070997288889 |
| C1310 |  | Colocación de protección para geotextil |  | 79d | 2024-12-22 | 2025-03-10 | C1380 SS | 306d | 23d |  | 1 | 830 | 25678.65 | m2 | 1 | 830 | 30.9381325301205 | 1 | 1.2313 | 38.0941225843374 |

| ID | WBS | Activity | Duration | Start | Finish | Predecessors | Total float | Free float | Cuadrilla | Rendimiento | Metrado | Unidad | Turno | RCuad | Dur. Cal. | Cuadrilla día | FactorR | FDur |
| --- | --- | --- | --- | --- | --- | --- | --- | --- | --- | --- | --- | --- | --- | --- | --- | --- | --- | --- |
|  | 2 | **RELLENO** |  | 2024-12-02 | 2025-03-10 |  |  |  |  |  |  |  |  |  |  |  |  |  |
| C1390 |  | Proceso y selección de material propio | 39d | 2024-12-02 | 2025-01-09 | C1290 SS | 311d | 0d | 1 | 900 | 27876.75 | m3 | 1 | 900 | 30.9741666666667 | 1 | 1.2313 | 38.1384914166667 |
| C1400 |  | Transporte de material propio para relleno, d=1km | 39d | 2024-12-02 | 2025-01-09 | C1390 SS | 311d | 5d | 1 |  | 10593.16 | m3xkm | 1 | 0 |  | 1 | 1.2313 | 0 |
| C1340 |  | Conformación y compactación de superficie para fundación con equipo pesado | 26d | 2024-12-13 | 2025-01-07 | C1290 FF+2d | -3d | 0d | 1 | 2800 | 59142.45 | m2 | 1 | 2800 | 21.1223035714286 | 1 | 1.2313 | 26.0078923875 |
| C1350 |  | Relleno compactado con equipo pesado | 27d | 2024-12-15 | 2025-01-10 | C1340 SS+2d | -3d | 0d | 1 | 532.6 | 22286.09 | m3 | 2 | 1065.2 | 20.9219770935036 | 2 | 1.2313 | 25.761230395231 |
| C1370 |  | Perfilado de taludes de dique con equipo | 29d | 2024-12-17 | 2025-01-14 | C1350 SS+2d | -3d | 0d | 1 | 900 | 41386.65 | m2 | 2 | 1800 | 22.9925833333333 | 2 | 1.2313 | 28.3107678583333 |
| C1380 |  | Suministro, habilitación y colocación de geotextil no tejido 400 g/m2 | 79d | 2024-12-22 | 2025-03-10 | C1750 SS | 306d | 0d | 1 | 1500 | 28246.65 | m2 | 1 | 1500 | 18.8311 | 1 | 1.2313 | 23.18673343 |
| C1360 |  | Relleno propio sin compactar | 7d | 2025-03-04 | 2025-03-10 | C1450, C1560 | -3d | 0d | 1 | 1100 | 5590.66 | m3 | 1 | 1100 | 5.08241818181818 | 1 | 1.2313 | 6.25798150727273 |
|  | 7 | **ENROCADO DE PROTECCIÓN** |  | 2024-12-22 | 2025-03-10 |  |  |  |  |  |  |  |  |  |  |  |  |  |
| C1720 |  | Transporte de roca seleccionada de cantera para enrocado de protección, d=1km | 79d | 2024-12-22 | 2025-03-10 | C1750 SS | 306d | 0d | 1 |  | 43074.63 | m3xkm | 1 | 0 |  | 1 | 1.2313 | 0 |
| C1730 |  | Transporte de roca seleccionada de cantera para enrocado de protección, d>1km | 79d | 2024-12-22 | 2025-03-10 | C1720 SS | 306d | 23d | 1 |  | 731489.15 | m3xkm | 1 | 0 |  | 1 | 1.2313 | 0 |
| C1750 |  | Colocación de roca seleccionada, en uña antisocavante | 48d | 2024-12-22 | 2025-02-07 | C1300 SS+1d | -3d | 0d | 2 | 170 | 26170.06 | m3 | 2 | 680 | 38.4853823529412 | 4 | 1.2313 | 47.3870512911765 |
| C1740 |  | Colocación de roca seleccionada, en cara húmeda de talud | 55d | 2025-01-15 | 2025-03-10 | C1370, C1400 | 306d | 23d | 2 | 160 | 28338.72 | m3 | 2 | 640 | 44.27925 | 4 | 1.2313 | 54.521040525 |
|  | 8 | **REMOCION DE ENROCADO DE DIQUES EN MAL ESTADO** |  | 2025-02-08 | 2025-03-03 |  |  |  |  |  |  |  |  |  |  |  |  |  |
| C1450 |  | Remoción de enrocado de cara húmeda de talud | 24d | 2025-02-08 | 2025-03-03 | C1750 | -3d | 0d | 1 | 325 | 12412 | m3 | 2 | 650 | 19.0953846153846 | 2 | 1.2313 | 23.5121470769231 |
| C1460 |  | Selección y acopio de roca removida | 24d | 2025-02-08 | 2025-03-03 | C1450 SS | 313d | 0d | 1 | 300 | 8688.4 | m3 | 2 | 600 | 14.4806666666667 | 2 | 1.2313 | 17.8300448666667 |
| C1470 |  | Transporte de roca rechazada a DME, d=1km | 24d | 2025-02-08 | 2025-03-03 | C1460 SS | 313d | 0d | 1 | 500 | 2322.37 | m3xkm | 1 | 500 | 4.64474 | 1 | 1.2313 | 5.719068362 |
| C1480 |  | Transporte de roca rechazada a DME, d>1km | 24d | 2025-02-08 | 2025-03-03 | C1470 SS | 313d | 30d | 1 |  | 8587.4 | m3xkm | 1 | 0 |  | 1 | 1.2313 | 0 |
|  | 2 | **DIPRO-007-MD** |  | 2024-11-29 | 2025-04-02 |  |  |  |  |  |  |  |  |  |  |  |  |  |
|  | 1 | **MOVIMIENTO DE TIERRAS PARA DIQUE LONGITUDINALES** |  | 2024-11-29 | 2025-04-02 |  |  |  |  |  |  |  |  |  |  |  |  |  |
|  | 1 | **EXCAVACIÓN** |  | 2024-11-29 | 2025-04-02 |  |  |  |  |  |  |  |  |  |  |  |  |  |
| C1490 |  | Desbroce y remoción de suelo vegetal con equipo | 3d | 2024-11-29 | 2024-12-01 | A4690 SS | 5d | 0d | 1 | 10000 | 18558.16 | m2 | 1 | 10000 | 1.855816 | 1 | 1.2313 | 2.2850662408 |
| C1500 |  | Transporte de material excedente a DMO, d=1km | 3d | 2024-11-29 | 2024-12-01 | C1490 SS | 5d | 0d | 1 |  | 5467.96 | m3xkm | 1 | 0 |  | 1 | 1.2313 | 0 |
| C1510 |  | Transporte de material excedente a DMO, d>1km | 3d | 2024-11-29 | 2024-12-01 | C1500 SS | 5d | 0d | 1 |  | 78860.82 | m3xkm | 1 | 0 |  | 1 | 1.2313 | 0 |
| C1520 |  | Excavación en material común | 47d | 2024-12-02 | 2025-01-17 | C1490, C1510 | 5d | 0d | 1 | 724 | 54749.37 | m3 | 2 | 1448 | 37.8103383977901 | 2 | 1.2313 | 46.555869669199 |
| C1550 |  | Transporte de material excedente a DME, d=1km | 84d | 2024-12-02 | 2025-02-23 | C1520 SS | 5d | 0d | 1 |  | 40546.45 | m3xkm | 1 | 0 |  | 1 | 1.2313 | 0 |
| C1560 |  | Transporte de material excedente a DME, d>1km | 84d | 2024-12-02 | 2025-02-23 | C1550 SS | 5d | 8d | 1 |  | 418991 | m3xkm | 1 | 0 |  | 1 | 1.2313 | 0 |
| C1530 |  | Excavación para conformación de uña antisocavante | 37d | 2025-01-18 | 2025-02-23 | C1520 | 283d | 0d | 1 | 450 | 27030.03 | m3 | 2 | 900 | 30.0333666666667 | 2 | 1.2313 | 36.9800843766667 |
| C1540 |  | Colocación de protección para geotextil | 74d | 2025-01-19 | 2025-04-02 | C1610 SS | 283d | 0d | 1 | 830 | 27037.57 | m2 | 1 | 830 | 32.5753855421687 | 1 | 1.2313 | 40.1100722180723 |

| ID | WBS | Activity | Type | Duration | Start | Finish | Predecessors | Total float | Free float | Cuadrilla | Rendimiento | Metrado | Unidad | Turno | RCuad | Dur. Cal. | Cuadrilla día | FactorR | FDur |
| --- | --- | --- | --- | --- | --- | --- | --- | --- | --- | --- | --- | --- | --- | --- | --- | --- | --- | --- | --- |
|  | 2 | **RELLENO** |  |  | 2024-12-03 | 2025-04-02 |  |  |  |  |  |  |  |  |  |  |  |  |  |
| C1620 |  | Proceso y selección de material propio |  | 47d | 2024-12-03 | 2025-01-18 | C1520 SS+1d | 357d | 74d | 1 | 900 | 14839.94 | m3 | 1 | 900 | 16.4888222222222 | 1 | 1.2313 | 20.3026868022222 |
| C1570 |  | Conformación y compactación de superficie para fundación con equipo pesado |  | 26d | 2024-12-25 | 2025-01-19 | C1520 FF+2d | 305d | 0d | 1 | 2800 | 58695.04 | m2 | 1 | 2800 | 20.9625142857143 | 1 | 1.2313 | 25.81114384 |
| C1580 |  | Relleno compactado con equipo pesado |  | 22d | 2024-12-30 | 2025-01-20 | C1570 SS+5d | 305d | 0d | 1 | 532.6 | 9114.94 | m3 | 1 | 532.6 | 17.1140443109275 | 1 | 1.2313 | 21.072522760045 |
| C1630 |  | Transporte de material propio para relleno, d=1km |  | 22d | 2024-12-30 | 2025-01-20 | C1580 SS | 348d | 47d | 1 |  | 5639.18 | m3xkm | 1 | 0 |  | 1 | 1.2313 | 0 |
| C1600 |  | Perfilado de taludes de dique con equipo |  | 60d | 2025-01-04 | 2025-03-04 | C1580 SS+5d | 305d | 4d | 1 | 900 | 43276.05 | m2 | 1 | 900 | 48.0845 | 1 | 1.2313 | 59.20644485 |
| C1610 |  | Suministro, habilitación y colocación de geotextil no tejido 400 g/m2 |  | 74d | 2025-01-19 | 2025-04-02 | C1670 SS | 283d | 0d | 1 | 1500 | 29702.86 | m2 | 1 | 1500 | 19.8019066666667 | 1 | 1.2313 | 24.3820876786667 |
| C1590 |  | Relleno propio sin compactar |  | 7d | 2025-03-09 | 2025-03-15 | C1670, C1600, C1630, C1690, C1710 | 301d | 18d | 1 | 1100 | 5725 | m3 | 1 | 1100 | 5.20454545454545 | 1 | 1.2313 | 6.40835681818181 |
|  | 2 | **ENROCADO DE PROTECCIÓN** |  |  | 2025-01-19 | 2025-04-02 |  |  |  |  |  |  |  |  |  |  |  |  |  |
| C1640 |  | Transporte de roca seleccionada de cantera para enrocado de protección, d=1km |  | 74d | 2025-01-19 | 2025-04-02 | C1670 SS | 283d | 0d | 1 |  | 44832.78 | m3xkm | 1 | 0 |  | 1 | 1.2313 | 0 |
| C1650 |  | Transporte de roca seleccionada de cantera para enrocado de protección, d>1km |  | 74d | 2025-01-19 | 2025-04-02 | C1640 SS | 283d | 0d | 1 |  | 761345.86 | m3xkm | 1 | 0 |  | 1 | 1.2313 | 0 |
| C1670 |  | Colocación de roca seleccionada, en uña antisocavante |  | 49d | 2025-01-19 | 2025-03-08 | C1530 SS+1d | 283d | 0d | 2 | 170 | 27030.03 | m3 | 2 | 680 | 39.7500441176471 | 4 | 1.2313 | 48.9442293220589 |
| C1660 |  | Colocación de roca seleccionada, en cara húmeda de talud |  | 59d | 2025-02-03 | 2025-04-02 | C1530 SS+5d, C1680 | 283d | 0d | 2 | 160 | 30355.52 | m3 | 2 | 640 | 47.4305 | 4 | 1.2313 | 58.40117465 |
|  | 3 | **REMOCION DE ENROCADO DE DIQUES EN MAL ESTADO** |  |  | 2025-01-18 | 2025-02-02 |  |  |  |  |  |  |  |  |  |  |  |  |  |
| C1680 |  | Remoción de enrocado de cara húmeda de talud |  | 16d | 2025-01-18 | 2025-02-02 | C1520 | 283d | 0d | 1 | 325 | 4138.94 | m3 | 1 | 325 | 12.7352 | 1 | 1.2313 | 15.68085176 |
| C1700 |  | Transporte de roca rechazada a DME, d=1km |  | 16d | 2025-01-18 | 2025-02-02 | C1680 SS | 335d | 0d | 1 | 500 | 516.28 | m3xkm | 1 | 500 | 1.03256 | 1 | 1.2313 | 1.271391128 |
| C1710 |  | Transporte de roca rechazada a DME, d>1km |  | 16d | 2025-01-18 | 2025-02-02 | C1700 SS | 335d | 34d | 1 |  | 1909.06 | m3xkm | 1 | 0 |  | 1 | 1.2313 | 0 |
| C1690 |  | Selección y acopio de roca removida |  | 14d | 2025-01-20 | 2025-02-02 | C1680 FF | 335d | 34d | 1 | 300 | 3311.15 | m3 | 1 | 300 | 11.0371666666667 | 1 | 1.2313 | 13.5900633166667 |
|  | 6 | **ENCAUZAMIENTO DE RÍO - SECTOR 2 (PK 25+753 al 27+459)** |  |  | 2025-03-11 | 2025-12-10 |  |  |  |  |  |  |  |  |  |  |  |  |  |
| A4710 |  | Inicio - Sector 2 | milestone | 0d | 2025-03-11 | 2025-03-11 | C1360 | -3d | 0d |  |  |  |  |  | 0 |  | 0 |  | 0 |
| A4720 |  | Fin - Sector 2 | milestone | 0d | 2025-12-10 | 2025-12-10 | C1890 FF, C2650 FF, C2640 FF, A4700 FF, C2580 FF, C2590 FF, C2610 FF, C2700 FF, C2710 FF, A4760 FF | 31d | 34d |  |  |  |  |  | 0 |  | 0 |  | 0 |
|  | 1 | **DIPRO-004-MI** |  |  | 2025-03-11 | 2025-05-08 |  |  |  |  |  |  |  |  |  |  |  |  |  |
|  | 1 | **MOVIMIENTO DE TIERRAS PARA DIQUE LONGITUDINALES** |  |  | 2025-03-11 | 2025-05-08 |  |  |  |  |  |  |  |  |  |  |  |  |  |
|  | 1 | **EXCAVACIÓN** |  |  | 2025-03-11 | 2025-05-08 |  |  |  |  |  |  |  |  |  |  |  |  |  |
| C1760 |  | Excavación en material común |  | 13d | 2025-03-11 | 2025-03-23 | A4710 SS | 21d | 0d | 1 | 724 | 15270.74 | m3 | 2 | 1448 | 10.546091160221 | 2 | 1.2313 | 12.9854020455801 |
| C1790 |  | Transporte de material excedente a DME, d=1km |  | 26d | 2025-03-11 | 2025-04-05 | C1760 SS | 25d | 0d | 1 |  | 8070.9 | m3xkm | 1 | 0 |  | 1 | 1.2313 | 0 |
| C1800 |  | Transporte de material excedente a DME, d>1km |  | 26d | 2025-03-11 | 2025-04-05 | C1790 SS | 25d | 4d | 1 |  | 6511.18 | m3xkm | 1 | 0 |  | 1 | 1.2313 | 0 |
| C1770 |  | Excavación para conformación de uña antisocavante |  | 13d | 2025-03-24 | 2025-04-05 | C1760 | 21d | 0d | 1 | 450 | 9363.66 | m3 | 2 | 900 | 10.4040666666667 | 2 | 1.2313 | 12.8105272866667 |
| C1780 |  | Colocación de protección para geotextil |  | 45d | 2025-03-25 | 2025-05-08 | C1910 SS | 74d | 0d | 1 | 830 | 6579.15 | m2 | 1 | 830 | 7.92668674698795 | 1 | 1.2313 | 9.76012939156626 |

| ID | WBS | Activity | Duration | Start | Finish | Predecessors | Total float | Free float | Cuadrilla | Rendimiento | Metrado | Unidad | Turno | RCuad | Dur. Cal. | Cuadrilla día | FactorR | FDur |
| --- | --- | --- | --- | --- | --- | --- | --- | --- | --- | --- | --- | --- | --- | --- | --- | --- | --- | --- |
|  | 2 | **RELLENO** |  | 2025-03-12 | 2025-05-08 |  |  |  |  |  |  |  |  |  |  |  |  |  |
| C1860 |  | Proceso y selección de material propio | 12d | 2025-03-12 | 2025-03-23 | C1760 SS+1d | 34d | 0d | 1 | 900 | 3432.26 | m3 | 1 | 900 | 3.81362222222222 | 1 | 1.2313 | 4.69571304222222 |
| C1840 |  | Perfilado de taludes de dique con equipo | 16d | 2025-03-16 | 2025-03-31 | C1760 SS+5d | 112d | 49d | 1 | 900 | 11050.84 | m2 | 1 | 900 | 12.2787111111111 | 1 | 1.2313 | 15.1187769911111 |
| C1810 |  | Conformación y compactación de superficie para fundación con equipo pesado | 2d | 2025-03-22 | 2025-03-23 | C1760 FF | 34d | 0d | 1 | 2800 | 2552.96 | m2 | 1 | 2800 | 0.911771428571429 | 1 | 1.2313 | 1.12266416 |
| C1820 |  | Relleno compactado con equipo pesado | 4d | 2025-03-24 | 2025-03-27 | C1810 | 34d | 0d | 1 | 532.6 | 1695.84 | m3 | 1 | 532.6 | 3.18407810739767 | 1 | 1.2313 | 3.92055537363875 |
| C1870 |  | Transporte de material propio para relleno, d=1km | 4d | 2025-03-24 | 2025-03-27 | C1820 SS, C1860 | 34d | 13d | 1 |  | 1304.26 | m3xkm | 1 | 0 |  | 1 | 1.2313 | 0 |
| C1850 |  | Suministro, habilitación y colocación de geotextil no tejido 400 g/m2 | 45d | 2025-03-25 | 2025-05-08 | C1780 SS | 74d | 11d | 1 | 1500 | 7187.54 | m2 | 1 | 1500 | 4.79169333333333 | 1 | 1.2313 | 5.90001200133333 |
| C1830 |  | Relleno propio sin compactar | 2d | 2025-04-10 | 2025-04-11 | C1910 | 101d | 38d | 1 | 1100 | 1736.42 | m3 | 1 | 1100 | 1.57856363636364 | 1 | 1.2313 | 1.94368540545455 |
|  | 2 | **ENROCADO DE PROTECCIÓN** |  | 2025-03-25 | 2025-05-08 |  |  |  |  |  |  |  |  |  |  |  |  |  |
| C1880 |  | Transporte de roca seleccionada de cantera para enrocado de protección, d=1km | 45d | 2025-03-25 | 2025-05-08 | C1910 SS | 247d | 0d | 1 |  | 13760.42 | m3xkm | 1 | 0 |  | 1 | 1.2313 | 0 |
| C1890 |  | Transporte de roca seleccionada de cantera para enrocado de protección, d>1km | 45d | 2025-03-25 | 2025-05-08 | C1880 SS | 247d | 216d | 1 |  | 205024.64 | m3xkm | 1 | 0 |  | 1 | 1.2313 | 0 |
| C1910 |  | Colocación de roca seleccionada, en uña antisocavante | 16d | 2025-03-25 | 2025-04-09 | C1770 SS+1d | 21d | 0d | 2 | 170 | 9363.66 | m3 | 2 | 680 | 13.7700882352941 | 4 | 1.2313 | 16.9551096441176 |
| C1900 |  | Colocación de roca seleccionada, en cara húmeda de talud | 29d | 2025-04-10 | 2025-05-08 | C1910, C1800, C1870, C1950 | 21d | 0d | 1 | 160 | 7526.88 | m3 | 2 | 320 | 23.5215 | 2 | 1.2313 | 28.96202295 |
|  | 3 | **REMOCION DE ENROCADO DE DIQUES EN MAL ESTADO** |  | 2025-03-24 | 2025-04-06 |  |  |  |  |  |  |  |  |  |  |  |  |  |
| C1920 |  | Remoción de enrocado de cara húmeda de talud | 9d | 2025-03-24 | 2025-04-01 | C1760 | 24d | 0d | 1 | 300 | 4260 | m3 | 2 | 600 | 7.1 | 2 | 1.2313 | 8.74223 |
| C1930 |  | Selección y acopio de roca removida | 5d | 2025-04-02 | 2025-04-06 | C1920 | 24d | 0d | 1 | 500 | 3195 | m3 | 1 | 500 | 6.39 | 1 | 1.2313 | 7.868007 |
| C1940 |  | Transporte de roca rechazada a DME, d=1km | 5d | 2025-04-02 | 2025-04-06 | C1930 SS | 24d | 0d | 1 |  | 1044.43 | m3xkm | 1 | 0 |  | 1 | 1.2313 | 0 |
| C1950 |  | Transporte de roca rechazada a DME, d>1km | 5d | 2025-04-02 | 2025-04-06 | C1940 SS | 24d | 3d | 1 |  | 952.57 | m3xkm | 1 | 0 |  | 1 | 1.2313 | 0 |
|  | 2 | **DIPRO-005-MI** |  | 2025-03-11 | 2025-07-24 |  |  |  |  |  |  |  |  |  |  |  |  |  |
|  | 1 | **MOVIMIENTO DE TIERRAS PARA DIQUE LONGITUDINALES** |  | 2025-03-11 | 2025-07-24 |  |  |  |  |  |  |  |  |  |  |  |  |  |
|  | 1 | **EXCAVACIÓN** |  | 2025-03-11 | 2025-07-24 |  |  |  |  |  |  |  |  |  |  |  |  |  |
| C1960 |  | Excavación en material común | 70d | 2025-03-11 | 2025-05-19 | A4710 SS | 1d | 0d | 1 | 724 | 81647.9 | m3 | 2 | 1448 | 56.3866712707182 | 2 | 1.2313 | 69.4289083356353 |
| C1990 |  | Transporte de material excedente a DME, d=1km | 97d | 2025-03-11 | 2025-06-15 | C1960 SS | 138d | 0d | 1 |  | 33054.09 | m3xkm | 1 | 0 |  | 1 | 1.2313 | 0 |
| C2000 |  | Transporte de material excedente a DME, d>1km | 97d | 2025-03-11 | 2025-06-15 | C1990 SS | 138d | 8d | 1 |  | 26666.31 | m3xkm | 1 | 0 |  | 1 | 1.2313 | 0 |
| C1970 |  | Excavación para conformación de uña antisocavante | 27d | 2025-05-20 | 2025-06-15 | C1960, C1830, C1840, C1850 | 63d | 0d | 1 | 450 | 19241.41 | m3 | 2 | 900 | 21.3793444444444 | 2 | 1.2313 | 26.3243868144444 |
| C1980 |  | Colocación de protección para geotextil | 66d | 2025-05-20 | 2025-07-24 | C2050 SS | 82d | 19d | 1 | 830 | 13689.92 | m2 | 1 | 830 | 16.4938795180723 | 1 | 1.2313 | 20.3089138506024 |

| ID | WBS | Activity | Duration | Start | Finish | Predecessors | Total float | Free float | Cuadrilla | Rendimiento | Metrado | Unidad | Turno | RCuad | Dur. Cal. | Cuadrilla día | FactorR | FDur |
| --- | --- | --- | --- | --- | --- | --- | --- | --- | --- | --- | --- | --- | --- | --- | --- | --- | --- | --- |
|  | 2 | **RELLENO** |  | 2025-03-16 | 2025-07-24 |  |  |  |  |  |  |  |  |  |  |  |  |  |
| C2060 |  | Proceso y selección de material propio | 65d | 2025-03-16 | 2025-05-19 | C1960 SS+5d | 63d | 0d | 1 | 900 | 76580.54 | m3 | 2 | 1800 | 42.5447444444444 | 2 | 1.2313 | 52.3853438344444 |
| C2010 |  | Conformación y compactación de superficie para fundación con equipo pesado | 51d | 2025-03-31 | 2025-05-20 | C1960 SS+20d | 1d | 0d | 1 | 2800 | 56961.5 | m2 | 1 | 2800 | 20.3433928571429 | 1 | 1.2313 | 25.0488196250001 |
| C2020 |  | Relleno compactado con equipo pesado | 58d | 2025-04-02 | 2025-05-29 | C2010 SS+2d | 1d | 0d | 1 | 532.6 | 49704.27 | m3 | 2 | 1065.2 | 46.6619132557266 | 2 | 1.2313 | 57.4548137917762 |
| C2070 |  | Transporte de material propio para relleno, d=1km | 58d | 2025-04-02 | 2025-05-29 | C2020 SS | 1d | 0d | 1 |  | 29100.6 | m3xkm | 1 | 0 |  | 1 | 1.2313 | 0 |
| C2040 |  | Perfilado de taludes de dique con equipo | 32d | 2025-04-30 | 2025-05-31 | C2010 SS+30d | 35d | 34d | 1 | 900 | 22755.13 | m2 | 1 | 900 | 25.2834777777778 | 1 | 1.2313 | 31.1315461877778 |
| C2050 |  | Suministro, habilitación y colocación de geotextil no tejido 400 g/m2 | 66d | 2025-05-20 | 2025-07-24 | C2110 SS | 82d | 0d | 1 | 1500 | 14923.29 | m2 | 1 | 1500 | 9.94886 | 1 | 1.2313 | 12.250031318 |
| C2030 |  | Relleno propio sin compactar | 31d | 2025-06-24 | 2025-07-24 | C2110, C2000 | 130d | 26d | 1 | 1100 | 26876.27 | m3 | 2 | 2200 | 12.2164863636364 | 2 | 1.2313 | 15.0421596595455 |
|  | 2 | **ENROCADO DE PROTECCIÓN** |  | 2025-05-20 | 2025-07-24 |  |  |  |  |  |  |  |  |  |  |  |  |  |
| C2080 |  | Transporte de roca seleccionada de cantera para enrocado de protección, d=1km | 66d | 2025-05-20 | 2025-07-24 | C2110 SS | 82d | 0d | 1 |  | 28853.95 | m3xkm | 1 | 0 |  | 1 | 1.2313 | 0 |
| C2090 |  | Transporte de roca seleccionada de cantera para enrocado de protección, d>1km | 66d | 2025-05-20 | 2025-07-24 | C2080 SS | 82d | 19d | 1 |  | 429912.24 | m3xkm | 1 | 0 |  | 1 | 1.2313 | 0 |
| C2110 |  | Colocación de roca seleccionada, en uña antisocavante | 35d | 2025-05-20 | 2025-06-23 | C1970 SS, C2060 | 63d | 0d | 2 | 170 | 19241.41 | m3 | 2 | 680 | 28.2961911764706 | 4 | 1.2313 | 34.8411001955883 |
| C2100 |  | Colocación de roca seleccionada, en cara húmeda de talud | 31d | 2025-06-24 | 2025-07-24 | C2110 | 82d | 19d | 2 | 160 | 16176.04 | m3 | 2 | 640 | 25.2750625 | 4 | 1.2313 | 31.12118445625 |
|  | 3 | **DIPRO-006-MI** |  | 2025-06-24 | 2025-07-18 |  |  |  |  |  |  |  |  |  |  |  |  |  |
|  | 1 | **MOVIMIENTO DE TIERRAS PARA DIQUE LONGITUDINALES** |  | 2025-06-24 | 2025-07-18 |  |  |  |  |  |  |  |  |  |  |  |  |  |
|  | 1 | **EXCAVACIÓN** |  | 2025-06-24 | 2025-07-18 |  |  |  |  |  |  |  |  |  |  |  |  |  |
| C2160 |  | Desbroce y remoción de suelo vegetal con equipo | 1d | 2025-06-24 | 2025-06-24 | C2110 | 63d | 0d | 1 | 10000 | 1393.67 | m2 | 1 | 10000 | 0.139367 | 1 | 1.2313 | 0.1716025871 |
| C2170 |  | Transporte de material excedente a DMO, d=1km | 1d | 2025-06-24 | 2025-06-24 | C2160 SS | 63d | 0d | 1 |  | 398.76 | m3xkm | 1 | 0 |  | 1 | 1.2313 | 0 |
| C2180 |  | Transporte de material excedente a DMO, d>1km | 1d | 2025-06-24 | 2025-06-24 | C2170 SS | 63d | 0d | 1 |  | 4676.67 | m3xkm | 1 | 0 |  | 1 | 1.2313 | 0 |
| C2190 |  | Excavación en material común | 6d | 2025-06-25 | 2025-06-30 | C2160, C2180 | 63d | 0d | 1 | 724 | 3523.65 | m3 | 1 | 724 | 4.86691988950276 | 1 | 1.2313 | 5.99263845994475 |
| C2220 |  | Transporte de material excedente a DME, d=1km | 14d | 2025-06-25 | 2025-07-08 | C2190 SS | 88d | 0d | 1 |  | 1398.07 | m3xkm | 1 | 0 |  | 1 | 1.2313 | 0 |
| C2230 |  | Transporte de material excedente a DME, d>1km | 14d | 2025-06-25 | 2025-07-08 | C2220 SS | 88d | 0d | 1 |  | 1127.89 | m3xkm | 1 | 0 |  | 1 | 1.2313 | 0 |
| C2200 |  | Excavación para conformación de uña antisocavante | 2d | 2025-07-07 | 2025-07-08 | C2270 | 89d | 0d | 1 | 450 | 743.6 | m3 | 1 | 450 | 1.65244444444444 | 1 | 1.2313 | 2.03465484444444 |
| C2210 |  | Colocación de protección para geotextil | 10d | 2025-07-09 | 2025-07-18 | C2280 SS, C2230 | 88d | 25d | 1 | 830 | 447.2 | m2 | 1 | 830 | 0.538795180722892 | 1 | 1.2313 | 0.663418506024097 |

| ID | WBS | Activity | Duration | Start | Finish | Predecessors | Total float | Free float | Cuadrilla | Rendimiento | Metrado | Unidad | Turno | RCuad | Dur. Cal. | Cuadrilla día | FactorR | FDur |
| --- | --- | --- | --- | --- | --- | --- | --- | --- | --- | --- | --- | --- | --- | --- | --- | --- | --- | --- |
|  | 2 | **RELLENO** |  | 2025-06-27 | 2025-07-17 |  |  |  |  |  |  |  |  |  |  |  |  |  |
| C2290 |  | Proceso y selección de material propio | 4d | 2025-06-27 | 2025-06-30 | C2190 FF | 92d | 1d | 1 | 900 | 2760.11 | m3 | 1 | 900 | 3.06678888888889 | 1 | 1.2313 | 3.77613715888889 |
| C2240 |  | Conformación y compactación de superficie para fundación con equipo pesado | 1d | 2025-07-01 | 2025-07-01 | C2190 | 89d | 0d | 1 | 2800 | 2053 | m2 | 1 | 2800 | 0.733214285714286 | 1 | 1.2313 | 0.90280675 |
| C2250 |  | Relleno compactado con equipo pesado | 4d | 2025-07-02 | 2025-07-05 | C2240, C2240 FF | 89d | 0d | 1 | 532.6 | 1540.32 | m3 | 1 | 532.6 | 2.89207660533233 | 1 | 1.2313 | 3.5610139241457 |
| C2300 |  | Transporte de material propio para relleno, d=1km | 4d | 2025-07-02 | 2025-07-05 | C2250 SS, C2290 | 91d | 2d | 1 |  | 1048.84 | m3xkm | 1 | 0 |  | 1 | 1.2313 | 0 |
| C2270 |  | Perfilado de taludes de dique con equipo | 1d | 2025-07-06 | 2025-07-06 | C2250 | 89d | 0d | 1 | 900 | 800 | m2 | 1 | 900 | 0.888888888888889 | 1 | 1.2313 | 1.09448888888889 |
| C2280 |  | Suministro, habilitación y colocación de geotextil no tejido 400 g/m2 | 10d | 2025-07-08 | 2025-07-17 | C2340 SS | 89d | 1d | 1 | 1500 | 495.2 | m2 | 1 | 1500 | 0.330133333333333 | 1 | 1.2313 | 0.406493173333333 |
| C2260 |  | Relleno propio sin compactar | 2d | 2025-07-14 | 2025-07-15 | C2340 | 91d | 28d | 1 | 1100 | 1219.79 | m3 | 1 | 1100 | 1.1089 | 1 | 1.2313 | 1.36538857 |
|  | 2 | **ENROCADO DE PROTECCIÓN** |  | 2025-07-08 | 2025-07-17 |  |  |  |  |  |  |  |  |  |  |  |  |  |
| C2310 |  | Transporte de roca seleccionada de cantera para enrocado de protección, d=1km | 10d | 2025-07-08 | 2025-07-17 | C2340 SS, C2300 | 89d | 0d | 1 |  | 959.12 | m3xkm | 1 | 0 |  | 1 | 1.2313 | 0 |
| C2320 |  | Transporte de roca seleccionada de cantera para enrocado de protección, d>1km | 10d | 2025-07-08 | 2025-07-17 | C2310 SS | 89d | 26d | 1 |  | 14290.57 | m3xkm | 1 | 0 |  | 1 | 1.2313 | 0 |
| C2340 |  | Colocación de roca seleccionada, en uña antisocavante | 6d | 2025-07-08 | 2025-07-13 | C2200 SS+1d | 89d | 0d | 1 | 170 | 743.6 | m3 | 1 | 170 | 4.37411764705882 | 1 | 1.2313 | 5.38585105882353 |
| C2330 |  | Colocación de roca seleccionada, en cara húmeda de talud | 4d | 2025-07-14 | 2025-07-17 | C2340 | 89d | 26d | 1 | 160 | 433.7 | m3 | 1 | 160 | 2.710625 | 1 | 1.2313 | 3.3375925625 |
|  | 4 | **DIPRO-006-MD** |  | 2025-05-09 | 2025-09-07 |  |  |  |  |  |  |  |  |  |  |  |  |  |
|  | 1 | **MOVIMIENTO DE TIERRAS PARA DIQUE LONGITUDINALES** |  | 2025-05-09 | 2025-09-07 |  |  |  |  |  |  |  |  |  |  |  |  |  |
|  | 1 | **EXCAVACIÓN** |  | 2025-05-09 | 2025-09-07 |  |  |  |  |  |  |  |  |  |  |  |  |  |
| C2350 |  | Desbroce y remoción de suelo vegetal con equipo | 1d | 2025-05-09 | 2025-05-09 | C1900 | 21d | 0d | 1 | 10000 | 6346.08 | m2 | 1 | 10000 | 0.634608 | 1 | 1.2313 | 0.7813928304 |
| C2360 |  | Transporte de material excedente a DMO, d=1km | 1d | 2025-05-09 | 2025-05-09 | C2350 SS | 21d | 0d | 1 |  | 1815.77 | m3xkm | 1 | 0 |  | 1 | 1.2313 | 0 |
| C2370 |  | Transporte de material excedente a DMO, d>1km | 1d | 2025-05-09 | 2025-05-09 | C2360 SS | 21d | 20d | 1 |  | 21295.29 | m3xkm | 1 | 0 |  | 1 | 1.2313 | 0 |
| C2380 |  | Excavación en material común | 36d | 2025-05-30 | 2025-07-04 | C2350, C2350 FF, C2070, C2370 | 1d | 0d | 1 | 724 | 41730.44 | m3 | 2 | 1448 | 28.819364640884 | 2 | 1.2313 | 35.4852836823205 |
| C2410 |  | Transporte de material excedente a DME, d=1km | 36d | 2025-05-30 | 2025-07-04 | C2380 SS | 1d | 0d | 1 |  | 17155.84 | m3xkm | 1 | 0 |  | 1 | 1.2313 | 0 |
| C2420 |  | Transporte de material excedente a DME, d>1km | 36d | 2025-05-30 | 2025-07-04 | C2410 SS | 1d | 0d | 1 |  | 13840.44 | m3xkm | 1 | 0 |  | 1 | 1.2313 | 0 |
| C2390 |  | Excavación para conformación de uña antisocavante | 30d | 2025-07-05 | 2025-08-03 | C2380, C2040, C2420 | 1d | 0d | 1 | 450 | 10633.46 | m3 | 1 | 450 | 23.6299111111111 | 1 | 1.2313 | 29.0955095511111 |
| C2400 |  | Colocación de protección para geotextil | 65d | 2025-07-05 | 2025-09-07 | C2470 SS | 50d | 16d | 1 | 830 | 7621.570025 | m2 | 1 | 830 | 9.18261448795181 | 1 | 1.2313 | 11.3065532190151 |

| ID | WBS | Activity | Duration | Start | Finish | Predecessors | Total float | Free float | Cuadrilla | Rendimiento | Metrado | Unidad | Turno | RCuad | Dur. Cal. | Cuadrilla día | FactorR | FDur |
| --- | --- | --- | --- | --- | --- | --- | --- | --- | --- | --- | --- | --- | --- | --- | --- | --- | --- | --- |
|  | 2 | **RELLENO** |  | 2025-06-04 | 2025-09-07 |  |  |  |  |  |  |  |  |  |  |  |  |  |
| C2480 |  | Proceso y selección de material propio | 31d | 2025-06-04 | 2025-07-04 | C2380 SS+5d | 50d | 0d | 1 | 900 | 44462.22 | m3 | 2 | 1800 | 24.7012333333333 | 2 | 1.2313 | 30.4146286033333 |
| C2430 |  | Conformación y compactación de superficie para fundación con equipo pesado | 30d | 2025-06-06 | 2025-07-05 | C2380 SS+7d | 15d | 0d | 1 | 2800 | 33071.52 | m2 | 1 | 2800 | 11.8112571428571 | 1 | 1.2313 | 14.5432009199999 |
| C2440 |  | Relleno compactado con equipo pesado | 39d | 2025-06-10 | 2025-07-18 | C2430 SS+4d | 15d | 0d | 1 | 532.6 | 33326.69 | m3 | 2 | 1065.2 | 31.2867912129178 | 2 | 1.2313 | 38.5234260204657 |
| C2490 |  | Transporte de material propio para relleno, d=1km | 39d | 2025-06-10 | 2025-07-18 | C2440 SS | 36d | 17d | 1 |  | 16895.64 | m3xkm | 1 | 0 |  | 1 | 1.2313 | 0 |
| C2460 |  | Perfilado de taludes de dique con equipo | 25d | 2025-06-26 | 2025-07-20 | C2440 FF+2d | 15d | 14d | 1 | 900 | 12666.610025 | m2 | 1 | 900 | 14.0740111388889 | 1 | 1.2313 | 17.3293299153139 |
| C2470 |  | Suministro, habilitación y colocación de geotextil no tejido 400 g/m2 | 65d | 2025-07-05 | 2025-09-07 | C2530 SS | 50d | 0d | 1 | 1500 | 8307.970025 | m2 | 1 | 1500 | 5.53864668333333 | 1 | 1.2313 | 6.81973566118833 |
| C2450 |  | Relleno propio sin compactar | 13d | 2025-08-13 | 2025-08-25 | C2530, C1980, C2090, C2100, C2210, C2260, C2320, C2330 | 63d | 29d | 1 | 1100 | 11135.53 | m3 | 1 | 1100 | 10.1232090909091 | 1 | 1.2313 | 12.4647073536364 |
|  | 2 | **ENROCADO DE PROTECCIÓN** |  | 2025-07-05 | 2025-09-07 |  |  |  |  |  |  |  |  |  |  |  |  |  |
| C2500 |  | Transporte de roca seleccionada de cantera para enrocado de protección, d=1km | 65d | 2025-07-05 | 2025-09-07 | C2530 SS | 50d | 0d | 1 |  | 15960.68 | m3xkm | 1 | 0 |  | 1 | 1.2313 | 0 |
| C2510 |  | Transporte de roca seleccionada de cantera para enrocado de protección, d>1km | 65d | 2025-07-05 | 2025-09-07 | C2500 SS | 50d | 16d | 1 |  | 237807.63 | m3xkm | 1 | 0 |  | 1 | 1.2313 | 0 |
| C2530 |  | Colocación de roca seleccionada, en uña antisocavante | 39d | 2025-07-05 | 2025-08-12 | C2390 SS, C2480 | 50d | 0d | 1 | 170 | 10633.46 | m3 | 2 | 340 | 31.2748823529412 | 2 | 1.2313 | 38.5087626411765 |
| C2520 |  | Colocación de roca seleccionada, en cara húmeda de talud | 35d | 2025-08-04 | 2025-09-07 | C2390, C2460 | 1d | 0d | 1 | 160 | 8957.84 | m3 | 2 | 320 | 27.99325 | 2 | 1.2313 | 34.468088725 |
|  | 5 | **DIPRO-007-MD** |  | 2025-08-04 | 2025-12-10 |  |  |  |  |  |  |  |  |  |  |  |  |  |
|  | 1 | **MOVIMIENTO DE TIERRAS PARA DIQUE LONGITUDINALES** |  | 2025-08-04 | 2025-12-10 |  |  |  |  |  |  |  |  |  |  |  |  |  |
|  | 1 | **EXCAVACIÓN** |  | 2025-08-04 | 2025-12-10 |  |  |  |  |  |  |  |  |  |  |  |  |  |
| C2540 |  | Desbroce y remoción de suelo vegetal con equipo | 1d | 2025-08-04 | 2025-08-04 | C2390 | 19d | 0d | 1 | 10000 | 7143.51 | m2 | 1 | 10000 | 0.714351 | 1 | 1.2313 | 0.8795803863 |
| C2550 |  | Transporte de material excedente a DMO, d=1km | 1d | 2025-08-04 | 2025-08-04 | C2540 SS | 19d | 0d | 1 |  | 2043.93 | m3xkm | 1 | 0 |  | 1 | 1.2313 | 0 |
| C2560 |  | Transporte de material excedente a DMO, d>1km | 1d | 2025-08-04 | 2025-08-04 | C2550 SS | 19d | 0d | 1 |  | 23971.23 | m3xkm | 1 | 0 |  | 1 | 1.2313 | 0 |
| C2570 |  | Excavación en material común | 50d | 2025-08-05 | 2025-09-23 | C2540, C2490, C2560 | 19d | 0d | 1 | 724 | 58651.04 | m3 | 2 | 1448 | 40.504861878453 | 2 | 1.2313 | 49.8736364309392 |
| C2600 |  | Transporte de material excedente a DME, d=1km | 125d | 2025-08-05 | 2025-12-07 | C2570 SS | 34d | 0d | 1 |  | 26037.34 | m3xkm | 1 | 0 |  | 1 | 1.2313 | 0 |
| C2610 |  | Transporte de material excedente a DME, d>1km | 125d | 2025-08-05 | 2025-12-07 | C2600 SS | 34d | 3d | 1 |  | 21005.57 | m3xkm | 1 | 0 |  | 1 | 1.2313 | 0 |
| C2580 |  | Excavación para conformación de uña antisocavante | 75d | 2025-09-24 | 2025-12-07 | C2570, C2400, C2450, C2510 | 34d | 3d | 1 | 450 | 20821.41 | m3 | 2 | 900 | 23.1349 | 2 | 1.2313 | 28.48600237 |
| C2590 |  | Colocación de protección para geotextil | 77d | 2025-09-25 | 2025-12-10 | C2660 SS | 31d | 0d | 1 | 830 | 14876.7 | m2 | 1 | 830 | 17.923734939759 | 1 | 1.2313 | 22.0694948313253 |

| ID | WBS | Activity | Type | Duration | Start | Finish | Predecessors | Total float | Free float | Cuadrilla | Rendimiento | Metrado | Unidad | Turno | RCuad | Dur. Cal. | Cuadrilla día | FactorR | FDur |
| --- | --- | --- | --- | --- | --- | --- | --- | --- | --- | --- | --- | --- | --- | --- | --- | --- | --- | --- | --- |
|  | 2 | **RELLENO** |  |  | 2025-08-10 | 2025-12-10 |  |  |  |  |  |  |  |  |  |  |  |  |  |
| C2620 |  | Conformación y compactación de superficie para fundación con equipo pesado |  | 48d | 2025-08-10 | 2025-09-26 | C2570 SS+5d | 37d | 0d | 1 | 2800 | 21880.14 | m2 | 1 | 2800 | 7.81433571428571 | 1 | 1.2313 | 9.62179156499999 |
| C2670 |  | Proceso y selección de material propio |  | 42d | 2025-08-14 | 2025-09-24 | C2570 SS+9d | 31d | 0d | 1 | 900 | 29416.23 | m3 | 1 | 900 | 32.6847 | 1 | 1.2313 | 40.24467111 |
| C2630 |  | Relleno compactado con equipo pesado |  | 44d | 2025-08-15 | 2025-09-27 | C2620 SS+5d | 37d | 0d | 1 | 532.6 | 19377.37 | m3 | 1 | 532.6 | 36.3825948178746 | 1 | 1.2313 | 44.797888999249 |
| C2680 |  | Transporte de material propio para relleno, d=1km |  | 44d | 2025-08-15 | 2025-09-27 | C2630 SS | 37d | 6d | 1 |  | 11178.17 | m3xkm | 1 | 0 |  | 1 | 1.2313 | 0 |
| C2650 |  | Perfilado de taludes de dique con equipo |  | 40d | 2025-08-20 | 2025-09-28 | C2630 SS+5d, C2030 | 104d | 73d | 1 | 900 | 24755.1 | m2 | 1 | 900 | 27.5056666666667 | 1 | 1.2313 | 33.8677273666667 |
| C2660 |  | Suministro, habilitación y colocación de geotextil no tejido 400 g/m2 |  | 77d | 2025-09-25 | 2025-12-10 | C2720 SS, C2670 | 31d | 0d | 1 | 1500 | 16220.7 | m2 | 1 | 1500 | 10.8138 | 1 | 1.2313 | 13.31503194 |
| C2640 |  | Relleno propio sin compactar |  | 12d | 2025-11-29 | 2025-12-10 | C2720 FF+1d, C2760 | 31d | 0d | 1 | 1100 | 10038.86 | m3 | 1 | 1100 | 9.12623636363636 | 1 | 1.2313 | 11.2371348345454 |
|  | 2 | **ENROCADO DE PROTECCIÓN** |  |  | 2025-09-25 | 2025-12-10 |  |  |  |  |  |  |  |  |  |  |  |  |  |
| C2690 |  | Transporte de roca seleccionada de cantera para enrocado de protección, d=1km |  | 77d | 2025-09-25 | 2025-12-10 | C2720 SS | 31d | 0d | 1 |  | 31317.06 | m3xkm | 1 | 0 |  | 1 | 1.2313 | 0 |
| C2700 |  | Transporte de roca seleccionada de cantera para enrocado de protección, d>1km |  | 77d | 2025-09-25 | 2025-12-10 | C2690 SS | 31d | 0d | 1 |  | 466611.57 | m3xkm | 1 | 0 |  | 1 | 1.2313 | 0 |
| C2720 |  | Colocación de roca seleccionada, en uña antisocavante |  | 76d | 2025-09-25 | 2025-12-09 | C2570 FS+1d | 31d | 0d | 1 | 170 | 20821.41 | m3 | 2 | 340 | 61.2394411764706 | 2 | 1.2313 | 75.4041239205882 |
| C2710 |  | Colocación de roca seleccionada, en cara húmeda de talud |  | 68d | 2025-10-04 | 2025-12-10 | C2720 SS+9d, C2680 | 31d | 0d | 1 | 160 | 17619.44 | m3 | 2 | 320 | 55.06075 | 2 | 1.2313 | 67.796301475 |
|  | 3 | **REMOCION DE ENROCADO DE DIQUES EN MAL ESTADO** |  |  | 2025-09-24 | 2025-10-27 |  |  |  |  |  |  |  |  |  |  |  |  |  |
| C2730 |  | Remoción de enrocado de cara húmeda de talud |  | 24d | 2025-09-24 | 2025-10-17 | C2570 | 63d | 0d | 1 | 300 | 5632 | m3 | 1 | 300 | 18.7733333333333 | 1 | 1.2313 | 23.1156053333333 |
| C2740 |  | Selección y acopio de roca removida |  | 10d | 2025-10-18 | 2025-10-27 | C2730 | 63d | 0d | 1 | 500 | 3942.4 | m3 | 1 | 500 | 7.8848 | 1 | 1.2313 | 9.70855424 |
| C2750 |  | Transporte de roca rechazada a DME, d=1km |  | 10d | 2025-10-18 | 2025-10-27 | C2740 SS | 63d | 0d | 1 |  | 1341.36 | m3xkm | 1 | 0 |  | 1 | 1.2313 | 0 |
| C2760 |  | Transporte de roca rechazada a DME, d>1km |  | 10d | 2025-10-18 | 2025-10-27 | C2750 SS | 63d | 32d | 1 |  | 1223.38 | m3xkm | 1 | 0 |  | 1 | 1.2313 | 0 |
|  | 5 | **ENCAUZAMIENTO DE RÍO - SECTOR 5 (PK 25+351 al 25+753)** |  |  | 2025-09-08 | 2025-11-13 |  |  |  |  |  |  |  |  |  |  |  |  |  |
| A4730 |  | Inicio - Sector 5 | milestone | 0d | 2025-09-08 | 2025-09-08 | A4710 SS, C2520 | 1d | 0d |  |  |  |  |  | 0 |  | 0 |  | 0 |
| A4740 |  | Fin - Sector 5 | milestone | 0d | 2025-11-13 | 2025-11-13 | C3370 FF, C2810 FF, C2840 FF, C2910 FF, C2920 FF, C2970 FF, C3260 FF, C3290 FF, C3300 FF, C3320 FF, C3330 FF, C3340 FF, C3360 FF | 58d | 25d |  |  |  |  |  | 0 |  | 0 |  | 0 |
|  | 1 | **DIPRO-004-MI** |  |  | 2025-09-08 | 2025-11-10 |  |  |  |  |  |  |  |  |  |  |  |  |  |
|  | 1 | **MOVIMIENTO DE TIERRAS PARA DIQUE LONGITUDINALES** |  |  | 2025-09-08 | 2025-11-09 |  |  |  |  |  |  |  |  |  |  |  |  |  |
|  | 1 | **EXCAVACIÓN** |  |  | 2025-09-08 | 2025-10-30 |  |  |  |  |  |  |  |  |  |  |  |  |  |
| C2770 |  | Excavación en material común |  | 17d | 2025-09-08 | 2025-09-24 | A4730 SS | 61d | 0d | 1 | 724 | 19616.23 | m3 | 2 | 1448 | 13.5471201657459 | 2 | 1.2313 | 16.6805690600829 |
| C2800 |  | Transporte de material excedente a DME, d=1km |  | 53d | 2025-09-08 | 2025-10-30 | C2770 SS | 72d | 0d | 1 |  | 12469.46 | m3xkm | 1 | 0 |  | 1 | 1.2313 | 0 |
| C2810 |  | Transporte de material excedente a DME, d>1km |  | 53d | 2025-09-08 | 2025-10-30 | C2800 SS | 72d | 14d | 1 |  | 129050.84 | m3xkm | 1 | 0 |  | 1 | 1.2313 | 0 |
| C2780 |  | Excavación para conformación de uña antisocavante |  | 21d | 2025-10-10 | 2025-10-30 | C2830 | 61d | 0d | 1 | 450 | 7400.01 | m3 | 1 | 450 | 16.4444666666667 | 1 | 1.2313 | 20.2480718066667 |
| C2790 |  | Excavación de zanja de anclaje para geotextil |  | 2d | 2025-10-10 | 2025-10-11 | C2860 SS | 80d | 19d | 1 | 25 | 13.75 | m3 | 1 | 25 | 0.55 | 1 | 1.2313 | 0.677215 |

| ID | WBS | Activity | Duration | Start | Finish | Predecessors | Total float | Free float | Cuadrilla | Rendimiento | Metrado | Unidad | Turno | RCuad | Dur. Cal. | Cuadrilla día | FactorR | FDur |
| --- | --- | --- | --- | --- | --- | --- | --- | --- | --- | --- | --- | --- | --- | --- | --- | --- | --- | --- |
|  | 2 | **RELLENO** |  | 2025-09-10 | 2025-11-09 |  |  |  |  |  |  |  |  |  |  |  |  |  |
| C2870 |  | Proceso y selección de material propio | 16d | 2025-09-10 | 2025-09-25 | C2770 SS+2d | 85d | 5d | 1 | 900 | 11240.73 | m3 | 1 | 900 | 12.4897 | 1 | 1.2313 | 15.37856761 |
| C2820 |  | Conformación y compactación de superficie para fundación con equipo pesado | 4d | 2025-09-25 | 2025-09-28 | C2770 | 61d | 0d | 1 | 2800 | 15237.23 | m2 | 2 | 5600 | 2.72093392857143 | 2 | 1.2313 | 3.35028594625 |
| C2830 |  | Relleno compactado con equipo pesado | 11d | 2025-09-29 | 2025-10-09 | C2820 | 61d | 0d | 1 | 532.6 | 4617.43 | m3 | 1 | 532.6 | 8.66960195268494 | 1 | 1.2313 | 10.674880884341 |
| C2880 |  | Transporte de material propio para relleno, d=1km | 11d | 2025-09-29 | 2025-10-09 | C2830 SS | 62d | 1d | 1 |  | 1950.14 | m3xkm | 1 | 0 |  | 1 | 1.2313 | 0 |
| C2850 |  | Perfilado de taludes de dique con equipo | 11d | 2025-10-01 | 2025-10-11 | C2830 SS+2d, C2870 | 80d | 19d | 1 | 900 | 7908.32 | m2 | 1 | 900 | 8.78702222222222 | 1 | 1.2313 | 10.8194604622222 |
| C2860 |  | Suministro, habilitación y colocación de geotextil no tejido 400 g/m2 | 4d | 2025-10-10 | 2025-10-13 | C2830 | 77d | 0d | 1 | 1500 | 3709.18 | m2 | 1 | 1500 | 2.47278666666667 | 1 | 1.2313 | 3.04474222266667 |
| C2890 |  | Colocación de protección para geotextil | 5d | 2025-10-10 | 2025-10-14 | C2860 SS | 77d | 16d | 1 | 830 | 3295.18 | m2 | 1 | 830 | 3.97009638554217 | 1 | 1.2313 | 4.88837967951807 |
| C2840 |  | Relleno propio sin compactar | 3d | 2025-11-07 | 2025-11-09 | C2930 | 62d | 4d | 1 | 1100 | 2718.63 | m3 | 1 | 1100 | 2.47148181818182 | 1 | 1.2313 | 3.04313556272727 |
|  | 2 | **ENROCADO DE PROTECCIÓN** |  | 2025-10-11 | 2025-11-10 |  |  |  |  |  |  |  |  |  |  |  |  |  |
| C2900 |  | Transporte de roca seleccionada de cantera para enrocado de protección, d=1km | 31d | 2025-10-11 | 2025-11-10 | C2930 SS | 61d | 0d | 1 |  | 7687.7 | m3xkm | 1 | 0 |  | 1 | 1.2313 | 0 |
| C2910 |  | Transporte de roca seleccionada de cantera para enrocado de protección, d>1km | 31d | 2025-10-11 | 2025-11-10 | C2900 SS, C2880 | 61d | 3d | 1 |  | 116518.66 | m3xkm | 1 | 0 |  | 1 | 1.2313 | 0 |
| C2930 |  | Colocación de roca seleccionada, en uña antisocavante | 27d | 2025-10-11 | 2025-11-06 | C2780 SS+1d | 61d | 0d | 1 | 170 | 7400.01 | m3 | 2 | 340 | 21.7647352941176 | 2 | 1.2313 | 26.798918567647 |
| C2920 |  | Colocación de roca seleccionada, en cara húmeda de talud | 11d | 2025-10-31 | 2025-11-10 | C2780, C2790, C2850, C2890, C3020, C3060, C3090, C3140, C3160, C3170 | 61d | 3d | 1 | 160 | 2679.16 | m3 | 2 | 320 | 8.372375 | 2 | 1.2313 | 10.3089053375 |
|  | 3 | **REMOCION DE ENROCADO DE DIQUES EN MAL ESTADO** |  | 2025-09-25 | 2025-10-11 |  |  |  |  |  |  |  |  |  |  |  |  |  |
| C2940 |  | Remoción de enrocado de cara húmeda de talud | 12d | 2025-09-25 | 2025-10-06 | C2770 | 91d | 0d | 1 | 300 | 2840 | m3 | 1 | 300 | 9.46666666666667 | 1 | 1.2313 | 11.6563066666667 |
| C2950 |  | Selección y acopio de roca removida | 5d | 2025-10-07 | 2025-10-11 | C2940 | 91d | 0d | 1 | 500 | 2130 | m3 | 1 | 500 | 4.26 | 1 | 1.2313 | 5.245338 |
| C2960 |  | Transporte de roca rechazada a DME, d=1km | 5d | 2025-10-07 | 2025-10-11 | C2950 SS | 91d | 0d | 1 |  | 605.46 | m3xkm | 1 | 0 |  | 1 | 1.2313 | 0 |
| C2970 |  | Transporte de roca rechazada a DME, d>1km | 5d | 2025-10-07 | 2025-10-11 | C2960 SS | 91d | 33d | 1 |  | 6539.5 | m3xkm | 1 | 0 |  | 1 | 1.2313 | 0 |
|  | 4 | **SISTEMA DE CONFINAMIENTO CON GEOCELDAS** |  | 2025-10-10 | 2025-10-14 |  |  |  |  |  |  |  |  |  |  |  |  |  |
| C2980 |  | Suministro, habilitación y colocación de geotextil no tejido 200 g/m2 | 2d | 2025-10-10 | 2025-10-11 | C2860 SS | 77d | 0d | 1 | 1500 | 1450.89 | m2 | 1 | 1500 | 0.96726 | 1 | 1.2313 | 1.190987238 |
| C2990 |  | Suministro, habilitación y colocación de sistema de confinamiento geocelda h=100 mm | 2d | 2025-10-11 | 2025-10-12 | C2980 SS+1d | 77d | 0d | 1 | 750 | 642.86 | m2 | 1 | 750 | 0.857146666666667 | 1 | 1.2313 | 1.05540469066667 |
| C3000 |  | Suministro y colocación de concreto premezclado f'c=210 kg/cm2 para geocelda | 2d | 2025-10-13 | 2025-10-14 | C2990 | 77d | 0d | 1 | 337.5 | 64.29 | m3 | 1 | 337.5 | 0.190488888888889 | 1 | 1.2313 | 0.234548968888889 |
| C3010 |  | Transporte de concreto premezclado con camión mixer, d=1km | 2d | 2025-10-13 | 2025-10-14 | C3000 SS | 77d | 0d | 1 | 40 | 56.58 | m3xkm | 1 | 40 | 1.4145 | 1 | 1.2313 | 1.74167385 |
| C3020 |  | Transporte de concreto premezclado con camión mixer, d>1km | 2d | 2025-10-13 | 2025-10-14 | C3010 SS | 77d | 16d | 1 |  | 2301.77 | m3xkm | 1 | 0 |  | 1 | 1.2313 | 0 |

| ID | WBS | Activity | Duration | Start | Finish | Predecessors | Total float | Free float | Cuadrilla | Rendimiento | Metrado | Unidad | Turno | RCuad | Dur. Cal. | Cuadrilla día | FactorR | FDur |
| --- | --- | --- | --- | --- | --- | --- | --- | --- | --- | --- | --- | --- | --- | --- | --- | --- | --- | --- |
|  | 2 | **DIPRO-005-MD** |  | 2025-09-08 | 2025-10-25 |  |  |  |  |  |  |  |  |  |  |  |  |  |
|  | 1 | **MOVIMIENTO DE TIERRAS PARA DIQUE LONGITUDINALES** |  | 2025-09-08 | 2025-10-24 |  |  |  |  |  |  |  |  |  |  |  |  |  |
|  | 1 | **EXCAVACIÓN** |  | 2025-09-08 | 2025-10-11 |  |  |  |  |  |  |  |  |  |  |  |  |  |
| C3030 |  | Excavación en material común | 7d | 2025-09-08 | 2025-09-14 | A4730 SS | 58d | 0d | 1 | 724 | 3869.73 | m3 | 1 | 724 | 5.34493093922652 | 1 | 1.2313 | 6.58121346546962 |
| C3050 |  | Transporte de material excedente a DME, d=1km | 34d | 2025-09-08 | 2025-10-11 | C3030 SS | 80d | 0d | 1 |  | 2835.61 | m3xkm | 1 | 0 |  | 1 | 1.2313 | 0 |
| C3060 |  | Transporte de material excedente a DME, d>1km | 34d | 2025-09-08 | 2025-10-11 | C3050 SS | 80d | 19d | 1 |  | 29346.69 | m3xkm | 1 | 0 |  | 1 | 1.2313 | 0 |
| C3040 |  | Excavación para conformación de uña antisocavante | 17d | 2025-09-25 | 2025-10-11 | C3100, C3120, C3130 | 58d | 0d | 1 | 450 | 2277 | m3 | 1 | 450 | 5.06 | 1 | 1.2313 | 6.230378 |
|  | 2 | **RELLENO** |  | 2025-09-09 | 2025-10-24 |  |  |  |  |  |  |  |  |  |  |  |  |  |
| C3120 |  | Proceso y selección de material propio | 6d | 2025-09-09 | 2025-09-14 | C3030 SS+1d | 68d | 10d | 1 | 900 | 2557.49 | m3 | 1 | 900 | 2.84165555555556 | 1 | 1.2313 | 3.49893048555556 |
| C3070 |  | Conformación y compactación de superficie para fundación con equipo pesado | 2d | 2025-09-15 | 2025-09-16 | C3030 | 58d | 0d | 1 | 2800 | 3466.77 | m2 | 1 | 2800 | 1.23813214285714 | 1 | 1.2313 | 1.5245121075 |
| C3080 |  | Relleno compactado con equipo pesado | 3d | 2025-09-17 | 2025-09-19 | C3070 | 58d | 0d | 1 | 532.6 | 1216.46 | m3 | 1 | 532.6 | 2.28400300413068 | 1 | 1.2313 | 2.81229289898611 |
| C3130 |  | Transporte de material propio para relleno, d=1km | 3d | 2025-09-17 | 2025-09-19 | C3080 SS | 63d | 5d | 1 |  | 1633.98 | m3xkm | 1 | 0 |  | 1 | 1.2313 | 0 |
| C3100 |  | Perfilado de taludes de dique con equipo | 5d | 2025-09-20 | 2025-09-24 | C3080 | 58d | 0d | 1 | 900 | 3460.6 | m2 | 1 | 900 | 3.84511111111111 | 1 | 1.2313 | 4.73448531111111 |
| C3110 |  | Suministro, habilitación y colocación de geotextil no tejido 400 g/m2 | 29d | 2025-09-26 | 2025-10-24 | C3180 SS, C3100, C3220 | 67d | 0d | 1 | 1500 | 2243.44 | m2 | 1 | 1500 | 1.49562666666667 | 1 | 1.2313 | 1.84156511466667 |
| C3140 |  | Colocación de protección para geotextil | 29d | 2025-09-26 | 2025-10-24 | C3110 SS | 67d | 6d | 1 | 830 | 1995.04 | m2 | 1 | 830 | 2.40366265060241 | 1 | 1.2313 | 2.95962982168675 |
| C3090 |  | Relleno propio sin compactar | 5d | 2025-10-13 | 2025-10-17 | C3180 | 74d | 13d | 1 | 1100 | 592.72 | m3 | 1 | 1100 | 0.538836363636364 | 1 | 1.2313 | 0.663469214545455 |
|  | 2 | **ENROCADO DE PROTECCIÓN** |  | 2025-09-26 | 2025-10-25 |  |  |  |  |  |  |  |  |  |  |  |  |  |
| C3150 |  | Transporte de roca seleccionada de cantera para enrocado de protección, d=1km | 30d | 2025-09-26 | 2025-10-25 | C3180 SS | 66d | 0d | 1 |  | 2954.81 | m3xkm | 1 | 0 |  | 1 | 1.2313 | 0 |
| C3160 |  | Transporte de roca seleccionada de cantera para enrocado de protección, d>1km | 30d | 2025-09-26 | 2025-10-25 | C3150 SS | 66d | 5d | 1 |  | 44784.65 | m3xkm | 1 | 0 |  | 1 | 1.2313 | 0 |
| C3180 |  | Colocación de roca seleccionada, en uña antisocavante | 17d | 2025-09-26 | 2025-10-12 | C3040 SS+1d | 66d | 0d | 1 | 170 | 2277 | m3 | 1 | 170 | 13.3941176470588 | 1 | 1.2313 | 16.4921770588235 |
| C3170 |  | Colocación de roca seleccionada, en cara húmeda de talud | 13d | 2025-10-13 | 2025-10-25 | C3180 | 66d | 5d | 1 | 160 | 1596.99 | m3 | 1 | 160 | 9.9811875 | 1 | 1.2313 | 12.28983616875 |
|  | 3 | **REMOCION DE ENROCADO DE DIQUES EN MAL ESTADO** |  | 2025-09-15 | 2025-09-18 |  |  |  |  |  |  |  |  |  |  |  |  |  |
| C3190 |  | Remoción de enrocado de cara húmeda de talud | 3d | 2025-09-15 | 2025-09-17 | C3030 | 74d | 0d | 1 | 300 | 520 | m3 | 1 | 300 | 1.73333333333333 | 1 | 1.2313 | 2.13425333333333 |
| C3200 |  | Selección y acopio de roca removida | 1d | 2025-09-18 | 2025-09-18 | C3190 | 74d | 0d | 1 | 500 | 416 | m3 | 1 | 500 | 0.832 | 1 | 1.2313 | 1.0244416 |
| C3210 |  | Transporte de roca rechazada a DME, d=1km | 1d | 2025-09-18 | 2025-09-18 | C3200 SS | 74d | 0d | 1 |  | 110.86 | m3xkm | 1 | 0 |  | 1 | 1.2313 | 0 |
| C3220 |  | Transporte de roca rechazada a DME, d>1km | 1d | 2025-09-18 | 2025-09-18 | C3210 SS | 74d | 7d | 1 |  | 1197.37 | m3xkm | 1 | 0 |  | 1 | 1.2313 | 0 |

| ID | WBS | Activity | Type | Duration | Start | Finish | Predecessors | Total float | Free float | Cuadrilla | Rendimiento | Metrado | Unidad | Turno | RCuad | Dur. Cal. | Cuadrilla día | FactorR | FDur |
| --- | --- | --- | --- | --- | --- | --- | --- | --- | --- | --- | --- | --- | --- | --- | --- | --- | --- | --- | --- |
|  | 3 | **DIPRO-006-MD** |  |  | 2025-10-12 | 2025-11-13 |  |  |  |  |  |  |  |  |  |  |  |  |  |
|  | 1 | **MOVIMIENTO DE TIERRAS PARA DIQUE LONGITUDINALES** |  |  | 2025-10-12 | 2025-11-12 |  |  |  |  |  |  |  |  |  |  |  |  |  |
|  | 1 | **EXCAVACIÓN** |  |  | 2025-10-12 | 2025-11-03 |  |  |  |  |  |  |  |  |  |  |  |  |  |
| C3230 |  | Excavación en material común |  | 12d | 2025-10-12 | 2025-10-23 | C3040 | 58d | 0d | 1 | 724 | 12428.32 | m3 | 2 | 1448 | 8.58309392265193 | 2 | 1.2313 | 10.5683635469613 |
| C3250 |  | Transporte de material excedente a DME, d=1km |  | 23d | 2025-10-12 | 2025-11-03 | C3230 SS | 68d | 0d | 1 |  | 7105.57 | m3xkm | 1 | 0 |  | 1 | 1.2313 | 0 |
| C3260 |  | Transporte de material excedente a DME, d>1km |  | 23d | 2025-10-12 | 2025-11-03 | C3250 SS | 68d | 10d | 1 |  | 73538.1 | m3xkm | 1 | 0 |  | 1 | 1.2313 | 0 |
| C3240 |  | Excavación para conformación de uña antisocavante |  | 11d | 2025-10-24 | 2025-11-03 | C3230 | 58d | 0d | 1 | 450 | 2974.4 | m3 | 1 | 450 | 6.60977777777778 | 1 | 1.2313 | 8.13861937777778 |
|  | 2 | **RELLENO** |  |  | 2025-10-13 | 2025-11-12 |  |  |  |  |  |  |  |  |  |  |  |  |  |
| C3320 |  | Proceso y selección de material propio |  | 12d | 2025-10-13 | 2025-10-24 | C3230 SS+1d | 78d | 20d | 1 | 900 | 6408.65 | m3 | 1 | 900 | 7.12072222222222 | 1 | 1.2313 | 8.76774527222222 |
| C3270 |  | Conformación y compactación de superficie para fundación con equipo pesado |  | 10d | 2025-10-15 | 2025-10-24 | C3230 FF+1d | 76d | 0d | 1 | 2800 | 8687.17 | m2 | 1 | 2800 | 3.10256071428571 | 1 | 1.2313 | 3.82018300749999 |
| C3280 |  | Relleno compactado con equipo pesado |  | 10d | 2025-10-16 | 2025-10-25 | C3270 SS+1d | 76d | 0d | 1 | 532.6 | 8051.7 | m3 | 2 | 1065.2 | 7.55886218550507 | 2 | 1.2313 | 9.30722700901239 |
| C3330 |  | Transporte de material propio para relleno, d=1km |  | 10d | 2025-10-16 | 2025-10-25 | C3280 SS | 77d | 19d | 1 |  | 4094.49 | m3xkm | 1 | 0 |  | 1 | 1.2313 | 0 |
| C3300 |  | Perfilado de taludes de dique con equipo |  | 10d | 2025-10-17 | 2025-10-26 | C3280 SS+1d | 76d | 18d | 1 | 900 | 3404.39 | m2 | 1 | 900 | 3.78265555555556 | 1 | 1.2313 | 4.65758378555556 |
| C3310 |  | Suministro, habilitación y colocación de geotextil no tejido 400 g/m2 |  | 19d | 2025-10-25 | 2025-11-12 | C3380 SS | 59d | 0d | 1 | 1500 | 2185.19 | m2 | 1 | 1500 | 1.45679333333333 | 1 | 1.2313 | 1.79374963133333 |
| C3340 |  | Colocación de protección para geotextil |  | 19d | 2025-10-25 | 2025-11-12 | C3310 SS | 59d | 1d | 1 | 830 | 1993.19 | m2 | 1 | 830 | 2.40143373493976 | 1 | 1.2313 | 2.95688535783133 |
| C3290 |  | Relleno propio sin compactar |  | 4d | 2025-11-05 | 2025-11-08 | C3380 | 63d | 5d | 1 | 1100 | 3009.93 | m3 | 1 | 1100 | 2.7363 | 1 | 1.2313 | 3.36920619 |
|  | 2 | **ENROCADO DE PROTECCIÓN** |  |  | 2025-10-25 | 2025-11-13 |  |  |  |  |  |  |  |  |  |  |  |  |  |
| C3350 |  | Transporte de roca seleccionada de cantera para enrocado de protección, d=1km |  | 20d | 2025-10-25 | 2025-11-13 | C3380 SS | 58d | 0d | 1 |  | 3929.85 | m3xkm | 1 | 0 |  | 1 | 1.2313 | 0 |
| C3360 |  | Transporte de roca seleccionada de cantera para enrocado de protección, d>1km |  | 20d | 2025-10-25 | 2025-11-13 | C3350 SS | 58d | 0d | 1 |  | 59562.81 | m3xkm | 1 | 0 |  | 1 | 1.2313 | 0 |
| C3380 |  | Colocación de roca seleccionada, en uña antisocavante |  | 11d | 2025-10-25 | 2025-11-04 | C3240 SS+1d | 58d | 0d | 1 | 170 | 2974.4 | m3 | 2 | 340 | 8.74823529411765 | 2 | 1.2313 | 10.7717021176471 |
| C3370 |  | Colocación de roca seleccionada, en cara húmeda de talud |  | 9d | 2025-11-05 | 2025-11-13 | C3380 | 58d | 0d | 1 | 160 | 2177.94 | m3 | 2 | 320 | 6.8060625 | 2 | 1.2313 | 8.38030475625 |
|  | 2 | **ENCAUZAMIENTO DE RÍO - SECTOR 4 (PK 27+459 al 27+857)** |  |  | 2025-09-08 | 2025-12-08 |  |  |  |  |  |  |  |  |  |  |  |  |  |
| A4750 |  | Inicio - Sector 4 | milestone | 0d | 2025-09-08 | 2025-09-08 | A4730 SS | 1d | 0d |  |  |  |  |  | 0 |  | 0 |  | 0 |
| A4760 |  | Fin - Sector 4 | milestone | 0d | 2025-12-08 | 2025-12-08 | C3520 FF, C3660 FF, C4120 FF, A4740 FF, C3640 FF, C4020 FF, C4040 FF, C4070 FF, C4130 FF, C4140 FF | 33d | 2d |  |  |  |  |  | 0 |  | 0 |  | 0 |

| ID | WBS | Activity | Duration | Start | Finish | Predecessors | Total float | Free float | Cuadrilla | Rendimiento | Metrado | Unidad | Turno | RCuad | Dur. Cal. | Cuadrilla día | FactorR | FDur |
| --- | --- | --- | --- | --- | --- | --- | --- | --- | --- | --- | --- | --- | --- | --- | --- | --- | --- | --- |
|  | 1 | **DIPRO-006-MI** |  | 2025-09-08 | 2025-11-08 |  |  |  |  |  |  |  |  |  |  |  |  |  |
|  | 1 | **MOVIMIENTO DE TIERRAS PARA DIQUE LONGITUDINALES** |  | 2025-09-08 | 2025-10-08 |  |  |  |  |  |  |  |  |  |  |  |  |  |
|  | 1 | **EXCAVACIÓN** |  | 2025-09-08 | 2025-10-08 |  |  |  |  |  |  |  |  |  |  |  |  |  |
| C3390 |  | Desbroce y remoción de suelo vegetal con equipo | 1d | 2025-09-08 | 2025-09-08 | A4750 SS | 1d | 0d | 1 | 10000 | 3515.62 | m2 | 1 | 10000 | 0.351562 | 1 | 1.2313 | 0.4328782906 |
| C3400 |  | Transporte de material excedente a DMO, d=1km | 1d | 2025-09-08 | 2025-09-08 | C3390 SS | 1d | 0d | 1 |  | 948.33 | m3xkm | 1 | 0 |  | 1 | 1.2313 | 0 |
| C3410 |  | Transporte de material excedente a DMO, d>1km | 1d | 2025-09-08 | 2025-09-08 | C3400 SS | 1d | 0d | 1 |  | 12015.97 | m3xkm | 1 | 0 |  | 1 | 1.2313 | 0 |
| C3420 |  | Excavación en material común | 12d | 2025-09-09 | 2025-09-20 | C3390, C3410 | 1d | 0d | 1 | 724 | 13613.89 | m3 | 2 | 1448 | 9.40185773480663 | 2 | 1.2313 | 11.5765074288674 |
| C3450 |  | Transporte de material excedente a DME, d=1km | 22d | 2025-09-09 | 2025-09-30 | C3420 SS | 89d | 0d | 1 |  | 7047.8 | m3xkm | 1 | 0 |  | 1 | 1.2313 | 0 |
| C3460 |  | Transporte de material excedente a DME, d>1km | 22d | 2025-09-09 | 2025-09-30 | C3450 SS | 89d | 1d | 1 |  | 52829.21 | m3xkm | 1 | 0 |  | 1 | 1.2313 | 0 |
| C3430 |  | Excavación para conformación de uña antisocavante | 10d | 2025-09-21 | 2025-09-30 | C3420 | 1d | 0d | 1 | 450 | 2522.28 | m3 | 1 | 450 | 5.60506666666667 | 1 | 1.2313 | 6.90151858666667 |
| C3440 |  | Colocación de protección para geotextil | 17d | 2025-09-22 | 2025-10-08 | C3510 SS | 88d | 25d | 1 | 830 | 1534.3 | m2 | 1 | 830 | 1.84855421686747 | 1 | 1.2313 | 2.27612480722892 |
|  | 2 | **RELLENO** |  | 2025-09-10 | 2025-10-08 |  |  |  |  |  |  |  |  |  |  |  |  |  |
| C3530 |  | Proceso y selección de material propio | 12d | 2025-09-10 | 2025-09-21 | C3420 SS+1d | 100d | 10d | 1 | 900 | 12120 | m3 | 1 | 900 | 13.4666666666667 | 1 | 1.2313 | 16.5815066666667 |
| C3470 |  | Conformación y compactación de superficie para fundación con equipo pesado | 10d | 2025-09-12 | 2025-09-21 | C3420 FF+1d | 63d | 0d | 1 | 2800 | 10473.26 | m2 | 1 | 2800 | 3.74045 | 1 | 1.2313 | 4.605616085 |
| C3480 |  | Relleno compactado con equipo pesado | 10d | 2025-09-13 | 2025-09-22 | C3470 SS+1d | 63d | 0d | 1 | 532.6 | 7944.27 | m3 | 2 | 1065.2 | 7.45800788584303 | 2 | 1.2313 | 9.18304510983852 |
| C3540 |  | Transporte de material propio para relleno, d=1km | 10d | 2025-09-13 | 2025-09-22 | C3480 SS | 99d | 9d | 1 |  | 4605.61 | m3xkm | 1 | 0 |  | 1 | 1.2313 | 0 |
| C3500 |  | Perfilado de taludes de dique con equipo | 8d | 2025-09-16 | 2025-09-23 | C3480 FF+1d | 63d | 0d | 1 | 900 | 2627.77 | m2 | 1 | 900 | 2.91974444444444 | 1 | 1.2313 | 3.59508133444444 |
| C3510 |  | Suministro, habilitación y colocación de geotextil no tejido 200 g/m2 | 17d | 2025-09-22 | 2025-10-08 | C3520 SS | 88d | 0d | 1 | 750 | 292.5 | m2 | 1 | 750 | 0.39 | 1 | 1.2313 | 0.480207 |
| C3520 |  | Suministro, habilitación y colocación de geotextil no tejido 400 g/m2 | 17d | 2025-09-22 | 2025-10-08 | C3580 SS | 88d | 0d | 1 | 1500 | 1686.69 | m2 | 1 | 1500 | 1.12446 | 1 | 1.2313 | 1.384547598 |
| C3490 |  | Relleno propio sin compactar | 5d | 2025-10-02 | 2025-10-06 | C3580, C3530, C3540 | 90d | 27d | 1 | 1100 | 4175.73 | m3 | 1 | 1100 | 3.79611818181818 | 1 | 1.2313 | 4.67416031727273 |
|  | 2 | **ENROCADO DE PROTECCIÓN** |  | 2025-09-22 | 2025-10-08 |  |  |  |  |  |  |  |  |  |  |  |  |  |
| C3550 |  | Transporte de roca seleccionada de cantera para enrocado de protección, d=1km | 17d | 2025-09-22 | 2025-10-08 | C3580 SS | 88d | 0d | 1 |  | 3367.95 | m3xkm | 1 | 0 |  | 1 | 1.2313 | 0 |
| C3560 |  | Transporte de roca seleccionada de cantera para enrocado de protección, d>1km | 17d | 2025-09-22 | 2025-10-08 | C3550 SS | 88d | 25d | 1 |  | 52303.21 | m3xkm | 1 | 0 |  | 1 | 1.2313 | 0 |
| C3580 |  | Colocación de roca seleccionada, en uña antisocavante | 10d | 2025-09-22 | 2025-10-01 | C3430 SS+1d | 88d | 0d | 1 | 170 | 2522.28 | m3 | 2 | 340 | 7.41847058823529 | 2 | 1.2313 | 9.13436283529411 |
| C3570 |  | Colocación de roca seleccionada, en cara húmeda de talud | 7d | 2025-10-02 | 2025-10-08 | C3580, C3460 | 88d | 25d | 1 | 160 | 1679.25 | m3 | 2 | 320 | 5.24765625 | 2 | 1.2313 | 6.461439140625 |

| ID | WBS | Activity | Duration | Start | Finish | Predecessors | Total float | Free float | Cuadrilla | Rendimiento | Metrado | Unidad | Turno | RCuad | Dur. Cal. | Cuadrilla día | FactorR | FDur |
| --- | --- | --- | --- | --- | --- | --- | --- | --- | --- | --- | --- | --- | --- | --- | --- | --- | --- | --- |
|  | 3 | **GAVIONES** |  | 2025-11-03 | 2025-11-08 |  |  |  |  |  |  |  |  |  |  |  |  |  |
| C3630 |  | Suministro y colocación gavión caja plastificada de 5.0x1.0x1.0 m (Malla 10x12 cm. Dext=3.7mm) | 6d | 2025-11-03 | 2025-11-08 | C3670, C3440 | 63d | 0d | 1 | 4 | 16 | Und | 1 | 4 | 4 | 1 | 1.2313 | 4.9252 |
| C3640 |  | Suministro y colocación gavión caja plastificada de 5.0x1.5x0.5 m (Malla 10x12 cm. Dext=3.7mm) | 6d | 2025-11-03 | 2025-11-08 | C3630 SS, C3490, C3560, C3570, C3910 | 63d | 30d | 1 | 5 | 24 | Und | 1 | 5 | 4.8 | 1 | 1.2313 | 5.91024 |
| C3650 |  | Transporte de roca para gavión, d=1km | 5d | 2025-11-03 | 2025-11-07 | C3630 SS, C3900 | 64d | 0d | 1 |  | 145.86 | m3xkm | 1 | 0 |  | 1 | 1.2313 | 0 |
| C3660 |  | Transporte de roca para gavión, d>1km | 5d | 2025-11-03 | 2025-11-07 | C3650 SS, C3760, C3790, C3810, C3840 | 64d | 31d | 1 |  | 2311.55 | m3xkm | 1 | 0 |  | 1 | 1.2313 | 0 |
|  | 4 | **CONCRETO ARMADO** |  | 2025-09-24 | 2025-11-02 |  |  |  |  |  |  |  |  |  |  |  |  |  |
| C3670 |  | Suministro y colocación de concreto premezclado f´c=100 kg/cm2, e=0.10 m para solado | 40d | 2025-09-24 | 2025-11-02 | C3500 | 63d | 0d | 1 | 15 | 226.72 | m2 | 1 | 15 | 15.1146666666667 | 1 | 1.2313 | 18.6106890666667 |
| C3680 |  | Suministro, habilitación, encofrado y desencofrado para estructuras | 40d | 2025-09-24 | 2025-11-02 | C3670 SS | 64d | 0d | 3 | 16 | 569.8 | m2 | 1 | 48 | 11.8708333333333 | 3 | 1.2313 | 14.6165570833333 |
| C3690 |  | Suministro, habilitación y colocación de acero de refuerzo f'y=4200 kg/cm2 | 40d | 2025-09-24 | 2025-11-02 | C3680 SS | 64d | 0d | 4 | 312.5 | 22599.66 | kg | 1 | 1250 | 18.079728 | 4 | 1.2313 | 22.2615690864 |
| C3700 |  | Suministro y colocación de concreto estructural premezclado f´c=280 kg/cm2 | 40d | 2025-09-24 | 2025-11-02 | C3690 SS | 64d | 0d | 1 | 40 | 307.75 | m3 | 1 | 40 | 7.69375 | 1 | 1.2313 | 9.473314375 |
| C3710 |  | Transporte de concreto premezclado con camión mixer, d=1km | 40d | 2025-09-24 | 2025-11-02 | C3700 SS | 64d | 0d | 1 |  | 290.77 | m3xkm | 1 | 0 |  | 1 | 1.2313 | 0 |
| C3720 |  | Transporte de concreto premezclado con camión mixer, d>1km | 40d | 2025-09-24 | 2025-11-02 | C3710 SS | 64d | 0d | 1 |  | 11886.27 | m3xkm | 1 | 0 |  | 1 | 1.2313 | 0 |
| C3730 |  | Suministro, habilitación y colocación de geocompuesto de drenaje | 40d | 2025-09-24 | 2025-11-02 | C3720 SS | 64d | 0d | 1 | 50 | 203.83 | m2 | 1 | 50 | 4.0766 | 1 | 1.2313 | 5.01951758 |
| C3740 |  | Suministro, habilitación e instalación de Tubería PVC Ø=2" | 40d | 2025-09-24 | 2025-11-02 | C3730 SS | 64d | 0d | 1 | 100 | 16.2 | m | 1 | 100 | 0.162 | 1 | 1.2313 | 0.1994706 |
| C3750 |  | Suministro, habilitación e instalación de Tubería HDPE corrugada Ø=4" | 40d | 2025-09-24 | 2025-11-02 | C3740 SS | 64d | 0d | 1 | 50 | 55.36 | m | 1 | 50 | 1.1072 | 1 | 1.2313 | 1.36329536 |
| C3760 |  | Junta de Dilatación para muros de Poliestireno Expandido e=1" | 40d | 2025-09-24 | 2025-11-02 | C3750 SS | 64d | 0d | 1 | 40 | 77.25 | m | 1 | 40 | 1.93125 | 1 | 1.2313 | 2.377948125 |
|  | 2 | **DIPRO-007-MI** |  | 2025-10-01 | 2025-10-26 |  |  |  |  |  |  |  |  |  |  |  |  |  |
|  | 1 | **MOVIMIENTO DE TIERRAS PARA DIQUE LONGITUDINALES** |  | 2025-10-01 | 2025-10-25 |  |  |  |  |  |  |  |  |  |  |  |  |  |
|  | 1 | **EXCAVACIÓN** |  | 2025-10-01 | 2025-10-25 |  |  |  |  |  |  |  |  |  |  |  |  |  |
| C3770 |  | Excavación en material común | 2d | 2025-10-01 | 2025-10-02 | C3430 | 1d | 0d | 1 | 724 | 2374.97 | m3 | 2 | 1448 | 1.6401726519337 | 2 | 1.2313 | 2.01954458632596 |
| C3800 |  | Transporte de material excedente a DME, d=1km | 14d | 2025-10-01 | 2025-10-14 | C3770 SS | 83d | 0d | 1 |  | 1878.37 | m3xkm | 1 | 0 |  | 1 | 1.2313 | 0 |
| C3810 |  | Transporte de material excedente a DME, d>1km | 14d | 2025-10-01 | 2025-10-14 | C3800 SS | 83d | 19d | 1 |  | 14079.94 | m3xkm | 1 | 0 |  | 1 | 1.2313 | 0 |
| C3780 |  | Excavación para conformación de uña antisocavante | 5d | 2025-10-10 | 2025-10-14 | C3850 | 1d | 0d | 1 | 450 | 1925.61 | m3 | 1 | 450 | 4.27913333333333 | 1 | 1.2313 | 5.26889687333333 |
| C3790 |  | Colocación de protección para geotextil | 16d | 2025-10-10 | 2025-10-25 | C3860 SS | 72d | 8d | 1 | 830 | 2091.15 | m2 | 1 | 830 | 2.5194578313253 | 1 | 1.2313 | 3.10220842771084 |

| ID | WBS | Activity | Duration | Start | Finish | Predecessors | Total float | Free float | Cuadrilla | Rendimiento | Metrado | Unidad | Turno | RCuad | Dur. Cal. | Cuadrilla día | FactorR | FDur |
| --- | --- | --- | --- | --- | --- | --- | --- | --- | --- | --- | --- | --- | --- | --- | --- | --- | --- | --- |
|  | 2 | **RELLENO** |  | 2025-10-01 | 2025-10-25 |  |  |  |  |  |  |  |  |  |  |  |  |  |
| C3870 |  | Proceso y selección de material propio | 2d | 2025-10-01 | 2025-10-02 | C3770 SS | 79d | 7d | 1 | 900 | 887.18 | m3 | 1 | 900 | 0.985755555555555 | 1 | 1.2313 | 1.21376081555556 |
| C3820 |  | Conformación y compactación de superficie para fundación con equipo pesado | 2d | 2025-10-03 | 2025-10-04 | C3770 | 1d | 0d | 1 | 2800 | 2791.31 | m2 | 1 | 2800 | 0.996896428571429 | 1 | 1.2313 | 1.2274785725 |
| C3830 |  | Relleno compactado con equipo pesado | 2d | 2025-10-05 | 2025-10-06 | C3820 | 1d | 0d | 1 | 532.6 | 486.57 | m3 | 1 | 532.6 | 0.913574915508825 | 1 | 1.2313 | 1.12488479346602 |
| C3880 |  | Transporte de material propio para relleno, d=1km | 2d | 2025-10-05 | 2025-10-06 | C3830 SS | 75d | 3d | 1 |  | 337.13 | m3xkm | 1 | 0 |  | 1 | 1.2313 | 0 |
| C3850 |  | Perfilado de taludes de dique con equipo | 3d | 2025-10-07 | 2025-10-09 | C3830 | 1d | 0d | 1 | 900 | 3365.55 | m2 | 2 | 1800 | 1.86975 | 2 | 1.2313 | 2.302223175 |
| C3860 |  | Suministro, habilitación y colocación de geotextil no tejido 400 g/m2 | 16d | 2025-10-10 | 2025-10-25 | C3920 SS, C3870, C3880 | 72d | 0d | 1 | 1500 | 2307.15 | m2 | 1 | 1500 | 1.5381 | 1 | 1.2313 | 1.89386253 |
| C3840 |  | Relleno propio sin compactar | 1d | 2025-10-17 | 2025-10-17 | C3920 | 80d | 16d | 1 | 1100 | 400.61 | m3 | 1 | 1100 | 0.364190909090909 | 1 | 1.2313 | 0.448428266363636 |
|  | 2 | **ENROCADO DE PROTECCIÓN** |  | 2025-10-10 | 2025-10-26 |  |  |  |  |  |  |  |  |  |  |  |  |  |
| C3890 |  | Transporte de roca seleccionada de cantera para enrocado de protección, d=1km | 17d | 2025-10-10 | 2025-10-26 | C3920 SS | 71d | 0d | 1 |  | 3532.26 | m3xkm | 1 | 0 |  | 1 | 1.2313 | 0 |
| C3900 |  | Transporte de roca seleccionada de cantera para enrocado de protección, d>1km | 17d | 2025-10-10 | 2025-10-26 | C3890 SS | 71d | 7d | 1 |  | 54854.8 | m3xkm | 1 | 0 |  | 1 | 1.2313 | 0 |
| C3920 |  | Colocación de roca seleccionada, en uña antisocavante | 7d | 2025-10-10 | 2025-10-16 | C3780 SS, C3960 | 70d | 0d | 1 | 170 | 1925.61 | m3 | 2 | 340 | 5.66355882352941 | 2 | 1.2313 | 6.97353997941176 |
| C3910 |  | Colocación de roca seleccionada, en cara húmeda de talud | 10d | 2025-10-17 | 2025-10-26 | C3920 | 70d | 7d | 1 | 160 | 2480.89 | m3 | 2 | 320 | 7.75278125 | 2 | 1.2313 | 9.545999553125 |
|  | 3 | **REMOCION DE ENROCADO DE DIQUES EN MAL ESTADO** |  | 2025-10-03 | 2025-10-09 |  |  |  |  |  |  |  |  |  |  |  |  |  |
| C3930 |  | Remoción de enrocado de cara húmeda de talud | 5d | 2025-10-03 | 2025-10-07 | C3770 | 70d | 0d | 1 | 300 | 1040 | m3 | 1 | 300 | 3.46666666666667 | 1 | 1.2313 | 4.26850666666667 |
| C3940 |  | Selección y acopio de roca removida | 2d | 2025-10-08 | 2025-10-09 | C3930 | 70d | 0d | 1 | 500 | 739.4 | m3 | 1 | 500 | 1.4788 | 1 | 1.2313 | 1.82084644 |
| C3950 |  | Transporte de roca rechazada a DME, d=1km | 2d | 2025-10-08 | 2025-10-09 | C3940 SS | 70d | 0d | 1 |  | 248.27 | m3xkm | 1 | 0 |  | 1 | 1.2313 | 0 |
| C3960 |  | Transporte de roca rechazada a DME, d>1km | 2d | 2025-10-08 | 2025-10-09 | C3950 SS | 70d | 0d | 1 |  | 1852.92 | m3xkm | 1 | 0 |  | 1 | 1.2313 | 0 |
|  | 3 | **DIPRO-006-MD** |  | 2025-10-15 | 2025-12-08 |  |  |  |  |  |  |  |  |  |  |  |  |  |
|  | 1 | **MOVIMIENTO DE TIERRAS PARA DIQUE LONGITUDINALES** |  | 2025-10-15 | 2025-12-08 |  |  |  |  |  |  |  |  |  |  |  |  |  |
|  | 1 | **EXCAVACIÓN** |  | 2025-10-15 | 2025-12-08 |  |  |  |  |  |  |  |  |  |  |  |  |  |
| C3970 |  | Desbroce y remoción de suelo vegetal con equipo | 1d | 2025-10-15 | 2025-10-15 | C3780 | 1d | 0d | 1 | 10000 | 3177.01 | m2 | 1 | 10000 | 0.317701 | 1 | 1.2313 | 0.3911852413 |
| C3980 |  | Transporte de material excedente a DMO, d=1km | 1d | 2025-10-15 | 2025-10-15 | C3970 SS | 1d | 0d | 1 |  | 856.99 | m3xkm | 1 | 0 |  | 1 | 1.2313 | 0 |
| C3990 |  | Transporte de material excedente a DMO, d>1km | 1d | 2025-10-15 | 2025-10-15 | C3980 SS | 1d | 0d | 1 |  | 10858.62 | m3xkm | 1 | 0 |  | 1 | 1.2313 | 0 |
| C4000 |  | Excavación en material común | 8d | 2025-10-16 | 2025-10-23 | C3970, C3990 | 1d | 0d | 1 | 724 | 9040.6 | m3 | 2 | 1448 | 6.24350828729282 | 2 | 1.2313 | 7.68763175414365 |
| C4030 |  | Transporte de material excedente a DME, d=1km | 28d | 2025-10-16 | 2025-11-12 | C4000 SS | 59d | 0d | 1 |  | 6345.93 | m3xkm | 1 | 0 |  | 1 | 1.2313 | 0 |
| C4040 |  | Transporte de material excedente a DME, d>1km | 28d | 2025-10-16 | 2025-11-12 | C4030 SS | 59d | 26d | 1 |  | 47568.11 | m3xkm | 1 | 0 |  | 1 | 1.2313 | 0 |
| C4010 |  | Excavación para conformación de uña antisocavante | 20d | 2025-10-24 | 2025-11-12 | C4000 | 33d | 0d | 1 | 450 | 5488.62 | m3 | 1 | 450 | 12.1969333333333 | 1 | 1.2313 | 15.0180840133333 |
| C4020 |  | Colocación de protección para geotextil | 45d | 2025-10-25 | 2025-12-08 | C4090 SS | 33d | 0d | 1 | 830 | 5058.35 | m2 | 1 | 830 | 6.09439759036145 | 1 | 1.2313 | 7.50403175301205 |

| ID | WBS | Activity | Type | Duration | Start | Finish | Predecessors | Total float | Free float | Cuadrilla | Rendimiento | Metrado | Unidad | Turno | RCuad | Dur. Cal. | Cuadrilla día | FactorR | FDur |
| --- | --- | --- | --- | --- | --- | --- | --- | --- | --- | --- | --- | --- | --- | --- | --- | --- | --- | --- | --- |
|  | 2 | **RELLENO** |  |  | 2025-10-17 | 2025-12-08 |  |  |  |  |  |  |  |  |  |  |  |  |  |
| C4100 |  | Proceso y selección de material propio |  | 8d | 2025-10-17 | 2025-10-24 | C4000 SS+1d | 33d | 0d | 1 | 900 | 2991.35 | m3 | 1 | 900 | 3.32372222222222 | 1 | 1.2313 | 4.09249917222222 |
| C4050 |  | Conformación y compactación de superficie para fundación con equipo pesado |  | 6d | 2025-10-19 | 2025-10-24 | C4000 FF+1d | 49d | 0d | 1 | 2800 | 9430.26 | m2 | 1 | 2800 | 3.36795 | 1 | 1.2313 | 4.146956835 |
| C4060 |  | Relleno compactado con equipo pesado |  | 5d | 2025-10-21 | 2025-10-25 | C4050 SS+2d | 49d | 0d | 1 | 532.6 | 1938.78 | m3 | 1 | 532.6 | 3.64021779947428 | 1 | 1.2313 | 4.48220017649268 |
| C4110 |  | Transporte de material propio para relleno, d=1km |  | 5d | 2025-10-21 | 2025-10-25 | C4060 SS | 49d | 5d | 1 |  | 1136.71 | m3xkm | 1 | 0 |  | 1 | 1.2313 | 0 |
| C4080 |  | Perfilado de taludes de dique con equipo |  | 6d | 2025-10-22 | 2025-10-27 | C4060 SS+1d | 50d | 17d | 1 | 900 | 8107.85 | m2 | 2 | 1800 | 4.50436111111111 | 2 | 1.2313 | 5.54621983611111 |
| C4090 |  | Suministro, habilitación y colocación de geotextil no tejido 400 g/m2 |  | 45d | 2025-10-25 | 2025-12-08 | C4150 SS | 33d | 0d | 1 | 1500 | 5538.35 | m2 | 1 | 1500 | 3.69223333333333 | 1 | 1.2313 | 4.54624690333333 |
| C4070 |  | Relleno propio sin compactar |  | 2d | 2025-11-14 | 2025-11-15 | C4150 | 56d | 23d | 1 | 1100 | 1052.57 | m3 | 1 | 1100 | 0.956881818181818 | 1 | 1.2313 | 1.17820858272727 |
|  | 2 | **ENROCADO DE PROTECCIÓN** |  |  | 2025-10-25 | 2025-12-08 |  |  |  |  |  |  |  |  |  |  |  |  |  |
| C4120 |  | Transporte de roca seleccionada de cantera para enrocado de protección, d=1km |  | 45d | 2025-10-25 | 2025-12-08 | C4150 SS | 33d | 0d | 1 |  | 9427.11 | m3xkm | 1 | 0 |  | 1 | 1.2313 | 0 |
| C4130 |  | Transporte de roca seleccionada de cantera para enrocado de protección, d>1km |  | 45d | 2025-10-25 | 2025-12-08 | C4120 SS | 33d | 0d | 1 |  | 146400.02 | m3xkm | 1 | 0 |  | 1 | 1.2313 | 0 |
| C4150 |  | Colocación de roca seleccionada, en uña antisocavante |  | 20d | 2025-10-25 | 2025-11-13 | C4010 SS+1d, C4100 | 33d | 0d | 1 | 170 | 5488.62 | m3 | 2 | 340 | 16.143 | 2 | 1.2313 | 19.8768759 |
| C4140 |  | Colocación de roca seleccionada, en cara húmeda de talud |  | 25d | 2025-11-14 | 2025-12-08 | C4150, C4080, C4190 | 33d | 0d | 1 | 160 | 6271.73 | m3 | 2 | 320 | 19.59915625 | 2 | 1.2313 | 24.132441090625 |
|  | 3 | **REMOCION DE ENROCADO DE DIQUES EN MAL ESTADO** |  |  | 2025-10-24 | 2025-11-02 |  |  |  |  |  |  |  |  |  |  |  |  |  |
| C4160 |  | Remoción de enrocado de cara húmeda de talud |  | 7d | 2025-10-24 | 2025-10-30 | C4000 | 44d | 0d | 1 | 300 | 1536 | m3 | 1 | 300 | 5.12 | 1 | 1.2313 | 6.304256 |
| C4170 |  | Selección y acopio de roca removida |  | 3d | 2025-10-31 | 2025-11-02 | C4160, C4110 | 44d | 0d | 1 | 500 | 1075.2 | m3 | 1 | 500 | 2.1504 | 1 | 1.2313 | 2.64778752 |
| C4180 |  | Transporte de roca rechazada a DME, d=1km |  | 3d | 2025-10-31 | 2025-11-02 | C4170 SS | 44d | 0d | 1 |  | 364.33 | m3xkm | 1 | 0 |  | 1 | 1.2313 | 0 |
| C4190 |  | Transporte de roca rechazada a DME, d>1km |  | 3d | 2025-10-31 | 2025-11-02 | C4180 SS | 44d | 11d | 1 |  | 2719.08 | m3xkm | 1 | 0 |  | 1 | 1.2313 | 0 |
|  | 4 | **ENCAUZAMIENTO DE RÍO - SECTOR 3 (PK 15+800 al 25+351)** |  |  | 2025-04-05 | 2026-01-13 |  |  |  |  |  |  |  |  |  |  |  |  |  |
| A4770 |  | Inicio - Sector 3 | milestone | 0d | 2025-04-05 | 2025-04-05 | A4710 SS+25d | -3d | 0d |  |  |  |  |  | 0 |  | 0 |  | 0 |
| A4780 |  | Fin - Sector 3 | milestone | 0d | 2026-01-13 | 2026-01-13 | C5550 FF, C4330 FF, C4220 FF, C4270 FF, C4350 FF, C4360 FF, C4420 FF, C4470 FF, C4730 FF, C4780 FF, C4980 FF, C5350 FF, C5370 FF, C5380 FF, C5540 FF, A6000 FF, A6030 FF, A6070 FF | -3d | 0d |  |  |  |  |  | 0 |  | 0 |  | 0 |
|  | 1 | **DIPRO-002-MI** |  |  | 2025-04-05 | 2025-12-28 |  |  |  |  |  |  |  |  |  |  |  |  |  |
|  | 1 | **MOVIMIENTO DE TIERRAS PARA DIQUE LONGITUDINALES** |  |  | 2025-04-05 | 2025-12-28 |  |  |  |  |  |  |  |  |  |  |  |  |  |
|  | 1 | **EXCAVACIÓN** |  |  | 2025-04-05 | 2025-11-02 |  |  |  |  |  |  |  |  |  |  |  |  |  |
| C4200 |  | Excavación en material común |  | 111d | 2025-04-05 | 2025-07-24 | A4770 SS | 13d | 0d | 2 | 724 | 259062.77 | m3 | 2 | 2896 | 89.4553763812155 | 4 | 1.2313 | 110.146404938191 |
| C4230 |  | Transporte de material excedente a DME, d=1km |  | 188d | 2025-04-05 | 2025-10-09 | C4200 SS | 63d | 0d | 1 |  | 101417.65 | m3xkm | 1 | 0 |  | 1 | 1.2313 | 0 |
| C4240 |  | Transporte de material excedente a DME, d>1km |  | 188d | 2025-04-05 | 2025-10-09 | C4230 SS | 63d | 1d | 1 |  | 524938.23 | m3xkm | 1 | 0 |  | 1 | 1.2313 | 0 |
| C4210 |  | Excavación para conformación de uña antisocavante |  | 77d | 2025-07-25 | 2025-10-09 | C4200 | 13d | 0d | 1 | 450 | 42267.41 | m3 | 2 | 900 | 46.9637888888889 | 2 | 1.2313 | 57.8265132588889 |
| C4220 |  | Excavación de zanja de anclaje para geotextil |  | 100d | 2025-07-26 | 2025-11-02 | C4290 SS | 69d | 72d | 1 | 25 | 490.88 | m3 | 1 | 25 | 19.6352 | 1 | 1.2313 | 24.17682176 |

| ID | WBS | Activity | Duration | Start | Finish | Predecessors | Total float | Free float | Cuadrilla | Rendimiento | Metrado | Unidad | Turno | RCuad | Dur. Cal. | Cuadrilla día | FactorR | FDur |
| --- | --- | --- | --- | --- | --- | --- | --- | --- | --- | --- | --- | --- | --- | --- | --- | --- | --- | --- |
|  | 2 | **RELLENO** |  | 2025-04-06 | 2025-12-28 |  |  |  |  |  |  |  |  |  |  |  |  |  |
| C4300 |  | Proceso y selección de material propio | 133d | 2025-04-06 | 2025-08-16 | C4200 SS+1d | 90d | 19d | 1 | 900 | 194275.39 | m3 | 2 | 1800 | 107.930772222222 | 2 | 1.2313 | 132.895159837222 |
| C4250 |  | Conformación y compactación de superficie para fundación con equipo pesado | 82d | 2025-05-29 | 2025-08-18 | C4200 FF+25d | 71d | 0d | 1 | 2800 | 188346.23 | m2 | 1 | 2800 | 67.2665107142857 | 1 | 1.2313 | 82.8252546425 |
| C4260 |  | Relleno compactado con equipo pesado | 82d | 2025-05-31 | 2025-08-20 | C4250 SS+2d | 71d | 0d | 2 | 532.6 | 141273.61 | m3 | 2 | 2130.4 | 66.3131853173113 | 4 | 1.2313 | 81.6514250812054 |
| C4310 |  | Transporte de material propio para relleno, d=1km | 82d | 2025-05-31 | 2025-08-20 | C4260 SS, C4560, C4700 | 86d | 0d | 1 |  | 75240.45 | m3xkm | 1 | 0 |  | 1 | 1.2313 | 0 |
| C4320 |  | Transporte de material propio para relleno, d>1km | 82d | 2025-05-31 | 2025-08-20 | C4310 SS | 86d | 15d | 1 |  | 719.59 | m3xkm | 1 | 0 |  | 1 | 1.2313 | 0 |
| C4280 |  | Perfilado de taludes de dique con equipo | 48d | 2025-07-19 | 2025-09-04 | C4260 FF+15d | 71d | 0d | 1 | 900 | 69814.35 | m2 | 2 | 1800 | 38.78575 | 2 | 1.2313 | 47.756893975 |
| C4290 |  | Suministro, habilitación y colocación de geotextil no tejido 400 g/m2 | 155d | 2025-07-26 | 2025-12-27 | C4370 SS | 13d | 0d | 1 | 1500 | 24039.99 | m2 | 1 | 1500 | 16.02666 | 1 | 1.2313 | 19.733626458 |
| C4330 |  | Colocación de protección para geotextil | 154d | 2025-07-28 | 2025-12-28 | C4290 SS+2d | 13d | 16d | 1 | 830 | 21708.25 | m2 | 1 | 830 | 26.1545180722892 | 1 | 1.2313 | 32.2040581024097 |
| C4270 |  | Relleno propio sin compactar | 30d | 2025-10-11 | 2025-11-09 | C4370, C4210, C4240 | 62d | 65d | 1 | 1100 | 52890.77 | m3 | 2 | 2200 | 24.0412590909091 | 2 | 1.2313 | 29.6020023186364 |
|  | 2 | **ENROCADO DE PROTECCIÓN** |  | 2025-07-26 | 2025-12-27 |  |  |  |  |  |  |  |  |  |  |  |  |  |
| C4340 |  | Transporte de roca seleccionada de cantera para enrocado de protección, d=1km | 155d | 2025-07-26 | 2025-12-27 | C4370 SS | 14d | 0d | 1 |  | 38243.6 | m3xkm | 1 | 0 |  | 1 | 1.2313 | 0 |
| C4350 |  | Transporte de roca seleccionada de cantera para enrocado de protección, d>1km | 155d | 2025-07-26 | 2025-12-27 | C4340 SS | 14d | 17d | 1 |  | 866992.69 | m3xkm | 1 | 0 |  | 1 | 1.2313 | 0 |
| C4370 |  | Colocación de roca seleccionada, en uña antisocavante | 77d | 2025-07-26 | 2025-10-10 | C4210 SS+1d | 13d | 0d | 2 | 170 | 42267.41 | m3 | 2 | 680 | 62.1579558823529 | 4 | 1.2313 | 76.5350910779411 |
| C4360 |  | Colocación de roca seleccionada, en cara húmeda de talud | 78d | 2025-10-11 | 2025-12-27 | C4370 | 14d | 17d | 1 | 160 | 20199.77 | m3 | 2 | 320 | 63.12428125 | 2 | 1.2313 | 77.724927503125 |
|  | 3 | **REMOCION DE ENROCADO DE DIQUES EN MAL ESTADO** |  | 2025-07-25 | 2025-10-31 |  |  |  |  |  |  |  |  |  |  |  |  |  |
| C4380 |  | Remoción de enrocado de cara húmeda de talud | 68d | 2025-07-25 | 2025-09-30 | C4200, C4520, C4550 | 71d | 0d | 1 | 300 | 32869.46 | m3 | 2 | 600 | 54.7824333333333 | 2 | 1.2313 | 67.4536101633333 |
| C4400 |  | Selección y acopio de roca removida | 31d | 2025-10-01 | 2025-10-31 | C4380 | 71d | 0d | 1 | 500 | 24652.09 | m3 | 2 | 1000 | 24.65209 | 2 | 1.2313 | 30.354118417 |
| C4410 |  | Transporte de roca rechazada a DME, d=1km | 31d | 2025-10-01 | 2025-10-31 | C4400 SS | 71d | 0d | 1 |  | 7231.28 | m3xkm | 1 | 0 |  | 1 | 1.2313 | 0 |
| C4420 |  | Transporte de roca rechazada a DME, d>1km | 31d | 2025-10-01 | 2025-10-31 | C4410 SS | 71d | 74d | 1 |  | 44837.3 | m3xkm | 1 | 0 |  | 1 | 1.2313 | 0 |
|  | 4 | **SISTEMA DE CONFINAMIENTO CON GEOCELDAS** |  | 2025-09-05 | 2025-10-31 |  |  |  |  |  |  |  |  |  |  |  |  |  |
| C4430 |  | Suministro, habilitación y colocación de geotextil no tejido 200 g/m2 | 47d | 2025-09-05 | 2025-10-21 | C4280, C4550, C4610, C4630, C4640, C4320, C4300 | 71d | 0d | 1 | 750 | 28533.39 | m2 | 1 | 750 | 38.04452 | 1 | 1.2313 | 46.844217476 |
| C4440 |  | Suministro, habilitación y colocación de sistema de confinamiento geocelda h=100 mm | 47d | 2025-09-12 | 2025-10-28 | C4430 SS+7d | 71d | 0d | 2 | 337.5 | 25583.62 | m2 | 1 | 675 | 37.9016592592593 | 2 | 1.2313 | 46.668313045926 |
| C4450 |  | Suministro y colocación de concreto premezclado f'c=210 kg/cm2 para geocelda | 47d | 2025-09-15 | 2025-10-31 | C4440 SS+3d | 71d | 0d | 1 | 40 | 2548.77 | m3 | 1 | 40 | 63.71925 | 1 | 1.2313 | 78.457512525 |
| C4460 |  | Transporte de concreto premezclado con camión mixer, d=1km | 47d | 2025-09-15 | 2025-10-31 | C4450 SS | 71d | 0d | 1 |  | 2242.92 | m3xkm | 1 | 0 |  | 1 | 1.2313 | 0 |
| C4470 |  | Transporte de concreto premezclado con camión mixer, d>1km | 47d | 2025-09-15 | 2025-10-31 | C4460 SS | 71d | 74d | 1 |  | 91373.6 | m3xkm | 1 | 0 |  | 1 | 1.2313 | 0 |

| ID | WBS | Activity | Duration | Start | Finish | Predecessors | Total float | Free float | Cuadrilla | Rendimiento | Metrado | Unidad | Turno | RCuad | Dur. Cal. | Cuadrilla día | FactorR | FDur |
| --- | --- | --- | --- | --- | --- | --- | --- | --- | --- | --- | --- | --- | --- | --- | --- | --- | --- | --- |
|  | 2 | **DIPRO-003-MI** |  | 2025-04-05 | 2025-08-02 |  |  |  |  |  |  |  |  |  |  |  |  |  |
|  | 1 | **MOVIMIENTO DE TIERRAS PARA DIQUE LONGITUDINALES** |  | 2025-04-05 | 2025-08-02 |  |  |  |  |  |  |  |  |  |  |  |  |  |
|  | 1 | **EXCAVACIÓN** |  | 2025-04-05 | 2025-06-29 |  |  |  |  |  |  |  |  |  |  |  |  |  |
| C4480 |  | Excavación en material común | 30d | 2025-04-05 | 2025-05-04 | A4770 SS | -3d | 0d | 1 | 724 | 34601.27 | m3 | 2 | 1448 | 23.8959046961326 | 2 | 1.2313 | 29.4230274523481 |
| C4510 |  | Transporte de material excedente a DME, d=1km | 86d | 2025-04-05 | 2025-06-29 | C4480 SS | 96d | 0d | 1 |  | 16762.48 | m3xkm | 1 | 0 |  | 1 | 1.2313 | 0 |
| C4520 |  | Transporte de material excedente a DME, d>1km | 86d | 2025-04-05 | 2025-06-29 | C4510 SS | 96d | 25d | 1 |  | 86762.65 | m3xkm | 1 | 0 |  | 1 | 1.2313 | 0 |
| C4490 |  | Excavación para conformación de uña antisocavante | 56d | 2025-05-05 | 2025-06-29 | C4480 | 6d | 0d | 1 | 450 | 15284.21 | m3 | 2 | 900 | 16.9824555555556 | 2 | 1.2313 | 20.9104975255556 |
|  | 2 | **RELLENO** |  | 2025-04-06 | 2025-08-02 |  |  |  |  |  |  |  |  |  |  |  |  |  |
| C4580 |  | Proceso y selección de material propio | 30d | 2025-04-06 | 2025-05-05 | C4480 SS+1d | 104d | 0d | 1 | 900 | 32307.76 | m3 | 2 | 1800 | 17.9487555555556 | 2 | 1.2313 | 22.1003027155556 |
| C4530 |  | Conformación y compactación de superficie para fundación con equipo pesado | 20d | 2025-04-17 | 2025-05-06 | C4480 FF+2d | 95d | 0d | 1 | 2800 | 31130.17 | m2 | 1 | 2800 | 11.1179178571429 | 1 | 1.2313 | 13.6894922575001 |
| C4540 |  | Relleno compactado con equipo pesado | 28d | 2025-04-22 | 2025-05-19 | C4530 SS+5d | 95d | 0d | 1 | 532.6 | 23844.24 | m3 | 2 | 1065.2 | 22.3847540368006 | 2 | 1.2313 | 27.5623476455126 |
| C4590 |  | Transporte de material propio para relleno, d=1km | 28d | 2025-04-22 | 2025-05-19 | C4540 SS | 127d | 0d | 1 |  | 12512.39 | m3xkm | 1 | 0 |  | 1 | 1.2313 | 0 |
| C4600 |  | Transporte de material propio para relleno, d>1km | 28d | 2025-04-22 | 2025-05-19 | C4590 SS | 127d | 42d | 1 |  | 119.67 | m3xkm | 1 | 0 |  | 1 | 1.2313 | 0 |
| C4560 |  | Perfilado de taludes de dique con equipo | 25d | 2025-04-27 | 2025-05-21 | C4540 FF+2d | 95d | 9d | 1 | 900 | 17827.25 | m2 | 1 | 900 | 19.8080555555556 | 1 | 1.2313 | 24.3896588055556 |
| C4570 |  | Suministro, habilitación y colocación de geotextil no tejido 400 g/m2 | 89d | 2025-05-06 | 2025-08-02 | C4650 SS | 104d | 0d | 1 | 1500 | 11104.55 | m2 | 1 | 1500 | 7.40303333333333 | 1 | 1.2313 | 9.11535494333333 |
| C4610 |  | Colocación de protección para geotextil | 89d | 2025-05-06 | 2025-08-02 | C4570 SS | 104d | 33d | 1 | 830 | 9928.55 | m2 | 1 | 830 | 11.9621084337349 | 1 | 1.2313 | 14.7289441144578 |
| C4550 |  | Relleno propio sin compactar | 10d | 2025-07-01 | 2025-07-10 | C4650, C4600 | 85d | 14d | 1 | 1100 | 8392.15 | m3 | 1 | 1100 | 7.62922727272727 | 1 | 1.2313 | 9.39386754090909 |
|  | 2 | **ENROCADO DE PROTECCIÓN** |  | 2025-05-06 | 2025-08-02 |  |  |  |  |  |  |  |  |  |  |  |  |  |
| C4620 |  | Transporte de roca seleccionada de cantera para enrocado de protección, d=1km | 89d | 2025-05-06 | 2025-08-02 | C4650 SS, C4580 | 104d | 0d | 1 |  | 14523.24 | m3xkm | 1 | 0 |  | 1 | 1.2313 | 0 |
| C4630 |  | Transporte de roca seleccionada de cantera para enrocado de protección, d>1km | 89d | 2025-05-06 | 2025-08-02 | C4620 SS | 104d | 33d | 1 |  | 329245.73 | m3xkm | 1 | 0 |  | 1 | 1.2313 | 0 |
| C4650 |  | Colocación de roca seleccionada, en uña antisocavante | 56d | 2025-05-06 | 2025-06-30 | C4490 SS+1d | 6d | 0d | 1 | 170 | 15284.21 | m3 | 2 | 340 | 44.9535588235294 | 2 | 1.2313 | 55.3513169794118 |
| C4640 |  | Colocación de roca seleccionada, en cara húmeda de talud | 33d | 2025-07-01 | 2025-08-02 | C4650 | 104d | 33d | 1 | 160 | 8438.08 | m3 | 2 | 320 | 26.369 | 2 | 1.2313 | 32.4681497 |
|  | 3 | **REMOCION DE ENROCADO DE DIQUES EN MAL ESTADO** |  | 2025-05-05 | 2025-05-23 |  |  |  |  |  |  |  |  |  |  |  |  |  |
| C4660 |  | Remoción de enrocado de cara húmeda de talud | 13d | 2025-05-05 | 2025-05-17 | C4480 | 94d | 0d | 1 | 300 | 3179.95 | m3 | 1 | 300 | 10.5998333333333 | 1 | 1.2313 | 13.0515747833333 |
| C4680 |  | Selección y acopio de roca removida | 6d | 2025-05-18 | 2025-05-23 | C4660 | 94d | 0d | 1 | 500 | 2384.96 | m3 | 1 | 500 | 4.76992 | 1 | 1.2313 | 5.873202496 |
| C4690 |  | Transporte de roca rechazada a DME, d=1km | 5d | 2025-05-18 | 2025-05-22 | C4680 SS | 94d | 0d | 1 |  | 699.59 | m3xkm | 1 | 0 |  | 1 | 1.2313 | 0 |
| C4700 |  | Transporte de roca rechazada a DME, d>1km | 5d | 2025-05-18 | 2025-05-22 | C4690 SS | 94d | 8d | 1 |  | 4337.77 | m3xkm | 1 | 0 |  | 1 | 1.2313 | 0 |

| ID | WBS | Activity | Duration | Start | Finish | Predecessors | Total float | Free float | Cuadrilla | Rendimiento | Metrado | Unidad | Turno | RCuad | Dur. Cal. | Cuadrilla día | FactorR | FDur |
| --- | --- | --- | --- | --- | --- | --- | --- | --- | --- | --- | --- | --- | --- | --- | --- | --- | --- | --- |
|  | 3 | **DIPRO-004-MI** |  | 2025-07-01 | 2026-01-04 |  |  |  |  |  |  |  |  |  |  |  |  |  |
|  | 1 | **MOVIMIENTO DE TIERRAS PARA DIQUE LONGITUDINALES** |  | 2025-07-01 | 2025-12-18 |  |  |  |  |  |  |  |  |  |  |  |  |  |
|  | 1 | **EXCAVACIÓN** |  | 2025-07-01 | 2025-12-18 |  |  |  |  |  |  |  |  |  |  |  |  |  |
| C4710 |  | Excavación en material común | 53d | 2025-07-01 | 2025-08-22 | C4650 | 6d | 0d | 2 | 724 | 122733.11 | m3 | 2 | 2896 | 42.3802175414365 | 4 | 1.2313 | 52.1827618587708 |
| C4740 |  | Transporte de material excedente a DME, d=1km | 146d | 2025-07-01 | 2025-11-23 | C4710 SS | 31d | 0d | 1 |  | 50198.9 | m3xkm | 1 | 0 |  | 1 | 1.2313 | 0 |
| C4750 |  | Transporte de material excedente a DME, d>1km | 146d | 2025-07-01 | 2025-11-23 | C4740 SS | 31d | 1d | 1 |  | 259829.72 | m3xkm | 1 | 0 |  | 1 | 1.2313 | 0 |
| C4720 |  | Excavación para conformación de uña antisocavante | 93d | 2025-08-23 | 2025-11-23 | C4710 | 30d | 0d | 1 | 450 | 25719.7 | m3 | 2 | 900 | 28.5774444444444 | 2 | 1.2313 | 35.1874073444444 |
| C4730 |  | Excavación de zanja de anclaje para geotextil | 70d | 2025-10-10 | 2025-12-18 | C4940 SS | 23d | 26d | 1 | 25 | 940.16 | m3 | 1 | 25 | 37.6064 | 1 | 1.2313 | 46.30476032 |
|  | 2 | **RELLENO** |  | 2025-07-01 | 2025-12-11 |  |  |  |  |  |  |  |  |  |  |  |  |  |
| C4810 |  | Proceso y selección de material propio | 53d | 2025-07-01 | 2025-08-22 | C4710 SS, C5070 | 30d | 0d | 1 | 900 | 144383.73 | m3 | 1 | 900 | 160.426366666667 | 1 | 1.2313 | 197.532985276667 |
| C4760 |  | Conformación y compactación de superficie para fundación con equipo pesado | 41d | 2025-07-14 | 2025-08-23 | C4710 FF+1d | 6d | 0d | 1 | 2800 | 93226.1 | m2 | 1 | 2800 | 33.2950357142857 | 1 | 1.2313 | 40.996177475 |
| C4770 |  | Relleno compactado con equipo pesado | 67d | 2025-07-19 | 2025-09-23 | C4760 SS+5d | 6d | 0d | 2 | 532.6 | 115277.03 | m3 | 2 | 2130.4 | 54.1105097634247 | 4 | 1.2313 | 66.6262706717048 |
| C4820 |  | Transporte de material propio para relleno, d=1km | 67d | 2025-07-19 | 2025-09-23 | C4770 SS | 63d | 0d | 1 |  | 55918.03 | m3xkm | 1 | 0 |  | 1 | 1.2313 | 0 |
| C4830 |  | Transporte de material propio para relleno, d>1km | 67d | 2025-07-19 | 2025-09-23 | C4820 SS | 63d | 0d | 1 |  | 534.79 | m3xkm | 1 | 0 |  | 1 | 1.2313 | 0 |
| C4790 |  | Perfilado de taludes de dique con equipo | 76d | 2025-07-26 | 2025-10-09 | C4770 SS+7d | 6d | 0d | 1 | 900 | 110346 | m2 | 2 | 1800 | 61.3033333333333 | 2 | 1.2313 | 75.4827943333333 |
| C4780 |  | Relleno propio sin compactar | 17d | 2025-11-25 | 2025-12-11 | C4880, C4750, C4930, C4860, C5290 | 30d | 33d | 1 | 1100 | 28787.77 | m3 | 2 | 2200 | 13.08535 | 2 | 1.2313 | 16.111991455 |
|  | 2 | **ENROCADO DE PROTECCIÓN** |  | 2025-08-23 | 2025-11-24 |  |  |  |  |  |  |  |  |  |  |  |  |  |
| C4850 |  | Transporte de roca seleccionada de cantera para enrocado de protección, d=1km | 94d | 2025-08-23 | 2025-11-24 | C4880 SS, C4810, C5010, C5030 | 30d | 0d | 1 |  | 15746.09 | m3xkm | 1 | 0 |  | 1 | 1.2313 | 0 |
| C4860 |  | Transporte de roca seleccionada de cantera para enrocado de protección, d>1km | 94d | 2025-08-23 | 2025-11-24 | C4850 SS, C5340 | 30d | 0d | 1 |  | 356968.12 | m3xkm | 1 | 0 |  | 1 | 1.2313 | 0 |
| C4880 |  | Colocación de roca seleccionada, en uña antisocavante | 94d | 2025-08-23 | 2025-11-24 | C4720 SS, C5060, C5320 | 30d | 0d | 1 | 170 | 25719.7 | m3 | 2 | 340 | 75.6461764705882 | 2 | 1.2313 | 93.1431370882353 |
|  | 3 | **REMOCION DE ENROCADO DE DIQUES EN MAL ESTADO** |  | 2025-08-23 | 2025-10-22 |  |  |  |  |  |  |  |  |  |  |  |  |  |
| C4890 |  | Remoción de enrocado de cara húmeda de talud | 32d | 2025-08-23 | 2025-09-23 | C4710 | 63d | 0d | 1 | 300 | 15336 | m3 | 2 | 600 | 25.56 | 2 | 1.2313 | 31.472028 |
| C4910 |  | Selección y acopio de roca removida | 29d | 2025-09-24 | 2025-10-22 | C4890, C4830, C5080, C5120 | 63d | 0d | 1 | 500 | 11502 | m3 | 1 | 500 | 23.004 | 1 | 1.2313 | 28.3248252 |
| C4920 |  | Transporte de roca rechazada a DME, d=1km | 29d | 2025-09-24 | 2025-10-22 | C4910 SS, C5140 | 63d | 0d | 1 |  | 3373.92 | m3xkm | 1 | 0 |  | 1 | 1.2313 | 0 |
| C4930 |  | Transporte de roca rechazada a DME, d>1km | 29d | 2025-09-24 | 2025-10-22 | C4920 SS, C5150 | 63d | 33d | 1 |  | 20919.87 | m3xkm | 1 | 0 |  | 1 | 1.2313 | 0 |

| ID | WBS | Activity | Duration | Start | Finish | Predecessors | Total float | Free float | Cuadrilla | Rendimiento | Metrado | Unidad | Turno | RCuad | Dur. Cal. | Cuadrilla día | FactorR | FDur |
| --- | --- | --- | --- | --- | --- | --- | --- | --- | --- | --- | --- | --- | --- | --- | --- | --- | --- | --- |
|  | 4 | **SISTEMA DE CONFINAMIENTO CON GEOCELDAS** |  | 2025-10-10 | 2026-01-04 |  |  |  |  |  |  |  |  |  |  |  |  |  |
| C4940 |  | Suministro, habilitación y colocación de geotextil no tejido 200 g/m2 | 84d | 2025-10-10 | 2026-01-01 | C4790 | 6d | 0d | 2 | 750 | 102186.8 | m2 | 1 | 1500 | 68.1245333333333 | 2 | 1.2313 | 83.8817378933333 |
| C4950 |  | Suministro, habilitación y colocación de sistema de confinamiento geocelda h=100 mm | 83d | 2025-10-12 | 2026-01-02 | C4940 SS+2d | 6d | 0d | 2 | 337.5 | 45446.2 | m2 | 1 | 675 | 67.3277037037037 | 2 | 1.2313 | 82.9006015703704 |
| C4960 |  | Suministro y colocación de concreto premezclado f'c=210 kg/cm2 para geocelda | 80d | 2025-10-17 | 2026-01-04 | C4950 SS+5d | 6d | 0d | 2 | 40 | 4548.88 | m3 | 1 | 80 | 56.861 | 2 | 1.2313 | 70.0129493 |
| C4970 |  | Transporte de concreto premezclado con camión mixer, d=1km | 80d | 2025-10-17 | 2026-01-04 | C4960 SS | 6d | 0d | 1 |  | 4003.01 | m3xkm | 1 | 0 |  | 1 | 1.2313 | 0 |
| C4980 |  | Transporte de concreto premezclado con camión mixer, d>1km | 80d | 2025-10-17 | 2026-01-04 | C4970 SS | 6d | 9d | 1 |  | 163077.71 | m3xkm | 1 | 0 |  | 1 | 1.2313 | 0 |
|  | 4 | **DIPRO-004-MD** |  | 2025-05-05 | 2025-08-31 |  |  |  |  |  |  |  |  |  |  |  |  |  |
|  | 1 | **MOVIMIENTO DE TIERRAS PARA DIQUE LONGITUDINALES** |  | 2025-05-05 | 2025-08-31 |  |  |  |  |  |  |  |  |  |  |  |  |  |
|  | 1 | **EXCAVACIÓN** |  | 2025-05-05 | 2025-08-22 |  |  |  |  |  |  |  |  |  |  |  |  |  |
| C4990 |  | Excavación en material común | 34d | 2025-05-05 | 2025-06-07 | C4480 | -3d | 0d | 1 | 724 | 39085.55 | m3 | 2 | 1448 | 26.9927831491713 | 2 | 1.2313 | 33.2362138915746 |
| C5020 |  | Transporte de material excedente a DME, d=1km | 94d | 2025-05-05 | 2025-08-06 | C4990 SS | 46d | 0d | 1 |  | 18646.67 | m3xkm | 1 | 0 |  | 1 | 1.2313 | 0 |
| C5030 |  | Transporte de material excedente a DME, d>1km | 94d | 2025-05-05 | 2025-08-06 | C5020 SS | 46d | 16d | 1 |  | 96515.26 | m3xkm | 1 | 0 |  | 1 | 1.2313 | 0 |
| C5000 |  | Excavación para conformación de uña antisocavante | 60d | 2025-06-08 | 2025-08-06 | C4990 | 30d | 0d | 1 | 450 | 16407.34 | m3 | 1 | 450 | 36.4607555555556 | 1 | 1.2313 | 44.8941283155556 |
| C5010 |  | Excavación de zanja de anclaje para geotextil | 75d | 2025-06-09 | 2025-08-22 | C5080 SS | 30d | 0d | 1 | 25 | 0 | m3 | 1 | 25 | 0 | 1 | 1.2313 | 0 |
|  | 2 | **RELLENO** |  | 2025-05-05 | 2025-08-31 |  |  |  |  |  |  |  |  |  |  |  |  |  |
| C5090 |  | Proceso y selección de material propio | 34d | 2025-05-05 | 2025-06-07 | C4990 SS | 31d | 1d | 1 | 900 | 26327.31 | m3 | 1 | 900 | 29.2525666666667 | 1 | 1.2313 | 36.0186853366667 |
| C5040 |  | Conformación y compactación de superficie para fundación con equipo pesado | 16d | 2025-05-25 | 2025-06-09 | C4990 FF+2d | 45d | 0d | 1 | 2800 | 34629.38 | m2 | 1 | 2800 | 12.3676357142857 | 1 | 1.2313 | 15.228269855 |
| C5050 |  | Relleno compactado con equipo pesado | 20d | 2025-05-26 | 2025-06-14 | C5040 SS+1d | 45d | 0d | 1 | 532.6 | 16569.23 | m3 | 2 | 1065.2 | 15.5550413067968 | 2 | 1.2313 | 19.1529223610589 |
| C5100 |  | Transporte de material propio para relleno, d=1km | 20d | 2025-05-26 | 2025-06-14 | C5050 SS | 51d | 0d | 1 |  | 10196.24 | m3xkm | 1 | 0 |  | 1 | 1.2313 | 0 |
| C5110 |  | Transporte de material propio para relleno, d>1km | 20d | 2025-05-26 | 2025-06-14 | C5100 SS | 51d | 0d | 1 |  | 97.52 | m3xkm | 1 | 0 |  | 1 | 1.2313 | 0 |
| C5070 |  | Perfilado de taludes de dique con equipo | 10d | 2025-06-06 | 2025-06-15 | C5050 FF+1d | 45d | 15d | 1 | 900 | 14411.13 | m2 | 2 | 1800 | 8.00618333333333 | 2 | 1.2313 | 9.85801353833333 |
| C5080 |  | Suministro, habilitación y colocación de geotextil no tejido 400 g/m2 | 84d | 2025-06-09 | 2025-08-31 | C5160 SS, C5090 | 30d | 0d | 1 | 1500 | 8413.11 | m2 | 1 | 1500 | 5.60874 | 1 | 1.2313 | 6.906041562 |
| C5120 |  | Colocación de protección para geotextil | 84d | 2025-06-09 | 2025-08-31 | C5080 SS | 86d | 23d | 1 | 830 | 7544.31 | m2 | 1 | 830 | 9.08953012048193 | 1 | 1.2313 | 11.1919384373494 |
| C5060 |  | Relleno propio sin compactar | 11d | 2025-08-08 | 2025-08-18 | C5160 | 34d | 4d | 1 | 1100 | 9699.92 | m3 | 1 | 1100 | 8.81810909090909 | 1 | 1.2313 | 10.8577377236364 |

| ID | WBS | Activity | Duration | Start | Finish | Predecessors | Total float | Free float | Cuadrilla | Metrado | Unidad | Turno | RCuad | Cuadrilla día | FactorR | FDur | Rendimiento | Dur. Cal. |
| --- | --- | --- | --- | --- | --- | --- | --- | --- | --- | --- | --- | --- | --- | --- | --- | --- | --- | --- |
|  | 2 | **ENROCADO DE PROTECCIÓN** |  | 2025-06-09 | 2025-08-31 |  |  |  |  |  |  |  |  |  |  |  |  |  |
| C5130 |  | Transporte de roca seleccionada de cantera para enrocado de protección, d=1km | 84d | 2025-06-09 | 2025-08-31 | C5160 SS | 86d | 0d | 1 | 13801.93 | m3xkm | 1 | 0 | 1 | 1.2313 | 0 |  |  |
| C5140 |  | Transporte de roca seleccionada de cantera para enrocado de protección, d>1km | 84d | 2025-06-09 | 2025-08-31 | C5130 SS | 86d | 23d | 1 | 312893.42 | m3xkm | 1 | 0 | 1 | 1.2313 | 0 |  |  |
| C5160 |  | Colocación de roca seleccionada, en uña antisocavante | 60d | 2025-06-09 | 2025-08-07 | C5000 SS+1d | 30d | 0d | 1 | 16407.34 | m3 | 2 | 340 | 2 | 1.2313 | 59.4186992411765 | 170 | 48.2568823529412 |
| C5150 |  | Colocación de roca seleccionada, en cara húmeda de talud | 24d | 2025-08-08 | 2025-08-31 | C5160, C5210 | 86d | 23d | 1 | 6136.76 | m3 | 2 | 320 | 2 | 1.2313 | 23.6131018375 | 160 | 19.177375 |
|  | 3 | **REMOCION DE ENROCADO DE DIQUES EN MAL ESTADO** |  | 2025-06-08 | 2025-06-25 |  |  |  |  |  |  |  |  |  |  |  |  |  |
| C5170 |  | Remoción de enrocado de cara húmeda de talud | 7d | 2025-06-08 | 2025-06-14 | C4990 | 51d | 0d | 1 | 1508.4 | m3 | 1 | 300 | 1 | 1.2313 | 6.1909764 | 300 | 5.028 |
| C5180 |  | Remoción de enrocado de uña | 6d | 2025-06-15 | 2025-06-20 | C5170, C5110 | 51d | 0d | 1 | 1818.8 | m3 | 1 | 400 | 1 | 1.2313 | 5.5987211 | 400 | 4.547 |
| C5190 |  | Selección y acopio de roca removida | 5d | 2025-06-21 | 2025-06-25 | C5180 | 51d | 0d | 1 | 1934.24 | m3 | 1 | 500 | 1 | 1.2313 | 4.763259424 | 500 | 3.86848 |
| C5200 |  | Transporte de roca rechazada a DME, d=1km | 5d | 2025-06-21 | 2025-06-25 | C5190 SS | 129d | 0d | 1 | 1225.8 | m3xkm | 1 | 0 | 1 | 1.2313 | 0 |  |  |
| C5210 |  | Transporte de roca rechazada a DME, d>1km | 5d | 2025-06-21 | 2025-06-25 | C5200 SS | 129d | 43d | 1 | 7600.56 | m3xkm | 1 | 0 | 1 | 1.2313 | 0 |  |  |
|  | 5 | **DIPRO-005-MD** |  | 2025-06-08 | 2026-01-03 |  |  |  |  |  |  |  |  |  |  |  |  |  |
|  | 1 | **MOVIMIENTO DE TIERRAS PARA DIQUE LONGITUDINALES** |  | 2025-06-08 | 2025-12-29 |  |  |  |  |  |  |  |  |  |  |  |  |  |
|  | 1 | **EXCAVACIÓN** |  | 2025-06-08 | 2025-10-23 |  |  |  |  |  |  |  |  |  |  |  |  |  |
| C5220 |  | Excavación en material común | 65d | 2025-06-08 | 2025-08-11 | C4990 | -3d | 0d | 1 | 76216.5299999999 | m3 | 2 | 1448 | 2 | 1.2313 | 64.810368362569 | 724 | 52.6357251381215 |
| C5250 |  | Transporte de material excedente a DME, d=1km | 138d | 2025-06-08 | 2025-10-23 | C5220 SS | 51d | 0d | 1 | 39138.34 | m3xkm | 1 | 0 | 1 | 1.2313 | 0 |  |  |
| C5260 |  | Transporte de material excedente a DME, d>1km | 138d | 2025-06-08 | 2025-10-23 | C5250 SS | 51d | 0d | 1 | 202580.24 | m3xkm | 1 | 0 | 1 | 1.2313 | 0 |  |  |
| C5230 |  | Excavación para conformación de uña antisocavante | 73d | 2025-08-12 | 2025-10-23 | C5220 | 7d | 0d | 1 | 40260 | m3 | 2 | 900 | 2 | 1.2313 | 55.0801533333333 | 450 | 44.7333333333333 |
|  | 2 | **RELLENO** |  | 2025-06-09 | 2025-12-29 |  |  |  |  |  |  |  |  |  |  |  |  |  |
| C5320 |  | Proceso y selección de material propio | 65d | 2025-06-09 | 2025-08-12 | C5220 SS+1d | 40d | 10d | 1 | 23917.52 | m3 | 1 | 900 | 1 | 1.2313 | 32.7218248622222 | 900 | 26.5750222222222 |
| C5270 |  | Conformación y compactación de superficie para fundación con equipo pesado | 32d | 2025-07-12 | 2025-08-12 | C5220 FF+1d | 13d | 0d | 1 | 72685.17 | m2 | 1 | 2800 | 1 | 1.2313 | 31.9633035075 | 2800 | 25.9589892857143 |
| C5280 |  | Relleno compactado con equipo pesado | 33d | 2025-07-17 | 2025-08-18 | C5270 SS+5d | 13d | 0d | 1 | 14200.47 | m3 | 1 | 532.6 | 1 | 1.2313 | 32.8295882669921 | 532.6 | 26.6625422455877 |
| C5330 |  | Transporte de material propio para relleno, d=1km | 33d | 2025-07-17 | 2025-08-18 | C5280 SS | 34d | 0d | 1 | 9262.96 | m3xkm | 1 | 0 | 1 | 1.2313 | 0 |  |  |
| C5340 |  | Transporte de material propio para relleno, d>1km | 33d | 2025-07-17 | 2025-08-18 | C5330 SS | 34d | 4d | 1 | 88.59 | m3xkm | 1 | 0 | 1 | 1.2313 | 0 |  |  |
| C5300 |  | Perfilado de taludes de dique con equipo | 44d | 2025-07-22 | 2025-09-03 | C5280 SS+5d | 13d | 16d | 1 | 64236.85 | m2 | 2 | 1800 | 2 | 1.2313 | 43.9415741138889 | 900 | 35.6871388888889 |
| C5310 |  | Suministro, habilitación y colocación de geotextil no tejido 400 g/m2 | 140d | 2025-08-12 | 2025-12-29 | C5390 SS | 12d | 0d | 1 | 42716.05 | m2 | 1 | 1500 | 1 | 1.2313 | 35.0641815766667 | 1500 | 28.4773666666667 |
| C5350 |  | Colocación de protección para geotextil | 140d | 2025-08-12 | 2025-12-29 | C5310 SS | 12d | 15d | 1 | 38324.04 | m2 | 1 | 830 | 1 | 1.2313 | 56.8534824722892 | 830 | 46.1735421686747 |
| C5290 |  | Relleno propio sin compactar | 11d | 2025-10-24 | 2025-11-03 | C5390, C5260 | 51d | 21d | 1 | 9664.22 | m3 | 1 | 1100 | 1 | 1.2313 | 10.8177764418182 | 1100 | 8.78565454545454 |

| ID | WBS | Activity | Duration | Start | Finish | Predecessors | Total float | Free float | Cuadrilla | Metrado | Unidad | Turno | RCuad | Cuadrilla día | FactorR | FDur | Rendimiento | Dur. Cal. |
| --- | --- | --- | --- | --- | --- | --- | --- | --- | --- | --- | --- | --- | --- | --- | --- | --- | --- | --- |
|  | 2 | **ENROCADO DE PROTECCIÓN** |  | 2025-08-12 | 2026-01-03 |  |  |  |  |  |  |  |  |  |  |  |  |  |
| C5360 |  | Transporte de roca seleccionada de cantera para enrocado de protección, d=1km | 145d | 2025-08-12 | 2026-01-03 | C5390 SS | 7d | 0d | 1 | 47560.95 | m3xkm | 1 | 0 | 1 | 1.2313 | 0 |  |  |
| C5370 |  | Transporte de roca seleccionada de cantera para enrocado de protección, d>1km | 145d | 2025-08-12 | 2026-01-03 | C5360 SS | 7d | 10d | 1 | 1078219.52 | m3xkm | 1 | 0 | 1 | 1.2313 | 0 |  |  |
| C5390 |  | Colocación de roca seleccionada, en uña antisocavante | 73d | 2025-08-12 | 2025-10-23 | C5230 SS | 7d | 0d | 2 | 40260 | m3 | 2 | 680 | 4 | 1.2313 | 72.9002029411765 | 170 | 59.2058823529412 |
| C5380 |  | Colocación de roca seleccionada, en cara húmeda de talud | 72d | 2025-10-24 | 2026-01-03 | C5390 | 7d | 10d | 2 | 37426.16 | m3 | 2 | 640 | 4 | 1.2313 | 72.0044231375 | 160 | 58.478375 |
|  | 3 | **REMOCION DE ENROCADO DE DIQUES EN MAL ESTADO** |  | 2025-08-12 | 2025-11-23 |  |  |  |  |  |  |  |  |  |  |  |  |  |
| C5400 |  | Remoción de enrocado de cara húmeda de talud | 39d | 2025-08-12 | 2025-09-19 | C5220 | -3d | 0d | 1 | 18812 | m3 | 2 | 600 | 2 | 1.2313 | 38.6053593333333 | 300 | 31.3533333333333 |
| C5410 |  | Remoción de enrocado de uña | 35d | 2025-09-20 | 2025-10-24 | C5400, C5300 | -3d | 0d | 1 | 22576 | m3 | 2 | 800 | 2 | 1.2313 | 34.747286 | 400 | 28.22 |
| C5420 |  | Selección y acopio de roca removida | 30d | 2025-10-25 | 2025-11-23 | C5410 | -3d | 0d | 1 | 24080 | m3 | 2 | 1000 | 2 | 1.2313 | 29.649704 | 500 | 24.08 |
| C5430 |  | Transporte de roca rechazada a DME, d=1km | 30d | 2025-10-25 | 2025-11-23 | C5420 SS | -3d | 0d | 1 | 15231.04 | m3xkm | 1 | 0 | 1 | 1.2313 | 0 |  |  |
| C5440 |  | Transporte de roca rechazada a DME, d>1km | 30d | 2025-10-25 | 2025-11-23 | C5430 SS | -3d | 0d | 1 | 94439.52 | m3xkm | 1 | 0 | 1 | 1.2313 | 0 |  |  |
|  | 6 | **ESPIGONES** |  | 2025-11-24 | 2026-01-13 |  |  |  |  |  |  |  |  |  |  |  |  |  |
| C5450 |  | Relleno compactado para estructuras | 11d | 2025-11-24 | 2025-12-04 | C5420, C5440 | -3d | 0d | 1 | 612.3 | m3 | 1 | 70 | 1 | 1.2313 | 10.770357 | 70 | 8.74714285714286 |
| C5460 |  | Colocación y acomodo de material base para espigones | 11d | 2025-11-24 | 2025-12-04 | C5450 SS | -3d | 0d | 1 | 296.01 | m3 | 1 | 0 | 1 | 1.2313 | 0 |  |  |
| C5470 |  | Suministro y colocación de colchón caja plastificada de 5.0x1.5x0.50 m (Malla 8x10 cm. Dext=3.7mm con recubrimiento de p | 40d | 2025-12-05 | 2026-01-13 | C5460 | -3d | 0d | 1 | 156 | Und | 1 | 5 | 1 | 1.2313 | 38.41656 | 5 | 31.2 |
| C5480 |  | Suministro y colocación gavión caja plastificada de 5.0x1.0x1.0 m (Malla 10x12 cm. Dext=3.7mm con recubrimiento de polím | 40d | 2025-12-05 | 2026-01-13 | C5470 SS | -3d | 0d | 1 | 30 | Und | 1 | 4 | 1 | 1.2313 | 9.23475 | 4 | 7.5 |
| C5490 |  | Suministro y colocación gavión caja plastificada de 5.0x1.0x1.0 m (doble malla 10x12 cm. Dext=3.7mm con recubrimiento de | 40d | 2025-12-05 | 2026-01-13 | C5480 SS | -3d | 0d | 1 | 54 | Und | 1 | 0 | 1 | 1.2313 | 0 |  |  |
| C5500 |  | Suministro, habilitación y colocación de geotextil no tejido 200 g/m2 | 40d | 2025-12-05 | 2026-01-13 | C5490 SS | -3d | 0d | 1 | 1875.5 | m2 | 1 | 750 | 1 | 1.2313 | 3.07907086666667 | 750 | 2.50066666666667 |
| C5510 |  | Transporte de roca para gavión, d=1km | 40d | 2025-12-05 | 2026-01-13 | C5500 SS | -3d | 0d | 1 | 884.4 | m3xkm | 1 | 0 | 1 | 1.2313 | 0 |  |  |
| C5520 |  | Transporte de roca para gavión, d>1km | 40d | 2025-12-05 | 2026-01-13 | C5510 SS | -3d | 0d | 1 | 11316.3 | m3xkm | 1 | 0 | 1 | 1.2313 | 0 |  |  |
| C5530 |  | Transporte de roca seleccionada de cantera para enrocado de protección, d=1km | 40d | 2025-12-05 | 2026-01-13 | C5520 SS, A5940 | -3d | 0d | 1 | 260.49 | m3xkm | 1 | 0 | 1 | 1.2313 | 0 |  |  |
| C5540 |  | Transporte de roca seleccionada de cantera para enrocado de protección, d>1km | 40d | 2025-12-05 | 2026-01-13 | C5530 SS | -3d | 0d | 1 | 3333.07 | m3xkm | 1 | 0 | 1 | 1.2313 | 0 |  |  |
|  | 7 | **AREAS DEGRADADAS** |  | 2025-08-12 | 2026-01-13 |  |  |  |  |  |  |  |  |  |  |  |  |  |
| C5550 |  | Carguío y transporte de residuos municipales, no municipales y residuos de la construcción y demolición | 155d | 2025-08-12 | 2026-01-13 | C5220 | -3d | 0d | 1 | 38203.54 | m3 | 1 | 0 | 1 | 1.2313 | 0 |  |  |

| ID | WBS | Activity | Duration | Start | Finish | Predecessors | Total float | Free float | Cuadrilla | Rendimiento | Metrado | Unidad | Turno | RCuad | Dur. Cal. | Cuadrilla día | FactorR | FDur |
| --- | --- | --- | --- | --- | --- | --- | --- | --- | --- | --- | --- | --- | --- | --- | --- | --- | --- | --- |
|  | 10 | **ALCANTARILLA DE RETORNO** |  | 2025-05-20 | 2025-07-05 |  |  |  |  |  |  |  |  |  |  |  |  |  |
|  | 1 | **RET-MI 26+600** |  | 2025-05-20 | 2025-06-11 |  |  |  |  |  |  |  |  |  |  |  |  |  |
|  | 1 | **MOVIMIENTO DE TIERRAS** |  | 2025-05-20 | 2025-06-11 |  |  |  |  |  |  |  |  |  |  |  |  |  |
| A4800 |  | Excavación en material común | 3d | 2025-05-20 | 2025-05-22 | C1960 | 64d | 0d | 1 | 724 | 250.96 | m3 | 1 | 724 | 0.346629834254144 | 1 | 1.2313 | 0.426805314917128 |
| A4810 |  | Relleno compactado con equipo pesado | 3d | 2025-05-20 | 2025-05-22 | A4800 SS | 64d | 0d | 1 | 532.6 | 189.9578 | m3 | 1 | 532.6 | 0.356661284265866 | 1 | 1.2313 | 0.439157039316561 |
| A4820 |  | Trazo y replanteo de interferencia | 3d | 2025-05-20 | 2025-05-22 | A4810 SS | 64d | 0d | 1 | 625 | 352.71 | m2 | 1 | 625 | 0.564336 | 1 | 1.2313 | 0.6948669168 |
| A4830 |  | Material de filtro piedra zarandeada (Ø 1/4" - 3") | 3d | 2025-05-20 | 2025-05-22 | A4820 SS | 97d | 0d | 1 | 60 | 34.932 | m3 | 1 | 60 | 0.5822 | 1 | 1.2313 | 0.71686286 |
| A4840 |  | Roca Subangular y/o subredondeada (Ø 3" - 10") | 3d | 2025-05-20 | 2025-05-22 | A4830 SS | 97d | 18d | 1 | 60 | 75.544 | m3 | 1 | 60 | 1.25906666666667 | 1 | 1.2313 | 1.55028878666667 |
| A4850 |  | Relleno compactado para estructuras | 5d | 2025-06-07 | 2025-06-11 | A4840 SS, A4960 | 79d | 13d | 1 | 70 | 246.6114 | m3 | 1 | 70 | 3.52302 | 1 | 1.2313 | 4.337894526 |
|  | 2 | **OBRAS DE CONCRETO** |  | 2025-05-23 | 2025-06-06 |  |  |  |  |  |  |  |  |  |  |  |  |  |
| A4860 |  | Suministro y colocación de concreto premezclado f´c=100 kg/cm2, e=0.10 m para solado | 15d | 2025-05-23 | 2025-06-06 | A4820 | 64d | 0d | 1 | 15 | 31.64 | m2 | 1 | 15 | 2.10933333333333 | 1 | 1.2313 | 2.59722213333333 |
| A4870 |  | Suministro y colocacion de cama de arena,e=0.20m para proteccion de tuberia | 15d | 2025-05-23 | 2025-06-06 | A4860 SS | 64d | 0d | 1 | 60 | 24.14 | m3 | 1 | 60 | 0.402333333333333 | 1 | 1.2313 | 0.495393033333333 |
| A4880 |  | Suministro y colocación de concreto ciclopeo f´c=175kg/cm2 + 30%PM | 15d | 2025-05-23 | 2025-06-06 | A4870 SS | 64d | 0d | 1 | 15 | 46.64 | m3 | 1 | 15 | 3.10933333333333 | 1 | 1.2313 | 3.82852213333333 |
| A4890 |  | Suministro y colocación de mampostería de piedra de concreto 70%pm + 30% concreto f´c=175 kg/cm2 | 15d | 2025-05-23 | 2025-06-06 | A4880 SS | 64d | 0d | 1 | 15 | 52.89 | m3 | 1 | 15 | 3.526 | 1 | 1.2313 | 4.3415638 |
| A4900 |  | Suministro, habilitación, encofrado y desencofrado para estructuras | 15d | 2025-05-23 | 2025-06-06 | A4890 SS | 64d | 0d | 2 | 16 | 174.07 | m2 | 1 | 32 | 5.4396875 | 2 | 1.2313 | 6.69788721875 |
| A4910 |  | Suministro, habilitación y colocación de acero de refuerzo f'y=4200 kg/cm2 | 15d | 2025-05-23 | 2025-06-06 | A4900 SS | 64d | 0d | 1 | 312.5 | 2291.23 | kg | 1 | 312.5 | 7.331936 | 1 | 1.2313 | 9.0278127968 |
| A4920 |  | Suministro y colocación de concreto estructural premezclado f´c=280 kg/cm2 | 15d | 2025-05-23 | 2025-06-06 | A4910 SS | 64d | 0d | 1 | 40 | 37.8 | m3 | 1 | 40 | 0.945 | 1 | 1.2313 | 1.1635785 |
| A4930 |  | Desvío provisional - canal de tierra para estructuras de interferencias | 15d | 2025-05-23 | 2025-06-06 | A4920 SS | 64d | 0d | 1 |  | 140 | m | 1 | 0 |  | 1 | 1.2313 | 0 |
| A4940 |  | Colocación de roca seleccionada, en uña antisocavante | 15d | 2025-05-23 | 2025-06-06 | A4930 SS | 64d | 0d | 1 | 170 | 129.72 | m3 | 1 | 170 | 0.763058823529412 | 1 | 1.2313 | 0.939554329411765 |
| A4950 |  | Junta de dilatación para mamposteria con sellante elastomérico de poliuretano 1/2" | 15d | 2025-05-23 | 2025-06-06 | A4940 SS | 64d | 0d | 1 | 50 | 14.23 | m | 1 | 50 | 0.2846 | 1 | 1.2313 | 0.35042798 |
| A4960 |  | Junta de contracción para mampostería con junta asfáltica 1"x1/2" | 15d | 2025-05-23 | 2025-06-06 | A4950 SS | 64d | 0d | 1 | 50 | 14.92 | m | 1 | 50 | 0.2984 | 1 | 1.2313 | 0.36741992 |
|  | 3 | **INSTALACIONES HIDRAULICAS** |  | 2025-06-07 | 2025-06-09 |  |  |  |  |  |  |  |  |  |  |  |  |  |
| A4970 |  | Suministro, habilitación e instalación de compuerta antiretorno tipo clapeta de DN 1200 mm | 3d | 2025-06-07 | 2025-06-09 | A4960 | 64d | 0d | 1 | 1.25 | 3 | und | 1 | 1.25 | 2.4 | 1 | 1.2313 | 2.95512 |
| A4980 |  | Suministro, habilitación e instalación de Tubería HDPE corrugado DN 1200 mm | 3d | 2025-06-07 | 2025-06-09 | A4970 SS | 64d | 0d | 1 | 24 | 44.4 | m | 1 | 24 | 1.85 | 1 | 1.2313 | 2.277905 |
| A4990 |  | Suministro, habilitación e instalación de junta de estanquidad waterstop 6" | 3d | 2025-06-07 | 2025-06-09 | A4980 SS | 64d | 0d | 1 | 50 | 22.62 | m | 1 | 50 | 0.4524 | 1 | 1.2313 | 0.55704012 |
| A5000 |  | Suministro, habilitación y colocación de geotextil no tejido 400 g/m2 | 3d | 2025-06-07 | 2025-06-09 | A4990 SS | 64d | 0d | 1 | 1500 | 135.042 | m2 | 1 | 1500 | 0.090028 | 1 | 1.2313 | 0.1108514764 |

| ID | WBS | Activity | Duration | Start | Finish | Predecessors | Total float | Free float | Cuadrilla | Rendimiento | Metrado | Unidad | Turno | RCuad | Dur. Cal. | Cuadrilla día | FactorR | FDur |
| --- | --- | --- | --- | --- | --- | --- | --- | --- | --- | --- | --- | --- | --- | --- | --- | --- | --- | --- |
|  | 2 | **RET-MI 27+150** |  | 2025-06-07 | 2025-06-29 |  |  |  |  |  |  |  |  |  |  |  |  |  |
|  | 1 | **MOVIMIENTO DE TIERRAS** |  | 2025-06-07 | 2025-06-29 |  |  |  |  |  |  |  |  |  |  |  |  |  |
| A5010 |  | Excavación en material común | 3d | 2025-06-07 | 2025-06-09 | A4860 | 64d | 0d | 1 | 724 | 331.85 | m3 | 1 | 724 | 0.45835635359116 | 1 | 1.2313 | 0.564374178176795 |
| A5020 |  | Relleno compactado con equipo pesado | 3d | 2025-06-07 | 2025-06-09 | A5010 SS | 64d | 0d | 1 | 532.6 | 174.1 | m3 | 1 | 532.6 | 0.326886969583177 | 1 | 1.2313 | 0.402495925647766 |
| A5030 |  | Trazo y replanteo de interferencia | 3d | 2025-06-07 | 2025-06-09 | A5020 SS | 64d | 0d | 1 | 625 | 634.27 | m2 | 1 | 625 | 1.014832 | 1 | 1.2313 | 1.2495626416 |
| A5040 |  | Material de filtro piedra zarandeada (Ø 1/4" - 3") | 3d | 2025-06-07 | 2025-06-09 | A5030 SS | 82d | 0d | 1 | 60 | 16.836 | m3 | 1 | 60 | 0.2806 | 1 | 1.2313 | 0.34550278 |
| A5050 |  | Roca Subangular y/o subredondeada (Ø 3" - 10") | 3d | 2025-06-07 | 2025-06-09 | A5040 SS | 82d | 18d | 1 | 60 | 35.512 | m3 | 1 | 60 | 0.591866666666667 | 1 | 1.2313 | 0.728765426666667 |
| A5060 |  | Relleno compactado para estructuras | 5d | 2025-06-25 | 2025-06-29 | A5050 SS, A5160 | 64d | 1d | 1 | 70 | 246.6 | m3 | 1 | 70 | 3.52285714285714 | 1 | 1.2313 | 4.337694 |
|  | 2 | **OBRAS DE CONCRETO** |  | 2025-06-10 | 2025-06-24 |  |  |  |  |  |  |  |  |  |  |  |  |  |
| A5070 |  | Suministro y colocación de concreto premezclado f´c=100 kg/cm2, e=0.10 m para solado | 15d | 2025-06-10 | 2025-06-24 | A5030, A5000 | 64d | 0d | 1 | 15 | 16.31 | m2 | 1 | 15 | 1.08733333333333 | 1 | 1.2313 | 1.33883353333333 |
| A5080 |  | Suministro y colocacion de cama de arena,e=0.20m para proteccion de tuberia | 15d | 2025-06-10 | 2025-06-24 | A5070 SS | 64d | 0d | 1 | 60 | 11.776 | m3 | 1 | 60 | 0.196266666666667 | 1 | 1.2313 | 0.241663146666667 |
| A5090 |  | Suministro y colocación de concreto ciclopeo f´c=175kg/cm2 + 30%PM | 15d | 2025-06-10 | 2025-06-24 | A5080 SS | 64d | 0d | 1 | 15 | 28.99 | m3 | 1 | 15 | 1.93266666666667 | 1 | 1.2313 | 2.37969246666667 |
| A5100 |  | Suministro y colocación de mampostería de piedra de concreto 70%pm + 30% concreto f´c=175 kg/cm2 | 15d | 2025-06-10 | 2025-06-24 | A5090 SS | 64d | 0d | 1 | 15 | 86.81 | m3 | 1 | 15 | 5.78733333333333 | 1 | 1.2313 | 7.12594353333333 |
| A5110 |  | Suministro, habilitación, encofrado y desencofrado para estructuras | 15d | 2025-06-10 | 2025-06-24 | A5100 SS | 64d | 0d | 3 | 16 | 301.16 | m2 | 1 | 48 | 6.27416666666667 | 3 | 1.2313 | 7.72538141666667 |
| A5120 |  | Suministro, habilitación y colocación de acero de refuerzo f'y=4200 kg/cm2 | 15d | 2025-06-10 | 2025-06-24 | A5110 SS | 64d | 0d | 1 | 312.5 | 1647.28 | kg | 1 | 312.5 | 5.271296 | 1 | 1.2313 | 6.4905467648 |
| A5130 |  | Suministro y colocación de concreto estructural premezclado f´c=280 kg/cm2 | 15d | 2025-06-10 | 2025-06-24 | A5120 SS | 64d | 0d | 1 | 40 | 25.64 | m3 | 1 | 40 | 0.641 | 1 | 1.2313 | 0.7892633 |
| A5140 |  | Suministro y colocación de enrocado con mortero (70% enrocado + 30% mortero f´c=175 kg/cm2) | 15d | 2025-06-10 | 2025-06-24 | A5130 SS | 64d | 0d | 1 | 100 | 187.63 | m3 | 1 | 100 | 1.8763 | 1 | 1.2313 | 2.31028819 |
| A5150 |  | Junta de dilatación para mamposteria con sellante elastomérico de poliuretano 1/2" | 15d | 2025-06-10 | 2025-06-24 | A5140 SS | 64d | 0d | 1 | 50 | 14.49 | m | 1 | 50 | 0.2898 | 1 | 1.2313 | 0.35683074 |
| A5160 |  | Junta de contracción para mampostería con junta asfáltica 1"x1/2" | 15d | 2025-06-10 | 2025-06-24 | A5150 SS | 64d | 0d | 1 | 50 | 85.74 | m | 1 | 50 | 1.7148 | 1 | 1.2313 | 2.11143324 |
|  | 3 | **INSTALACIONES HIDRAULICAS** |  | 2025-06-25 | 2025-06-27 |  |  |  |  |  |  |  |  |  |  |  |  |  |
| A5170 |  | Suministro, habilitación e instalación de compuerta antiretorno tipo clapeta de DN 1200 mm | 3d | 2025-06-25 | 2025-06-27 | A5160, A4850 | 66d | 0d | 1 | 1.25 | 2 | und | 1 | 1.25 | 1.6 | 1 | 1.2313 | 1.97008 |
| A5180 |  | Suministro, habilitación e instalación de Tubería HDPE corrugado DN 1200 mm | 3d | 2025-06-25 | 2025-06-27 | A5170 SS | 66d | 0d | 1 | 24 | 19.56 | m | 1 | 24 | 0.815 | 1 | 1.2313 | 1.0035095 |
| A5190 |  | Suministro, habilitación e instalación de junta de estanquidad waterstop 6" | 3d | 2025-06-25 | 2025-06-27 | A5180 SS | 66d | 0d | 1 | 50 | 15.08 | m | 1 | 50 | 0.3016 | 1 | 1.2313 | 0.37136008 |
| A5200 |  | Suministro, habilitación y colocación de geotextil no tejido 400 g/m2 | 3d | 2025-06-25 | 2025-06-27 | A5190 SS | 66d | 3d | 1 | 1500 | 68.264 | m2 | 1 | 1500 | 0.0455093333333333 | 1 | 1.2313 | 0.0560356421333333 |

| ID | WBS | Activity | Duration | Start | Finish | Predecessors | Total float | Free float | Cuadrilla | Rendimiento | Metrado | Unidad | Turno | RCuad | Dur. Cal. | Cuadrilla día | FactorR | FDur |
| --- | --- | --- | --- | --- | --- | --- | --- | --- | --- | --- | --- | --- | --- | --- | --- | --- | --- | --- |
|  | 3 | **CA-MI 27+550** |  | 2025-07-01 | 2025-07-05 |  |  |  |  |  |  |  |  |  |  |  |  |  |
|  | 1 | **MOVIMIENTO DE TIERRAS** |  | 2025-07-01 | 2025-07-05 |  |  |  |  |  |  |  |  |  |  |  |  |  |
| A5210 |  | Excavación en material común | 5d | 2025-07-01 | 2025-07-05 | C2190, A5200 | 63d | 0d | 1 | 724 | 1233.54 | m3 | 1 | 724 | 1.70378453038674 | 1 | 1.2313 | 2.09786989226519 |
| A5220 |  | Trazo y replanteo de interferencia | 5d | 2025-07-01 | 2025-07-05 | A5210 SS, A5060 | 63d | 0d | 1 | 625 | 2440.27 | m2 | 1 | 625 | 3.904432 | 1 | 1.2313 | 4.8075271216 |
| A5230 |  | Relleno propio sin compactar | 5d | 2025-07-01 | 2025-07-05 | A5220 SS | 63d | 7d | 1 | 1100 | 171.8 | m3 | 1 | 1100 | 0.156181818181818 | 1 | 1.2313 | 0.192306672727273 |
|  | 11 | **RAMPAS Y ACCESOS A CORONA** |  | 2025-06-08 | 2025-12-05 |  |  |  |  |  |  |  |  |  |  |  |  |  |
|  | 1 | **ACC. COR - 19+655** |  | 2025-06-08 | 2025-06-10 |  |  |  |  |  |  |  |  |  |  |  |  |  |
|  | 1 | **MOVIMIENTO DE TIERRAS PARA RAMPAS Y ACCESOS A CORONA** |  | 2025-06-08 | 2025-06-10 |  |  |  |  |  |  |  |  |  |  |  |  |  |
| A5260 |  | Excavación en material común | 1d | 2025-06-08 | 2025-06-08 | C4990 | 66d | 0d | 1 | 724 | 60.7 | m3 | 1 | 724 | 0.0838397790055249 | 1 | 1.2313 | 0.103231919889503 |
| A5270 |  | Transporte de material excedente a DME, d=1km | 1d | 2025-06-08 | 2025-06-08 | A5260 SS | 66d | 0d | 1 |  | 26.52 | m3xkm | 1 | 0 |  | 1 | 1.2313 | 0 |
| A5280 |  | Transporte de material excedente a DME, d>1km | 1d | 2025-06-08 | 2025-06-08 | A5270 SS | 66d | 0d | 1 |  | 60.85 | m3xkm | 1 | 0 |  | 1 | 1.2313 | 0 |
| A5310 |  | Proceso y selección de material propio | 1d | 2025-06-08 | 2025-06-08 | A5260 SS | 67d | 1d | 1 | 900 | 267.36 | m3 | 1 | 900 | 0.297066666666667 | 1 | 1.2313 | 0.365778186666667 |
| A5290 |  | Conformación y compactación de superficie para fundación con equipo pesado | 1d | 2025-06-09 | 2025-06-09 | A5260, A5280 | 66d | 0d | 1 | 2800 | 613.95 | m2 | 1 | 2800 | 0.219267857142857 | 1 | 1.2313 | 0.2699845125 |
| A5300 |  | Relleno compactado con equipo pesado | 1d | 2025-06-10 | 2025-06-10 | A5290 | 66d | 0d | 1 | 532.6 | 267.36 | m3 | 1 | 532.6 | 0.501990236575291 | 1 | 1.2313 | 0.618100578295156 |
| A5320 |  | Transporte de material propio para relleno, d=1km | 1d | 2025-06-10 | 2025-06-10 | A5300 SS, A5310 | 66d | 15d | 1 |  | 37.44 | m3xkm | 1 | 0 |  | 1 | 1.2313 | 0 |
|  | 2 | **ACC. COR 19+730** |  | 2025-06-26 | 2025-07-18 |  |  |  |  |  |  |  |  |  |  |  |  |  |
|  | 1 | **MOVIMIENTO DE TIERRAS PARA RAMPAS Y ACCESOS A CORONA** |  | 2025-06-26 | 2025-07-18 |  |  |  |  |  |  |  |  |  |  |  |  |  |
| A5330 |  | Excavación en material común | 2d | 2025-06-26 | 2025-06-27 | C5190, A5320 | 51d | 0d | 1 | 724 | 698.06 | m3 | 1 | 724 | 0.964171270718232 | 1 | 1.2313 | 1.18718408563536 |
| A5360 |  | Transporte de material excedente a DME, d=1km | 17d | 2025-06-26 | 2025-07-12 | A5330 SS | 57d | 0d | 1 |  | 974.92 | m3xkm | 1 | 0 |  | 1 | 1.2313 | 0 |
| A5370 |  | Transporte de material excedente a DME, d>1km | 17d | 2025-06-26 | 2025-07-12 | A5360 SS | 57d | 12d | 1 |  | 2237.12 | m3xkm | 1 | 0 |  | 1 | 1.2313 | 0 |
| A5450 |  | Proceso y selección de material propio | 2d | 2025-06-26 | 2025-06-27 | A5330 SS | 95d | 4d | 1 | 900 | 268.85 | m3 | 1 | 900 | 0.298722222222222 | 1 | 1.2313 | 0.367816672222222 |
| A5380 |  | Conformación y compactación de superficie para fundación con equipo pesado | 1d | 2025-06-28 | 2025-06-28 | A5330 | 51d | 0d | 1 | 2800 | 1050 | m2 | 1 | 2800 | 0.375 | 1 | 1.2313 | 0.4617375 |
| A5400 |  | Perfilado de taludes de dique con equipo | 3d | 2025-06-29 | 2025-07-01 | A5380 | 51d | 0d | 1 | 900 | 1540 | m2 | 1 | 900 | 1.71111111111111 | 1 | 1.2313 | 2.10689111111111 |
| A5340 |  | Excavación para conformación de uña antisocavante | 11d | 2025-07-02 | 2025-07-12 | A5400 | 51d | 0d | 1 | 450 | 1516.15 | m3 | 1 | 450 | 3.36922222222222 | 1 | 1.2313 | 4.14852332222222 |
| A5350 |  | Excavación de zanja de anclaje para geotextil | 17d | 2025-07-02 | 2025-07-18 | A5420 SS | 51d | 6d | 1 | 25 | 17.21 | m3 | 1 | 25 | 0.6884 | 1 | 1.2313 | 0.84762692 |
| A5420 |  | Colocación de roca seleccionada, en uña antisocavante | 11d | 2025-07-02 | 2025-07-12 | A5340 SS | 51d | 0d | 1 | 170 | 1516.15 | m3 | 1 | 170 | 8.91852941176471 | 1 | 1.2313 | 10.9813852647059 |
| A5430 |  | Suministro, habilitación y colocación de geotextil no tejido 400 g/m2 | 17d | 2025-07-02 | 2025-07-18 | A5420 SS | 51d | 6d | 1 | 1500 | 1400 | m2 | 1 | 1500 | 0.933333333333333 | 1 | 1.2313 | 1.14921333333333 |
| A5470 |  | Transporte de roca seleccionada de cantera para enrocado de protección, d=1km | 17d | 2025-07-02 | 2025-07-18 | A5420 SS, A5450 | 91d | 0d | 1 |  | 2013.32 | m3xkm | 1 | 0 |  | 1 | 1.2313 | 0 |
| A5480 |  | Transporte de roca seleccionada de cantera para enrocado de protección, d>1km | 17d | 2025-07-02 | 2025-07-18 | A5470 SS | 91d | 37d | 1 |  | 41325.86 | m3xkm | 1 | 0 |  | 1 | 1.2313 | 0 |
| A5410 |  | Colocación de roca seleccionada, en cara húmeda de talud | 6d | 2025-07-13 | 2025-07-18 | A5420 | 51d | 6d | 1 | 160 | 771.71 | m3 | 1 | 160 | 4.8231875 | 1 | 1.2313 | 5.93879076875 |
| A5440 |  | Relleno propio sin compactar | 1d | 2025-07-13 | 2025-07-13 | A5420, A5230 | 56d | 0d | 1 | 1100 | 268.85 | m3 | 1 | 1100 | 0.244409090909091 | 1 | 1.2313 | 0.300940913636364 |
| A5460 |  | Transporte de material propio para relleno, d=1km | 1d | 2025-07-13 | 2025-07-13 | A5440 SS | 56d | 11d | 1 |  | 37.65 | m3xkm | 1 | 0 |  | 1 | 1.2313 | 0 |

| ID | WBS | Activity | Duration | Start | Finish | Predecessors | Total float | Free float | Cuadrilla | Rendimiento | Metrado | Unidad | Turno | RCuad | Dur. Cal. | Cuadrilla día | FactorR | FDur |
| --- | --- | --- | --- | --- | --- | --- | --- | --- | --- | --- | --- | --- | --- | --- | --- | --- | --- | --- |
|  | 3 | **ACC. COR 26+367** |  | 2025-09-24 | 2025-09-26 |  |  |  |  |  |  |  |  |  |  |  |  |  |
|  | 1 | **MOVIMIENTO DE TIERRAS PARA RAMPAS Y ACCESOS A CORONA** |  | 2025-09-24 | 2025-09-26 |  |  |  |  |  |  |  |  |  |  |  |  |  |
| A5490 |  | Excavación en material común | 1d | 2025-09-24 | 2025-09-24 | C2570 | 19d | 0d | 1 | 724 | 46.75 | m3 | 1 | 724 | 0.0645718232044199 | 1 | 1.2313 | 0.0795072859116022 |
| A5500 |  | Transporte de material excedente a DME, d=1km | 1d | 2025-09-24 | 2025-09-24 | A5490 SS | 19d | 0d | 1 |  | 20.43 | m3xkm | 1 | 0 |  | 1 | 1.2313 | 0 |
| A5510 |  | Transporte de material excedente a DME, d>1km | 1d | 2025-09-24 | 2025-09-24 | A5500 SS | 19d | 0d | 1 |  | 46.87 | m3xkm | 1 | 0 |  | 1 | 1.2313 | 0 |
| A5540 |  | Proceso y selección de material propio | 1d | 2025-09-24 | 2025-09-24 | A5490 SS | 20d | 1d | 1 | 900 | 1.15 | m3 | 1 | 900 | 0.00127777777777778 | 1 | 1.2313 | 0.00157332777777778 |
| A5520 |  | Conformación y compactación de superficie para fundación con equipo pesado | 1d | 2025-09-25 | 2025-09-25 | A5490, A5510 | 19d | 0d | 1 | 2800 | 149.7 | m2 | 1 | 2800 | 0.0534642857142857 | 1 | 1.2313 | 0.065830575 |
| A5530 |  | Relleno compactado con equipo pesado | 1d | 2025-09-26 | 2025-09-26 | A5520 | 19d | 0d | 1 | 532.6 | 1.15 | m3 | 1 | 532.6 | 0.00215921892602328 | 1 | 1.2313 | 0.00265864626361246 |
| A5550 |  | Transporte de material propio para relleno, d=1km | 1d | 2025-09-26 | 2025-09-26 | A5530 SS, A5540 | 19d | 0d | 1 |  | 0.16 | m3xkm | 1 | 0 |  | 1 | 1.2313 | 0 |
|  | 4 | **ACC. COR 26+340** |  | 2025-09-27 | 2025-09-29 |  |  |  |  |  |  |  |  |  |  |  |  |  |
|  | 1 | **MOVIMIENTO DE TIERRAS PARA RAMPAS Y ACCESOS A CORONA** |  | 2025-09-27 | 2025-09-29 |  |  |  |  |  |  |  |  |  |  |  |  |  |
| A5560 |  | Excavación en material común | 1d | 2025-09-27 | 2025-09-27 | A5550 | 19d | 0d | 1 | 724 | 6.56 | m3 | 1 | 724 | 0.00906077348066298 | 1 | 1.2313 | 0.0111565303867403 |
| A5570 |  | Transporte de material excedente a DME, d=1km | 1d | 2025-09-27 | 2025-09-27 | A5560 SS | 19d | 0d | 1 |  | 2.87 | m3xkm | 1 | 0 |  | 1 | 1.2313 | 0 |
| A5580 |  | Transporte de material excedente a DME, d>1km | 1d | 2025-09-27 | 2025-09-27 | A5570 SS | 19d | 0d | 1 |  | 6.58 | m3xkm | 1 | 0 |  | 1 | 1.2313 | 0 |
| A5610 |  | Proceso y selección de material propio | 1d | 2025-09-27 | 2025-09-27 | A5560 SS | 21d | 2d | 1 | 900 | 0.38 | m3 | 1 | 900 | 0.000422222222222222 | 1 | 1.2313 | 0.000519882222222222 |
| A5590 |  | Conformación y compactación de superficie para fundación con equipo pesado | 1d | 2025-09-28 | 2025-09-28 | A5560, A5580 | 19d | 0d | 1 | 2800 | 223.05 | m2 | 1 | 2800 | 0.0796607142857143 | 1 | 1.2313 | 0.0980862375 |
| A5600 |  | Relleno compactado con equipo pesado | 1d | 2025-09-29 | 2025-09-29 | A5590 | 19d | 0d | 1 | 532.6 | 0.38 | m3 | 1 | 532.6 | 0.000713481036425085 | 1 | 1.2313 | 0.000878509200150207 |
| A5620 |  | Transporte de material propio para relleno, d=1km | 1d | 2025-09-29 | 2025-09-29 | A5600 SS | 19d | 0d | 1 |  | 0.05 | m3xkm | 1 | 0 |  | 1 | 1.2313 | 0 |
|  | 5 | **ACC. COR 26+460** |  | 2025-09-30 | 2025-10-02 |  |  |  |  |  |  |  |  |  |  |  |  |  |
|  | 1 | **MOVIMIENTO DE TIERRAS PARA RAMPAS Y ACCESOS A CORONA** |  | 2025-09-30 | 2025-10-02 |  |  |  |  |  |  |  |  |  |  |  |  |  |
| A5630 |  | Excavación en material común | 1d | 2025-09-30 | 2025-09-30 | A5620, A5610 | 19d | 0d | 1 | 724 | 37.36 | m3 | 1 | 724 | 0.0516022099447514 | 1 | 1.2313 | 0.0635378011049724 |
| A5640 |  | Transporte de material excedente a DME, d=1km | 1d | 2025-09-30 | 2025-09-30 | A5630 SS | 19d | 0d | 1 |  | 16.32 | m3xkm | 1 | 0 |  | 1 | 1.2313 | 0 |
| A5650 |  | Transporte de material excedente a DME, d>1km | 1d | 2025-09-30 | 2025-09-30 | A5640 SS | 19d | 0d | 1 |  | 37.46 | m3xkm | 1 | 0 |  | 1 | 1.2313 | 0 |
| A5680 |  | Proceso y selección de material propio | 1d | 2025-09-30 | 2025-09-30 | A5630 SS | 20d | 1d | 1 | 900 | 5.3 | m3 | 1 | 900 | 0.00588888888888889 | 1 | 1.2313 | 0.00725098888888889 |
| A5660 |  | Conformación y compactación de superficie para fundación con equipo pesado | 1d | 2025-10-01 | 2025-10-01 | A5630, A5650 | 19d | 0d | 1 | 2800 | 438.9 | m2 | 1 | 2800 | 0.15675 | 1 | 1.2313 | 0.193006275 |
| A5670 |  | Relleno compactado con equipo pesado | 1d | 2025-10-02 | 2025-10-02 | A5660 | 19d | 0d | 1 | 532.6 | 5.3 | m3 | 1 | 532.6 | 0.00995118287645512 | 1 | 1.2313 | 0.0122528914757792 |
| A5690 |  | Transporte de material propio para relleno, d=1km | 1d | 2025-10-02 | 2025-10-02 | A5670 SS, A5680 | 19d | 12d | 1 |  | 0.74 | m3xkm | 1 | 0 |  | 1 | 1.2313 | 0 |

| ID | WBS | Activity | Duration | Start | Finish | Predecessors | Total float | Free float | Cuadrilla | Rendimiento | Metrado | Unidad | Turno | RCuad | Dur. Cal. | Cuadrilla día | FactorR | FDur |
| --- | --- | --- | --- | --- | --- | --- | --- | --- | --- | --- | --- | --- | --- | --- | --- | --- | --- | --- |
|  | 6 | **ACC. COR 27+657** |  | 2025-10-15 | 2025-10-17 |  |  |  |  |  |  |  |  |  |  |  |  |  |
|  | 1 | **MOVIMIENTO DE TIERRAS PARA RAMPAS Y ACCESOS A CORONA** |  | 2025-10-15 | 2025-10-17 |  |  |  |  |  |  |  |  |  |  |  |  |  |
| A5700 |  | Excavación en material común | 1d | 2025-10-15 | 2025-10-15 | C3780, A5690 | 7d | 0d | 1 | 724 | 2.88 | m3 | 1 | 724 | 0.00397790055248619 | 1 | 1.2313 | 0.00489798895027625 |
| A5710 |  | Transporte de material excedente a DME, d=1km | 1d | 2025-10-15 | 2025-10-15 | A5700 SS | 7d | 0d | 1 |  | 1.26 | m3xkm | 1 | 0 |  | 1 | 1.2313 | 0 |
| A5720 |  | Transporte de material excedente a DME, d>1km | 1d | 2025-10-15 | 2025-10-15 | A5710 SS | 7d | 0d | 1 |  | 2.89 | m3xkm | 1 | 0 |  | 1 | 1.2313 | 0 |
| A5750 |  | Proceso y selección de material propio | 1d | 2025-10-15 | 2025-10-15 | A5700 SS | 9d | 8d | 1 | 900 | 101.46 | m3 | 1 | 900 | 0.112733333333333 | 1 | 1.2313 | 0.138808553333333 |
| A5730 |  | Conformación y compactación de superficie para fundación con equipo pesado | 1d | 2025-10-16 | 2025-10-16 | A5700, A5720 | 7d | 0d | 1 | 2800 | 365.09 | m2 | 1 | 2800 | 0.130389285714286 | 1 | 1.2313 | 0.1605483275 |
| A5740 |  | Relleno compactado con equipo pesado | 1d | 2025-10-17 | 2025-10-17 | A5730 | 7d | 0d | 1 | 532.6 | 101.46 | m3 | 1 | 532.6 | 0.190499436725498 | 1 | 1.2313 | 0.234561956440106 |
| A5760 |  | Transporte de material propio para relleno, d=1km | 1d | 2025-10-17 | 2025-10-17 | A5740 SS | 7d | 6d | 1 |  | 14.21 | m3xkm | 1 | 0 |  | 1 | 1.2313 | 0 |
|  | 7 | **RAMPAS 15+870** |  | 2025-07-25 | 2025-09-09 |  |  |  |  |  |  |  |  |  |  |  |  |  |
|  | 1 | **MOVIMIENTO DE TIERRAS PARA RAMPAS Y ACCESOS A CORONA** |  | 2025-07-25 | 2025-09-09 |  |  |  |  |  |  |  |  |  |  |  |  |  |
| A5770 |  | Excavación en material común | 13d | 2025-07-25 | 2025-08-06 | C4200, A5350, A5370, A5410, A5430, A5460 | 45d | 0d | 1 | 724 | 7202.71 | m3 | 1 | 724 | 9.94849447513812 | 1 | 1.2313 | 12.2495812472376 |
| A5800 |  | Transporte de material excedente a DME, d=1km | 43d | 2025-07-25 | 2025-09-05 | A5770 SS | 49d | 0d | 1 |  | 3914.37 | m3xkm | 1 | 0 |  | 1 | 1.2313 | 0 |
| A5810 |  | Transporte de material excedente a DME, d>1km | 43d | 2025-07-25 | 2025-09-05 | A5800 SS | 49d | 48d | 1 |  | 8982.15 | m3xkm | 1 | 0 |  | 1 | 1.2313 | 0 |
| A5880 |  | Proceso y selección de material propio | 13d | 2025-07-25 | 2025-08-06 | A5770 SS | 45d | 0d | 1 | 900 | 9157.1 | m3 | 1 | 900 | 10.1745555555556 | 1 | 1.2313 | 12.5279302555556 |
| A5820 |  | Conformación y compactación de superficie para fundación con equipo pesado | 2d | 2025-08-05 | 2025-08-06 | A5770 FF | 45d | 0d | 1 | 2800 | 2569.28 | m2 | 1 | 2800 | 0.9176 | 1 | 1.2313 | 1.12984088 |
| A5830 |  | Relleno compactado con equipo pesado | 19d | 2025-08-06 | 2025-08-24 | A5820 SS+1d | 45d | 0d | 1 | 532.6 | 7966.96 | m3 | 1 | 532.6 | 14.9586180998873 | 1 | 1.2313 | 18.4185464663912 |
| A5890 |  | Transporte de material propio para relleno, d=1km | 19d | 2025-08-07 | 2025-08-25 | A5830 SS, A5880 | 45d | 0d | 1 |  | 1282.28 | m3xkm | 1 | 0 |  | 1 | 1.2313 | 0 |
| A5840 |  | Perfilado de taludes de dique con equipo | 3d | 2025-08-22 | 2025-08-24 | A5830 FF | 45d | 0d | 1 | 900 | 2260.85 | m2 | 1 | 900 | 2.51205555555556 | 1 | 1.2313 | 3.09309400555556 |
| A5780 |  | Excavación para conformación de uña antisocavante | 12d | 2025-08-25 | 2025-09-05 | A5840 | 45d | 0d | 1 | 450 | 1726.74 | m3 | 1 | 450 | 3.8372 | 1 | 1.2313 | 4.72474436 |
| A5790 |  | Excavación de zanja de anclaje para geotextil | 5d | 2025-08-25 | 2025-08-29 | A6150 SS, A5480 | 54d | 8d | 1 | 25 | 29.83 | m3 | 1 | 25 | 1.1932 | 1 | 1.2313 | 1.46918716 |
| A5860 |  | Colocación de roca seleccionada, en uña antisocavante | 12d | 2025-08-26 | 2025-09-06 | A5780 SS+1d | 45d | 0d | 1 | 170 | 1672.51 | m3 | 1 | 170 | 9.83829411764706 | 1 | 1.2313 | 12.1138915470588 |
| A5900 |  | Transporte de roca seleccionada de cantera para enrocado de protección, d=1km | 15d | 2025-08-26 | 2025-09-09 | A5860 SS, A5890 | 45d | 0d | 1 |  | 1703.16 | m3xkm | 1 | 0 |  | 1 | 1.2313 | 0 |
| A5910 |  | Transporte de roca seleccionada de cantera para enrocado de protección, d>1km | 15d | 2025-08-26 | 2025-09-09 | A5900 SS | 45d | 44d | 1 |  | 34959.52 | m3xkm | 1 | 0 |  | 1 | 1.2313 | 0 |
| A5850 |  | Colocación de roca seleccionada, en cara húmeda de talud | 3d | 2025-09-07 | 2025-09-09 | A5860, A6190 | 45d | 44d | 1 | 160 | 262.9 | m3 | 1 | 160 | 1.643125 | 1 | 1.2313 | 2.0231798125 |
| A5870 |  | Relleno propio sin compactar | 2d | 2025-09-07 | 2025-09-08 | A5860, A5790, A6130 | 46d | 45d | 1 | 1100 | 1190.14 | m3 | 1 | 1100 | 1.08194545454545 | 1 | 1.2313 | 1.33219943818181 |

| ID | WBS | Activity | Duration | Start | Finish | Predecessors | Total float | Free float | Cuadrilla | Rendimiento | Metrado | Unidad | Turno | RCuad | Dur. Cal. | Cuadrilla día | FactorR | FDur |
| --- | --- | --- | --- | --- | --- | --- | --- | --- | --- | --- | --- | --- | --- | --- | --- | --- | --- | --- |
|  | 2 | **SISTEMA DE CONFINAMIENTO CON GEOCELDAS** |  | 2025-08-25 | 2025-09-04 |  |  |  |  |  |  |  |  |  |  |  |  |  |
| A6150 |  | Suministro, habilitación y colocación de geotextil no tejido 200 g/m2 | 4d | 2025-08-25 | 2025-08-28 | A5840 | 47d | 0d | 1 | 750 | 2018.91 | m2 | 1 | 750 | 2.69188 | 1 | 1.2313 | 3.314511844 |
| A6160 |  | Suministro, habilitación y colocación de sistema de confinamiento geocelda h=200 mm | 4d | 2025-08-29 | 2025-09-01 | A6150 | 47d | 0d | 1 | 337.5 | 918.03 | m2 | 1 | 337.5 | 2.72008888888889 | 1 | 1.2313 | 3.34924544888889 |
| A6170 |  | Suministro y colocación de concreto premezclado f'c=210 kg/cm2 para geocelda | 6d | 2025-08-30 | 2025-09-04 | A6160 SS+1d | 47d | 0d | 1 | 40 | 181.41 | m3 | 1 | 40 | 4.53525 | 1 | 1.2313 | 5.584253325 |
| A6180 |  | Transporte de concreto premezclado con camión mixer, d=1km | 6d | 2025-08-30 | 2025-09-04 | A6170 SS | 47d | 0d | 1 |  | 159.64 | m3k | 1 | 0 |  | 1 | 1.2313 | 0 |
| A6190 |  | Transporte de concreto premezclado con camión mixer, d>1km | 6d | 2025-08-30 | 2025-09-04 | A6180 SS | 47d | 2d | 1 |  | 6072.16 | m3k | 1 | 0 |  | 1 | 1.2313 | 0 |
|  | 8 | **RAMPAS 25+860** |  | 2025-10-24 | 2025-12-05 |  |  |  |  |  |  |  |  |  |  |  |  |  |
|  | 1 | **MOVIMIENTO DE TIERRAS PARA RAMPAS Y ACCESOS A CORONA** |  | 2025-10-24 | 2025-12-05 |  |  |  |  |  |  |  |  |  |  |  |  |  |
| A5920 |  | Excavación en material común | 9d | 2025-10-24 | 2025-11-01 | C4000, A5750, A5760, A5810, A5850, A5870, A5910 | 1d | 0d | 1 | 724 | 4824.36 | m3 | 1 | 724 | 6.66348066298343 | 1 | 1.2313 | 8.2047437403315 |
| A5950 |  | Transporte de material excedente a DME, d=1km | 32d | 2025-10-24 | 2025-11-24 | A5920 SS | 37d | 0d | 1 |  | 3898.58 | m3xkm | 1 | 0 |  | 1 | 1.2313 | 0 |
| A5960 |  | Transporte de material excedente a DME, d>1km | 32d | 2025-10-24 | 2025-11-24 | A5950 SS | 37d | 1d | 1 |  | 8945.92 | m3xkm | 1 | 0 |  | 1 | 1.2313 | 0 |
| A6040 |  | Proceso y selección de material propio | 3d | 2025-10-24 | 2025-10-26 | A5920 SS | 7d | 6d | 1 | 900 | 1748.32 | m3 | 1 | 900 | 1.94257777777778 | 1 | 1.2313 | 2.39189601777778 |
| A5970 |  | Conformación y compactación de superficie para fundación con equipo pesado | 1d | 2025-11-02 | 2025-11-02 | A5920, A6490, A6040 | 1d | 0d | 1 | 2800 | 759.04 | m2 | 1 | 2800 | 0.271085714285714 | 1 | 1.2313 | 0.33378784 |
| A5980 |  | Relleno compactado con equipo pesado | 3d | 2025-11-03 | 2025-11-05 | A5970 | 1d | 0d | 1 | 532.6 | 1133.07 | m3 | 1 | 532.6 | 2.12743146826887 | 1 | 1.2313 | 2.61950636687946 |
| A6050 |  | Transporte de material propio para relleno, d=1km | 1d | 2025-11-03 | 2025-11-03 | A5980 SS | 7d | 6d | 1 |  | 244.82 | m3xkm | 1 | 0 |  | 1 | 1.2313 | 0 |
| A5990 |  | Perfilado de taludes de dique con equipo | 4d | 2025-11-06 | 2025-11-09 | A5980 | 1d | 0d | 1 | 900 | 2314.34 | m2 | 1 | 900 | 2.57148888888889 | 1 | 1.2313 | 3.16627426888889 |
| A5930 |  | Excavación para conformación de uña antisocavante | 15d | 2025-11-10 | 2025-11-24 | A5990, A6140, A6050 | 1d | 0d | 1 | 450 | 4070.23 | m3 | 1 | 450 | 9.04495555555555 | 1 | 1.2313 | 11.1370537755555 |
| A5940 |  | Excavación de zanja de anclaje para geotextil | 20d | 2025-11-11 | 2025-11-30 | A6020 SS | 1d | 4d | 1 | 25 | 28.55 | m3 | 1 | 25 | 1.142 | 1 | 1.2313 | 1.4061446 |
| A6010 |  | Colocación de roca seleccionada, en uña antisocavante | 15d | 2025-11-11 | 2025-11-25 | A5930 SS+1d | 1d | 0d | 1 | 170 | 4070.16 | m3 | 2 | 340 | 11.9710588235294 | 2 | 1.2313 | 14.7399647294118 |
| A6020 |  | Suministro, habilitación y colocación de geotextil no tejido 400 g/m2 | 25d | 2025-11-11 | 2025-12-05 | A6010 SS | 1d | 0d | 1 | 1500 | 2081.51 | m2 | 1 | 1500 | 1.38767333333333 | 1 | 1.2313 | 1.70864217533333 |
| A6060 |  | Transporte de roca seleccionada de cantera para enrocado de protección, d=1km | 25d | 2025-11-11 | 2025-12-05 | A6010 SS | 36d | 0d | 1 |  | 4696.48 | m3xkm | 1 | 0 |  | 1 | 1.2313 | 0 |
| A6070 |  | Transporte de roca seleccionada de cantera para enrocado de protección, d>1km | 25d | 2025-11-11 | 2025-12-05 | A6060 SS | 36d | 39d | 1 |  | 96401.16 | m3xkm | 1 | 0 |  | 1 | 1.2313 | 0 |
| A6000 |  | Colocación de roca seleccionada, en cara húmeda de talud | 10d | 2025-11-26 | 2025-12-05 | A6010, A5960 | 36d | 39d | 1 | 160 | 1266.75 | m3 | 1 | 160 | 7.9171875 | 1 | 1.2313 | 9.74843296875 |
| A6030 |  | Relleno propio sin compactar | 1d | 2025-11-26 | 2025-11-26 | A6010 | 45d | 48d | 1 | 1100 | 615.25 | m3 | 1 | 1100 | 0.559318181818182 | 1 | 1.2313 | 0.688688477272728 |

| ID | WBS | Activity | Type | Duration | Start | Finish | Predecessors | Total float | Free float | Cuadrilla | Rendimiento | Metrado | Unidad | Turno | RCuad | Dur. Cal. | Cuadrilla día | FactorR | FDur |
| --- | --- | --- | --- | --- | --- | --- | --- | --- | --- | --- | --- | --- | --- | --- | --- | --- | --- | --- | --- |
|  | 9 | **CONEXION 15+870** |  |  | 2025-09-06 | 2025-09-08 |  |  |  |  |  |  |  |  |  |  |  |  |  |
|  | 1 | **MOVIMIENTO DE TIERRAS PARA RAMPAS Y ACCESOS A CORONA** |  |  | 2025-09-06 | 2025-09-08 |  |  |  |  |  |  |  |  |  |  |  |  |  |
| A6080 |  | Excavación en material común |  | 1d | 2025-09-06 | 2025-09-06 | A5780 | 46d | 0d | 1 | 724 | 1.09 | m3 | 1 | 724 | 0.00150552486187845 | 1 | 1.2313 | 0.00185375276243094 |
| A6090 |  | Transporte de material excedente a DME, d=1km |  | 1d | 2025-09-06 | 2025-09-06 | A6080 SS | 63d | 0d | 1 |  | 0.48 | m3xkm | 1 | 0 |  | 1 | 1.2313 | 0 |
| A6100 |  | Transporte de material excedente a DME, d>1km |  | 1d | 2025-09-06 | 2025-09-06 | A6090 SS | 63d | 0d | 1 |  | 1.08 | m3xkm | 1 | 0 |  | 1 | 1.2313 | 0 |
| A6130 |  | Proceso y selección de material propio |  | 1d | 2025-09-06 | 2025-09-06 | A6080 SS | 46d | 0d | 1 | 900 | 408.08 | m3 | 1 | 900 | 0.453422222222222 | 1 | 1.2313 | 0.558298782222222 |
| A6110 |  | Conformación y compactación de superficie para fundación con equipo pesado |  | 1d | 2025-09-07 | 2025-09-07 | A6080, A6100 | 63d | 0d | 1 | 2800 | 475.54 | m2 | 1 | 2800 | 0.169835714285714 | 1 | 1.2313 | 0.209118715 |
| A6120 |  | Relleno compactado con equipo pesado |  | 1d | 2025-09-08 | 2025-09-08 | A6110 | 63d | 0d | 1 | 532.6 | 408.08 | m3 | 1 | 532.6 | 0.766203529853549 | 1 | 1.2313 | 0.943426406308675 |
| A6140 |  | Transporte de material propio para relleno, d=1km |  | 1d | 2025-09-08 | 2025-09-08 | A6120 SS | 63d | 62d | 1 |  | 57.14 | m3xkm | 1 | 0 |  | 1 | 1.2313 | 0 |
|  | 13 | **ARQUITECTURA Y PAISAJISMO** |  |  | 2025-04-05 | 2025-09-10 |  |  |  |  |  |  |  |  |  |  |  |  |  |
| A6480 |  | Inicio - Arquitectura y Paisajismo | milestone | 0d | 2025-04-05 | 2025-04-05 | A4770 SS | 17d | 0d |  |  |  |  |  | 0 |  | 0 |  | 0 |
| A6490 |  | Fin - Arquitectura y Paisajismo | milestone | 0d | 2025-09-10 | 2025-09-10 | A6460 FF | 53d | 52d |  |  |  |  |  | 0 |  | 0 |  | 0 |
|  | 1 | **MOVIMIENTO DE TIERRAS** |  |  | 2025-04-05 | 2025-04-09 |  |  |  |  |  |  |  |  |  |  |  |  |  |
| A6210 |  | Perfilado y compactación en zona de intervención |  | 5d | 2025-04-05 | 2025-04-09 | A6480 SS | 17d | 0d |  |  | 288.08 | m2 |  | 0 |  | 0 |  | 0 |
| A6220 |  | Excavación manual para instalación de bordillos y cimentaciones |  | 5d | 2025-04-05 | 2025-04-09 | A6210 SS | 17d | 0d |  | 2.5 | 10.88 | m3 |  | 0 |  | 0 |  | 0 |
| A6230 |  | Desbroce y remoción de suelo vegetal con equipo |  | 5d | 2025-04-05 | 2025-04-09 | A6220 SS | 17d | 0d |  |  | 81.86 | m2 |  | 0 |  | 0 |  | 0 |
| A6240 |  | Transporte de material excedente a DME, d=1km |  | 5d | 2025-04-05 | 2025-04-09 | A6230 SS | 17d | 0d |  |  | 9.57 | m3xkm |  | 0 |  | 0 |  | 0 |
| A6250 |  | Transporte de material excedente a DME, d>1km |  | 5d | 2025-04-05 | 2025-04-09 | A6240 SS | 17d | 0d |  |  | 6.09 | m3xkm |  | 0 |  | 0 |  | 0 |
| A6260 |  | Transporte de material excedente a DMO, d=1km |  | 5d | 2025-04-05 | 2025-04-09 | A6250 SS | 17d | 0d |  |  | 36.02 | m3xkm |  | 0 |  | 0 |  | 0 |
| A6270 |  | Transporte de material excedente a DMO, d>1km |  | 5d | 2025-04-05 | 2025-04-09 | A6260 SS | 17d | 0d |  |  | 18.83 | m3xkm |  | 0 |  | 0 |  | 0 |
|  | 2 | **PAVIMENTOS, RECUBRIMIENTOS Y BORDILLOS** |  |  | 2025-04-10 | 2025-04-23 |  |  |  |  |  |  |  |  |  |  |  |  |  |
| A6280 |  | Piso tierra apisonada (h=0.30cm) |  | 5d | 2025-04-10 | 2025-04-14 | A6270 | 17d | 0d |  | 25 | 100.58 | m2 |  | 0 |  | 0 |  | 0 |
| A6290 |  | Piso de gravilla |  | 2d | 2025-04-15 | 2025-04-16 | A6280 | 17d | 0d |  | 100 | 65.3 | m2 |  | 0 |  | 0 |  | 0 |
| A6300 |  | Recubrimiento de piedra del lugar e=0.05cm |  | 2d | 2025-04-17 | 2025-04-18 | A6290 | 17d | 0d |  | 40 | 12.24 | m2 |  | 0 |  | 0 |  | 0 |
| A6310 |  | Bordillos de piedra del lugar |  | 5d | 2025-04-19 | 2025-04-23 | A6300 | 17d | 0d |  | 50 | 181.33 | m |  | 0 |  | 0 |  | 0 |

| ID | WBS | Activity | Duration | Start | Finish | Predecessors | Total float | Free float | Metrado | Unidad | RCuad | Cuadrilla día | FDur | Rendimiento |
| --- | --- | --- | --- | --- | --- | --- | --- | --- | --- | --- | --- | --- | --- | --- |
|  | 3 | **MOBILIARIOS** |  | 2025-04-24 | 2025-04-28 |  |  |  |  |  |  |  |  |  |
| A6320 |  | Bancas de concreto, incluye cimentación | 5d | 2025-04-24 | 2025-04-28 | A6310 | 17d | 0d | 3 | und | 0 | 0 | 0 |  |
| A6330 |  | Señaletica informativa | 5d | 2025-04-24 | 2025-04-28 | A6320 SS | 53d | 0d | 1 | und | 0 | 0 | 0 |  |
| A6340 |  | Bolardos de piedra | 5d | 2025-04-24 | 2025-04-28 | A6330 SS | 53d | 0d | 22 | und | 0 | 0 | 0 |  |
|  | 4 | **OBRAS PRELIMINARES PAISAJISMO** |  | 2025-04-29 | 2025-05-08 |  |  |  |  |  |  |  |  |  |
| A6350 |  | Mejoramiento de suelo con tierra de chacra | 2d | 2025-04-29 | 2025-04-30 | A6340 | 53d | 0d | 40.93 | m3 | 0 | 0 | 0 | 56.25 |
| A6360 |  | Ubicación y delimitación de zona de plantación | 1d | 2025-05-01 | 2025-05-01 | A6350 | 53d | 0d | 48.37 | m | 0 | 0 | 0 | 150 |
| A6370 |  | Despedregado y rastrillado del terreno con medios manuales | 5d | 2025-05-02 | 2025-05-06 | A6360 | 53d | 0d | 109.96 | m2 | 0 | 0 | 0 | 37.5 |
| A6380 |  | Trazado y marcación de especies vegetales | 1d | 2025-05-07 | 2025-05-07 | A6370 | 53d | 0d | 109.96 | m2 | 0 | 0 | 0 | 1000 |
| A6390 |  | Retiro de residuos solidos | 1d | 2025-05-08 | 2025-05-08 | A6380 | 53d | 0d | 4.09 | m3 | 0 | 0 | 0 | 600 |
|  | 5 | **INSTALACIÓN DE PLANTONES (incluye colocación de sustrato, tierra del lugar, tutores y excavación)** |  | 2025-05-09 | 2025-06-11 |  |  |  |  |  |  |  |  |  |
| A6400 |  | Suministro e instalación de Prosopis pallida kunth algarrobo (0.80 a 1.50m) | 1d | 2025-05-09 | 2025-05-09 | A6390 | 53d | 0d | 1 | und | 0 | 0 | 0 |  |
| A6410 |  | Suministro e instalación de Acacia macracantha faique (0.80 a 1.50m) | 1d | 2025-05-10 | 2025-05-10 | A6400 | 53d | 0d | 4 | und | 0 | 0 | 0 |  |
| A6420 |  | Suministro e instalación de Tessaria integrifolia ruiz & pav pajarro bobo (0.80 a 1.50m) | 2d | 2025-05-11 | 2025-05-12 | A6410 | 53d | 0d | 10 | und | 0 | 0 | 0 |  |
| A6430 |  | Suministro e instalación de Encelia canescen girasol silvestre (0.20m a 0.30m) | 30d | 2025-05-13 | 2025-06-11 | A6420 | 53d | 0d | 172 | und | 0 | 0 | 0 |  |
|  | 6 | **INSTALACIÓN DE ALCORQUES** |  | 2025-06-12 | 2025-06-12 |  |  |  |  |  |  |  |  |  |
| A6440 |  | Alcorques de piedra de canto rodado para arboles | 1d | 2025-06-12 | 2025-06-12 | A6430 | 53d | 0d | 3 | und | 0 | 0 | 0 | 5 |
|  | 7 | **RIEGO DE ESPECIES 03 MESES ( instalacion+establecimiento)** |  | 2025-06-13 | 2025-09-10 |  |  |  |  |  |  |  |  |  |
| A6450 |  | Alquileres mensuales de cisternas de 20m3 para riego por inundacion | 90d | 2025-06-13 | 2025-09-10 | A6440 | 53d | 0d | 3 | mes | 0 | 0 | 0 |  |
|  | 8 | **MANTENIMIENTO PREVENTIVO PARA ESTABLECIMIENTO DE ESPECIE (03 meses)** |  | 2025-06-13 | 2025-09-10 |  |  |  |  |  |  |  |  |  |
| A6460 |  | Mantenimiento de especies y personal de riego | 90d | 2025-06-13 | 2025-09-10 | A6450 SS | 53d | 0d | 3 | mes | 0 | 0 | 0 |  |
